# DELTA STER SALE

Schedule from GanttProject, 2024-06-24 to 2024-07-11.

## Calendars

- Project calendar: Mon-Fri working; Sat-Sun off.

## Schedule

| ID | WBS | Task | Duration | Start | Finish | Intervenant |
| --- | --- | --- | --- | --- | --- | --- |
| 1 | 1 | **DELTA STER SALE** | 14d | 2024-06-24 | 2024-07-11 |  |
| 2 | 1.1 | **PHASE 1** | 10d | 2024-06-24 | 2024-07-05 |  |
| 3 | 1.1.1 | A-Vider le local | 1d | 2024-06-24 | 2024-06-24 | Ster |
| 4 | 1.1.2 | A-Adapt arrivées d'eau+carottage+installation décharge | 1d | 2024-06-25 | 2024-06-25 | Vervaert |
| 5 | 1.1.3 | A-AC (Heyer) | 1d | 2024-06-25 | 2024-06-25 | Heyer |
| 6 | 1.1.4 | A-Electricité | 1d | 2024-06-26 | 2024-06-26 | Equans |
| 7 | 1.1.5 | A-Installation prises data | 1d | 2024-06-26 | 2024-06-26 | Equans |
| 8 | 1.1.6 | A-Placement Décochoc | 2d | 2024-06-26 | 2024-06-27 | Isotrim |
| 9 | 1.1.7 | A-Intégration d'une vitre étanche (si possible) | 2d | 2024-06-27 | 2024-06-28 | Isotrim |
| 10 | 1.1.8 | Jours réserves | 2d | 2024-07-01 | 2024-07-02 |  |
| 11 | 1.1.9 | A&C-HVAC upgrade | 9d | 2024-06-25 | 2024-07-05 | TerraElec |
| 12 | 1.2 | **PHASE 2 - Utlrasons OK/éviers HS - B** | 6d | 2024-07-01 | 2024-07-08 |  |
| 13 | 1.2.1 | B-Installation d'une cloison provisoire (bâche) | 1d | 2024-07-01 | 2024-07-01 | Serv. Tech |
| 14 | 1.2.2 | B-Prépa des différents tech dans Fx-Pl,etc | 2d | 2024-07-01 | 2024-07-02 | Equans |
| 15 | 1.2.3 | B-Montage 2 cloisons dans couloir (D.A02_O06.02) | 1d | 2024-07-01 | 2024-07-01 | Serv. Tech |
| 16 | 1.2.4 | B-Dém. évier et deconnexions (Rotation évier) dans couloir | 1d | 2024-07-03 | 2024-07-03 | Ultrasonic |
| 17 | 1.2.5 | B-Prépa des différents tech dans Fx-Pl,etc | 2d | 2024-07-03 | 2024-07-04 | Heyer |
| 18 | 1.2.6 | B-Adaptation des techniques | 2d | 2024-07-03 | 2024-07-04 | Heyer |
| 19 | 1.2.7 | B-Adaptation des techniques | 2d | 2024-07-03 | 2024-07-04 | Vervaert |
| 20 | 1.2.8 | B-Adaptation des techniques | 2d | 2024-07-03 | 2024-07-04 | Equans |
| 21 | 1.2.9 | **B&C-Localc C vers B - nuit du 3 au 4 juillet** | 2d | 2024-07-03 | 2024-07-04 |  |
| 22 | 1.2.9.1 | Coupure eau stérille à partir de 22h00 | 2d | 2024-07-03 | 2024-07-04 | Vervaert |
| 23 | 1.2.9.2 | B-Prépa des différents tech dans Fx-Pl,etc | 2d | 2024-07-03 | 2024-07-04 | Vervaert |
| 24 | 1.2.9.3 | remonatge des tuyaux | 2d | 2024-07-03 | 2024-07-04 | Vervaert |
| 25 | 1.2.9.4 | Enlevement de l'ancienne décharge | 2d | 2024-07-03 | 2024-07-04 | Vervaert |
| 26 | 1.2.9.5 | Mise en place de la nouvelle alimentation B | 2d | 2024-07-03 | 2024-07-04 | Vervaert |
| 27 | 1.2.9.6 | B-Décharge B selon cotes | 2d | 2024-07-03 | 2024-07-04 | Vervaert |
| 28 | 1.2.9.7 | C-Preparation tuyaux d'eau en attente C | 2d | 2024-07-03 | 2024-07-04 | Vervaert |
| 29 | 1.2.10 | Transfert Ultrasons C vers B et raccordement | 1d | 2024-07-05 | 2024-07-05 | Celio/Sterima |
| 30 | 1.2.11 | C-1 jour durant lequel manque 1 Ultrason | 1d | 2024-07-05 | 2024-07-05 |  |
| 31 | 1.2.12 | A&C-TRAVAIL DE NUIT du 5 au 6/07 | 2d | 2024-07-05 | 2024-07-08 |  |

| ID | WBS | Task | Duration | Start | Finish | Intervenant |
| --- | --- | --- | --- | --- | --- | --- |
| 32 | 1.3 | **PHASE 3 Ultrasons OK** | 7d | 2024-07-03 | 2024-07-11 |  |
| 33 | 1.3.1 | C-Déconnexion techniques et connection vers A nuit 4 au 5 | 2d | 2024-07-05 | 2024-07-08 | Vervaert |
| 34 | 1.3.2 | C-Déconnexion techniques | 2d | 2024-07-03 | 2024-07-04 | Heyer |
| 35 | 1.3.3 | C-Installation d'une cloison provisoire | 1d | 2024-07-05 | 2024-07-05 | Serv. Tech |
| 36 | 1.3.4 | C-Déconnexion techniques | 3d | 2024-07-05 | 2024-07-09 | Equans |
| 37 | 1.3.5 | D-Ouverture de la cloison et ragréage entre A&C | 2d | 2024-07-08 | 2024-07-09 | Isotrim |
| 38 | 1.3.6 | A-Démontage porte+fermeture+Décochoc | 2d | 2024-07-08 | 2024-07-09 | Isotrim |
| 39 | 1.3.7 | Démontage cloison provisoire (tôt le matin) | 1d | 2024-07-10 | 2024-07-10 |  |
| 40 | 1.3.8 | A-Transfert et raccordement de l'évier | 1d | 2024-07-10 | 2024-07-10 | Ultrasonic |
| 41 | 1.4 | PHASE 4 - a organiser lors d'un long week-end | 1d | 2024-06-27 | 2024-06-27 |  |
