Schedule from GanttProject, 2021-02-12 to 2021-03-25.
Holidays every year on 01-01, 01-06, 05-01, 08-15, 10-03, 10-31, 11-01, 12-25, 12-26

## Calendars

- Project calendar: Mon-Fri working; Sat-Sun off.

## Resources

| Resource | Rate |
| --- | --- |
| Nils Thomsen | 60 |
| Leerlauf |  |

## Schedule

| ID | WBS | Task | Type | Duration | Start | Finish | Predecessors | Resources |
| --- | --- | --- | --- | --- | --- | --- | --- | --- |
| 1 | 1 | **Projekt 1** |  | 29d | 2021-02-12 | 2021-03-24 |  |  |
| 2 | 1.1 | **Vorgaben** |  | 1d | 2021-02-12 | 2021-02-12 |  |  |
| 3 | 1.1.1 | Prüfvorgaben mit Entwicklung klären |  | 1d | 2021-02-12 | 2021-02-12 |  | Nils Thomsen |
| 4 | 1.1.2 | Prüfmethodik definieren |  | 1d | 2021-02-12 | 2021-02-12 |  | Nils Thomsen |
| 5 | 1.2 | **Planung** |  | 3d | 2021-02-17 | 2021-02-19 | 2 |  |
| 6 | 1.2.1 | **Planung Mechanik** |  | 2d | 2021-02-17 | 2021-02-18 |  |  |
| 7 | 1.2.1.1 | Lastenheft |  | 1d | 2021-02-17 | 2021-02-17 |  | Nils Thomsen |
| 8 | 1.2.1.2 | Pflichtenheft |  | 1d | 2021-02-18 | 2021-02-18 | 7 | Nils Thomsen |
| 9 | 1.2.2 | **Planung Elektrotechnik** |  | 1d | 2021-02-19 | 2021-02-19 | 6 |  |
| 10 | 1.2.2.1 | Entwurf Schaltschrank |  | 1d | 2021-02-19 | 2021-02-19 |  | Nils Thomsen [50%] |
| 11 | 1.2.2.2 | Entwurf Messkarte |  | 1d | 2021-02-19 | 2021-02-19 |  | Nils Thomsen [50%] |
| 12 | 1.3 | Meilenstein Planung | milestone | 0d | 2021-02-22 | 2021-02-22 | 5 |  |
| 13 | 1.4 | **Materialbeschaffung** |  | 4d | 2021-02-23 | 2021-02-26 | 12 | Leerlauf |
| 14 | 1.4.1 | Zulauf Teststand / Prüfadapter |  | 4d | 2021-02-23 | 2021-02-26 | 17SF |  |
| 15 | 1.4.2 | Zulauf mechanische Komponenten |  | 3d | 2021-02-23 | 2021-02-25 | 17SF |  |
| 16 | 1.4.3 | Zulauf elektrotechnische Komponenten |  | 2d | 2021-02-23 | 2021-02-24 | 17SF |  |
| 17 | 1.4.4 | Überprüfung Material |  | 2d | 2021-02-25 | 2021-02-26 |  | Nils Thomsen |
| 18 | 1.5 | Meilenstein Materialbeschaffung | milestone | 0d | 2021-03-01 | 2021-03-01 | 13 |  |
| 19 | 1.6 | **Aufbau** |  | 3d | 2021-03-15 | 2021-03-17 | 18FS-10d |  |
| 20 | 1.6.1 | **Aufbau Mechanik** |  | 1d | 2021-03-15 | 2021-03-15 |  |  |
| 21 | 1.6.1.1 | Zusammenbau Teststand |  | 1d | 2021-03-15 | 2021-03-15 |  | Nils Thomsen |
| 22 | 1.6.2 | **Aufbau Elektrotechnik** |  | 2d | 2021-03-15 | 2021-03-16 |  |  |
| 23 | 1.6.2.1 | Verdrahtung und Beschriftung Schaltschrank |  | 1d | 2021-03-15 | 2021-03-15 |  | Nils Thomsen |
| 24 | 1.6.2.2 | Anbau Schaltschrank |  | 1d | 2021-03-16 | 2021-03-16 | 23 | Nils Thomsen |
| 25 | 1.6.3 | Hardwareansteuerung & Utility |  | 1d | 2021-03-17 | 2021-03-17 | 20, 22 | Nils Thomsen |
| 26 | 1.7 | Meilenstein Aufbau | milestone | 0d | 2021-03-18 | 2021-03-18 | 19 |  |
| 27 | 1.8 | Inbetriebnahme Teststand |  | 1d | 2021-03-18 | 2021-03-18 | 26 | Nils Thomsen |

| ID | WBS | Task | Type | Duration | Start | Finish | Predecessors | Resources |
| --- | --- | --- | --- | --- | --- | --- | --- | --- |
| 28 | 1.9 | **Programmierung** |  | 2d | 2021-03-19 | 2021-03-22 | 27 |  |
| 29 | 1.9.1 | Programmierung der Testschritte |  | 1d | 2021-03-19 | 2021-03-19 |  | Nils Thomsen |
| 30 | 1.9.2 | Einbau in Testinterface |  | 1d | 2021-03-22 | 2021-03-22 | 29 | Nils Thomsen |
| 31 | 1.10 | Prüfung Nullserie |  | 1d | 2021-03-23 | 2021-03-23 | 28 | Nils Thomsen |
| 32 | 1.11 | **Dokumentation** |  | 1d | 2021-03-24 | 2021-03-24 | 31 |  |
| 33 | 1.11.1 | Erstellung elektrotechnischer Dokumentation |  | 1d | 2021-03-24 | 2021-03-24 |  | Nils Thomsen [33.33%] |
| 34 | 1.11.2 | Erstellung Programmdokumentation |  | 1d | 2021-03-24 | 2021-03-24 |  | Nils Thomsen [33.33%] |
| 35 | 1.11.3 | Erstellung Prüfanweisung |  | 1d | 2021-03-24 | 2021-03-24 |  | Nils Thomsen [33.33%] |
| 36 | 1.12 | Meilenstein Auslieferung | milestone | 0d | 2021-03-25 | 2021-03-25 | 32 |  |
