# FT231501-CTT3x2-rev00 proposta BD

Schedule from GanttProject, 2024-02-19 to 2024-04-29.
Gru Comedil

## Calendars

- Project calendar: Mon-Fri working; Sat-Sun off. Exceptions (off unless hours are given): 2024-03-04, 2024-03-15, 2024-03-22, 2024-03-29, 2024-03-31 to 2024-04-01, 2024-04-25.

## Schedule

| ID | WBS | Task | Type | Duration | Start | Finish | Predecessors | Complete |
| --- | --- | --- | --- | --- | --- | --- | --- | --- |
| 1 | 1 | **Structures-Design & 1st Article for Prototype--** |  | 18d | 2024-02-19 | 2024-03-14 |  | 100% |
| 2 | 1.1 | **Other Jib Section-new TB08 *--** |  | 2d | 2024-02-19 | 2024-02-20 |  | 100% |
| 3 | 1.1.1 | TB08-BOMs,Drawings, Specs for 1st Article production-F2-ENG-C |  | 2d | 2024-02-19 | 2024-02-20 |  | 100% |
| 4 | 1.2 | **Other Jib Section-new TB09 *--** |  | 2d | 2024-02-21 | 2024-02-22 |  | 100% |
| 5 | 1.2.1 | TB09-BOMs,Drawings, Specs for 1st Article production-F2-ENG-C |  | 2d | 2024-02-21 | 2024-02-22 | 3 | 100% |
| 6 | 1.3 | **Other Jib Section-new TB38 *--** |  | 5d | 2024-02-23 | 2024-02-29 |  | 100% |
| 7 | 1.3.1 | TB38-BOMs,Drawings, Specs for 1st Article production-F2-ENG-C |  | 5d | 2024-02-23 | 2024-02-29 | 5 | 100% |
| 8 | 1.4 | **Other Jib Section-new TB37 *--** |  | 3d | 2024-03-01 | 2024-03-06 |  | 100% |
| 9 | 1.4.1 | TB37-BOMs,Drawings, Specs or 1st Article production-F2-ENG-C |  | 3d | 2024-03-01 | 2024-03-06 | 7 | 100% |
| 10 | 1.5 | **Other Jib Section-new TB36 *--** |  | 6d | 2024-03-07 | 2024-03-14 |  | 100% |
| 11 | 1.5.1 | TB36-BOMs,Drawings, Specs for 1st Article production-F2-ENG-C |  | 6d | 2024-03-07 | 2024-03-14 | 9 | 100% |
| 12 | 2 | **Other Jib Section-new TB34 *--** |  | 5d | 2024-03-26 | 2024-04-03 |  |  |
| 13 | 2.1 | TB34-BOMs,Drawings, Specs for 1st Article production-F2-ENG-C |  | 5d | 2024-03-26 | 2024-04-03 | 16 |  |
| 14 | 3 | **Other Jib Section-new TB35 *--** |  | 42d | 2024-02-19 | 2024-04-23 |  | 92% |
| 15 | 3.1 | TB35-Calculations & Docs for regulatory Technical File-F2-ENG-C |  | 1d | 2024-02-19 | 2024-02-19 |  |  |
| 16 | 3.2 | TB35-BOMs,Drawings, Specs for 1st Article production-F2-ENG-C (Carpenteria) |  | 5d | 2024-03-18 | 2024-03-25 | 11, 15 | 100% |
| 17 | 3.3 | TB35-Evaluation & Choice of Suppliers-F2-MTS |  | 1d | 2024-03-26 | 2024-03-26 | 16 |  |
| 18 | 3.4 | TB35-1st Article Production, Inspection, Review, Acceptance-F3-MTS |  | 18d | 2024-03-27 | 2024-04-23 | 17 | 100% |
| 19 | 4 | gate 2 | milestone | 0d | 2024-04-29 | 2024-04-29 | 18FS+2d |  |

Notes:
- 3: -In collaborazione con SBR. / -ECN 6130 notifica 23/02/2024
- 5: -In collaborazione con SBR. / -ECN 6130 notifica 23/02/2024
- 7: -In collaborazione con SBR. / -ECN 6130 notifica 06/03/2024
- 9: -In collaborazione con SBR. / -ECN 6130 notifica 06/03/2024
- 11: -In collaborazione con SBR / -Attività completata con emissione ECN6130
- 13: -Incluso disegno costruttivo. In collaborazione con SBR
- 16: -Incluso disegno costruttivo. In collaborazione con SBR / --Attività completata con emissione ECN6130
