# Residence for Riyas & Bushra

Schedule from GanttProject, 2023-12-15 to 2024-10-29.
iBeam Ventures LLP
Holidays every year on 01-26, 04-14, 08-15, 10-02, 11-01, 12-25

## Calendars

- Project calendar: Mon-Sat working; Sun off.

## Schedule

| ID | WBS | Task | Type | Duration | Start | Finish | Predecessors | Payment | Stage |
| --- | --- | --- | --- | --- | --- | --- | --- | --- | --- |
| 1 | 1 | Site Clearing | milestone | 0d | 2023-12-15 | 2023-12-15 |  | Rs. 6,00,000/- | 1.0 |
| 2 | 2 | **Foundation** |  | 26d | 2023-12-21 | 2024-01-20 | 1 |  |  |
| 3 | 2.1 | Earth Excavation |  | 2d | 2023-12-21 | 2023-12-22 |  |  |  |
| 4 | 2.2 | PCC |  | 1d | 2023-12-23 | 2023-12-23 | 3 |  |  |
| 5 | 2.3 | Foundation DRM |  | 2d | 2023-12-29 | 2023-12-30 | 4FS+3d |  |  |
| 6 | 2.4 | Basement RRM |  | 4d | 2024-01-03 | 2024-01-06 | 5FS+2d |  |  |
| 7 | 2.5 | Earth Filling |  | 3d | 2024-01-12 | 2024-01-15 | 6FS+4d |  |  |
| 8 | 2.6 | Plinth Belt Work |  | 4d | 2024-01-17 | 2024-01-20 | 7FS+1d |  |  |
| 9 | 3 | **Joinery Works** |  | 208d | 2024-01-08 | 2024-09-07 |  |  |  |
| 10 | 3.1 | Purchase & Drying Period |  | 10d | 2024-01-08 | 2024-01-18 |  | Rs. 3,00,000/- | 2.0 |
| 11 | 3.2 | Joinery Frame Work_GF |  | 7d | 2024-01-19 | 2024-01-27 | 10 |  |  |
| 12 | 3.3 | Joinery Frame Work_FF |  | 1d | 2024-03-23 | 2024-03-23 | 19FS+2d |  |  |
| 13 | 3.4 | Finshing Joinery Purchase |  | 7d | 2024-08-13 | 2024-08-21 | 30FS+5d |  |  |
| 14 | 3.5 | Joinery Finishing |  | 5d | 2024-09-03 | 2024-09-07 | 40FS+1d |  |  |
| 15 | 4 | **GF Superstructure** |  | 40d | 2024-02-03 | 2024-03-20 | 2FS+10d |  |  |
| 16 | 4.1 | Block Work upto Lintel |  | 10d | 2024-02-03 | 2024-02-14 | 2FS+10d, 11FS+1d | Rs. 6,00,000/- | 3.0 |
| 17 | 4.2 | Lintel & Shade |  | 8d | 2024-02-17 | 2024-02-26 | 16FS+2d |  |  |
| 18 | 4.3 | Block Work upto Roof |  | 3d | 2024-03-04 | 2024-03-06 | 17FS+5d |  |  |
| 19 | 4.4 | Roof Shuttering & Conrete |  | 10d | 2024-03-09 | 2024-03-20 | 18FS+2d |  |  |
| 20 | 5 | **FF Superstructure** |  | 41d | 2024-04-06 | 2024-05-23 | 12FS+1d |  |  |
| 21 | 5.1 | Block Work upto Lintel |  | 10d | 2024-04-06 | 2024-04-17 | 12FS+1d, 15FS+14d | Rs. 5,00,000/- | 4.0 |
| 22 | 5.2 | Lintel & Shade |  | 8d | 2024-04-20 | 2024-04-29 | 21FS+2d |  |  |
| 23 | 5.3 | Block Work upto Roof |  | 4d | 2024-05-06 | 2024-05-09 | 22FS+5d |  |  |
| 24 | 5.4 | Roof Shuttering & Conrete |  | 10d | 2024-05-13 | 2024-05-23 | 23FS+2d |  |  |

| ID | WBS | Task | Type | Duration | Start | Finish | Predecessors | Payment | Stage |
| --- | --- | --- | --- | --- | --- | --- | --- | --- | --- |
| 25 | 6 | **Electrical Works** |  | 104d | 2024-05-24 | 2024-09-23 | 15FS+14d, 20 |  |  |
| 26 | 6.1 | Concealed Work_GF |  | 7d | 2024-05-24 | 2024-05-31 | 15FS+14d, 20SS | Rs. 3,00,000/- | 5.0 |
| 27 | 6.2 | Concealed Work_FF |  | 6d | 2024-06-03 | 2024-06-08 | 20FF+14d, 26 |  |  |
| 28 | 6.3 | Wiring |  | 7d | 2024-09-13 | 2024-09-20 | 9, 41FS+2d | Rs. 3,00,000/- | 11.0 |
| 29 | 6.4 | Installing Fixtures |  | 4d | 2024-09-19 | 2024-09-23 |  |  |  |
| 30 | 7 | **Grey Finishing** |  | 57d | 2024-06-01 | 2024-08-06 |  |  |  |
| 31 | 7.1 | Anti Termite |  | 1d | 2024-06-01 | 2024-06-01 | 26 |  |  |
| 32 | 7.2 | GF Floor Concrete |  | 2d | 2024-06-05 | 2024-06-06 | 31FS+2d | Rs. 6,00,000/- | 6.0 |
| 33 | 7.3 | GF Plastering |  | 35d | 2024-06-10 | 2024-07-19 | 1, 32FS+2d |  |  |
| 34 | 7.4 | FF Plastering |  | 40d | 2024-06-21 | 2024-08-06 | 20FS+14d, 27FS+1d, 32FS+2d, 33SS+10d, 36FS+2d |  |  |
| 35 | 8 | **Miscellaneous Works** |  | 81d | 2024-06-10 | 2024-09-12 |  |  |  |
| 36 | 8.1 | Truss Work for Roof |  | 7d | 2024-06-10 | 2024-06-17 | 20FS+14d | Rs. 3,00,000/- | 7.0 |
| 37 | 8.2 | Handrails |  | 1d | 2024-08-06 | 2024-08-06 | 30FF |  |  |
| 38 | 8.3 | Roof Tile Laying |  | 5d | 2024-09-07 | 2024-09-12 | 28SF, 36FS+5d | Rs. 3,00,000/- | 10.0 |
| 39 | 9 | **Painting** |  | 51d | 2024-08-27 | 2024-10-25 | 30FS+7d |  |  |
| 40 | 9.1 | White washing |  | 5d | 2024-08-27 | 2024-08-31 | 30FS+7d, 45FS+2d | Rs. 3,00,000/- | 9.0 |
| 41 | 9.2 | Primer |  | 7d | 2024-09-03 | 2024-09-10 | 40FS+1d |  |  |
| 42 | 9.3 | Interior Painting |  | 1d | 2024-10-09 | 2024-10-09 | 49FS+3d |  |  |
| 43 | 9.4 | Exterior Painting |  | 12d | 2024-10-12 | 2024-10-25 | 42SS+3d |  |  |
| 44 | 10 | **Plumbing Work** |  | 48d | 2024-08-16 | 2024-10-11 |  |  |  |
| 45 | 10.1 | Interior Concealed |  | 5d | 2024-08-16 | 2024-08-21 | 30FF+2d | Rs. 3,00,000/- | 8.0 |
| 46 | 10.2 | Exterior Works |  | 4d | 2024-08-30 | 2024-09-03 | 45FS+5d |  |  |
| 47 | 10.3 | Installing Fixtures |  | 3d | 2024-10-09 | 2024-10-11 | 42SS, 49FS+2d |  |  |
| 48 | 11 | **Tiling Work** |  | 21d | 2024-09-23 | 2024-10-17 | 28FS+1d, 41FS+2d |  |  |
| 49 | 11.1 | Tile Laying |  | 10d | 2024-09-23 | 2024-10-04 | 28FS+1d, 41FS+2d | Rs. 3,00,000/- | 12.0 |
| 50 | 11.2 | Pointing & Finishing |  | 2d | 2024-10-16 | 2024-10-17 | 42FS+5d |  |  |
| 51 | 12 | Ready to Move-in | milestone | 0d | 2024-10-29 | 2024-10-29 | 39FS+2d | Balance | 13.0 |
