Schedule from GanttProject, 2025-02-17 to 2025-06-16.

## Calendars

- Project calendar: Mon-Fri working; Sat-Sun off.

## Schedule

| ID | WBS | Task | Duration | Start | Finish | Predecessors |
| --- | --- | --- | --- | --- | --- | --- |
| 1 | 1 | **Steel Shed** | 4d | 2025-02-24 | 2025-02-27 |  |
| 2 | 1.1 | Remove contents of shed | 2d | 2025-02-24 | 2025-02-25 |  |
| 3 | 1.2 | Dismantle shed | 2d | 2025-02-26 | 2025-02-27 | 2 |
| 4 | 2 | **New west-side lean-to** | 4d | 2025-02-17 | 2025-02-20 |  |
| 5 | 2.1 | clear of all obstructions | 1d | 2025-02-17 | 2025-02-17 |  |
| 6 | 2.2 | framing | 1d | 2025-02-18 | 2025-02-18 | 5 |
| 7 | 2.3 | gutters & drainage | 1d | 2025-02-19 | 2025-02-19 | 6 |
| 8 | 2.4 | polycarbonate roof sheeting | 1d | 2025-02-20 | 2025-02-20 | 7 |
| 9 | 3 | **Loggia** | 9d | 2025-02-21 | 2025-03-05 |  |
| 10 | 3.1 | Clear driveway obstructions | 1d | 2025-02-21 | 2025-02-21 |  |
| 11 | 3.2 | Dismantle existing loggia | 3d | 2025-02-28 | 2025-03-04 | 3, 10 |
| 12 | 3.3 | Remove artificial turf sheet | 1d | 2025-03-05 | 2025-03-05 | 11 |
| 13 | 4 | **Pool construction** | 56d | 2025-03-31 | 2025-06-16 |  |
| 14 | 4.1 | Excavation | 2d | 2025-03-31 | 2025-04-01 |  |
| 15 | 4.2 | Formwork | 8d | 2025-04-02 | 2025-04-11 | 14 |
| 16 | 4.3 | Reinforcing | 3d | 2025-04-14 | 2025-04-16 | 15 |
| 17 | 4.4 | Plumbing rough-in | 3d | 2025-04-17 | 2025-04-21 | 16 |
| 18 | 4.5 | Electrical rough-in | 2d | 2025-04-22 | 2025-04-23 | 17 |
| 19 | 4.6 | Pour pool shell | 2d | 2025-04-24 | 2025-04-25 | 18 |
| 20 | 4.7 | cure shell | 28d | 2025-04-28 | 2025-06-04 | 19 |
| 21 | 4.8 | waterproofing | 1d | 2025-06-05 | 2025-06-05 | 20 |
| 22 | 4.9 | plumbing fit-off | 1d | 2025-06-06 | 2025-06-06 | 21 |
| 23 | 4.10 | tiling | 6d | 2025-06-09 | 2025-06-16 | 22 |
| 24 | 4.11 | equipment fit-off | 1d | 2025-06-09 | 2025-06-09 | 22 |
| 25 | 4.12 | commissioning | 1d | 2025-06-10 | 2025-06-10 | 24 |

| ID | WBS | Task | Duration | Start | Finish | Predecessors |
| --- | --- | --- | --- | --- | --- | --- |
| 26 | 5 | **Pool fencing** | 6d | 2025-06-05 | 2025-06-12 |  |
| 27 | 5.1 | spigots | 2d | 2025-06-05 | 2025-06-06 | 20 |
| 28 | 5.2 | fencing | 3d | 2025-06-09 | 2025-06-11 | 27 |
| 29 | 5.3 | gate | 1d | 2025-06-12 | 2025-06-12 | 28 |
| 30 | 6 | **Hard landscape** | 2d | 2025-06-06 | 2025-06-09 |  |
| 31 | 6.1 | Decking | 1d | 2025-06-06 | 2025-06-06 | 21 |
| 32 | 6.2 | Garden bed wall | 1d | 2025-06-06 | 2025-06-06 | 21 |
| 33 | 6.3 | Paving | 1d | 2025-06-09 | 2025-06-09 | 32 |
