# Sample Decimals Issue

Schedule from GanttProject, 2022-02-17 to 2022-10-21.

## Calendars

- Project calendar: Mon-Fri working; Sat-Sun off.

## Resources

| Resource | Group | Rate |
| --- | --- | --- |
| W | Vice President - Technical/Regional | 2120 |
| R | Associate | 1520 |
| M | Associate | 1520 |
| B | Associate | 1520 |
| G | Sr. CAD/BIM Tech. | 1320 |
| MEP | Senior Associate | 2000 |
| EE |  | 2000 |

## Schedule

| ID | WBS | Task | Duration | Start | Finish | Predecessors | Resources |
| --- | --- | --- | --- | --- | --- | --- | --- |
| 1 | 1 | **Concept Design** | 15d | 2022-02-17 | 2022-03-09 |  |  |
| 2 | 1.1 | Design team meetings | 2d | 2022-02-17 | 2022-02-18 |  | W [25%]; R [50%]; M [25%] |
| 3 | 1.2 | Choose initial concept | 2d | 2022-02-21 | 2022-02-22 | 2 | W [25%]; R [50%]; M [25%]; MEP [25%]; EE [25%] |
| 4 | 1.3 | General performance specifications | 2d | 2022-02-23 | 2022-02-24 | 3 | W [15%]; R [35%]; M [50%]; B [25%]; MEP [75%]; EE [75%] |
| 5 | 1.4 | Feasibility study | 6d | 2022-02-25 | 2022-03-04 | 4 | W [10%]; R [25%]; M [25%]; B [50%]; MEP [25%]; EE [25%] |
| 6 | 1.5 | Concept iteration | 2d | 2022-03-07 | 2022-03-08 | 5 | W [10%]; R [50%]; M [75%]; B [75%]; MEP [25%]; EE [25%] |
| 7 | 1.6 | Final recommendation | 1d | 2022-03-09 | 2022-03-09 | 6 | W [10%]; R [25%]; M [25%]; B [25%] |
| 8 | 2 | **Concept Design deliverable** | 5d | 2022-03-10 | 2022-03-16 |  |  |
| 9 | 2.1 | Final feasibility study | 4d | 2022-03-10 | 2022-03-15 | 7 | W [15%]; R [50%]; M [80%]; B [75%]; G [33%]; MEP [50%]; EE [50%] |
| 10 | 2.2 | Sketches to clarify study | 1d | 2022-03-16 | 2022-03-16 | 9 | R [25%]; M [25%]; B [25%]; G |
| 11 | 3 | **Schematic Design** | 23d | 2022-03-18 | 2022-04-19 | 1 |  |
| 12 | 3.1 | Design team meetings | 3d | 2022-03-18 | 2022-03-22 | 8FS+1d |  |
| 13 | 3.2 | Material studies | 4d | 2022-03-23 | 2022-03-28 | 12 |  |
| 14 | 3.3 | Optimize design | 10d | 2022-03-29 | 2022-04-11 | 13 |  |
| 15 | 3.4 | Revise performance specifications | 1d | 2022-04-13 | 2022-04-13 | 14FS+1d |  |
| 16 | 3.5 | Finalize model | 4d | 2022-04-14 | 2022-04-19 | 15 |  |
| 17 | 4 | **Schematic Design deliverable** | 6d | 2022-04-21 | 2022-04-28 |  |  |
| 18 | 4.1 | Report Summary | 4d | 2022-04-21 | 2022-04-26 | 16FS+1d |  |
| 19 | 4.2 | Schematic drawings | 2d | 2022-04-27 | 2022-04-28 | 18 |  |
| 20 | 5 | **Detailed Design** | 32d | 2022-05-03 | 2022-06-15 | 11 |  |
| 21 | 5.1 | Design team meetings | 3d | 2022-05-03 | 2022-05-05 | 19FS+2d |  |
| 22 | 5.2 | Finalize materials | 10d | 2022-05-06 | 2022-05-19 | 21 |  |
| 23 | 5.3 | Part recommendations and potential suppliers | 21d | 2022-05-06 | 2022-06-03 | 22SS |  |
| 24 | 5.4 | Update model | 8d | 2022-06-06 | 2022-06-15 | 23 |  |

| ID | WBS | Task | Duration | Start | Finish | Predecessors |
| --- | --- | --- | --- | --- | --- | --- |
| 25 | 6 | **Detail Design Deliverable** | 7d | 2022-06-16 | 2022-06-24 |  |
| 26 | 6.1 | Engineering report | 5d | 2022-06-16 | 2022-06-22 | 24 |
| 27 | 6.2 | Detail drawings | 5d | 2022-06-20 | 2022-06-24 | 26SS+2d |
| 28 | 6.3 | Book of Specifications | 4d | 2022-06-20 | 2022-06-23 | 27SS |
| 29 | 7 | **SBE and Mock Ups** | 48d | 2022-06-28 | 2022-09-01 | 20 |
| 30 | 7.1 | Design team meetings | 2d | 2022-06-28 | 2022-06-29 | 28FS+2d |
| 31 | 7.2 | Kinematic study | 5d | 2022-06-30 | 2022-07-06 | 30 |
| 32 | 7.3 | Multi-body physics study | 15d | 2022-07-07 | 2022-07-27 | 31 |
| 33 | 7.4 | Partial-scale mock up as POC | 2d | 2022-08-01 | 2022-08-02 | 32FS+2d |
| 34 | 7.5 | Iterate model | 2d | 2022-08-03 | 2022-08-04 | 33 |
| 35 | 7.6 | Full-scale mock up | 20d | 2022-08-05 | 2022-09-01 | 34 |
| 36 | 8 | **Tender Drawings** | 3d | 2022-09-07 | 2022-09-09 | 29FS+3d |
| 37 | 8.1 | Design team meetings | 3d | 2022-09-07 | 2022-09-09 | 35FS+3d |
| 38 | 9 | **Tender Drawings deliverable** | 30d | 2022-09-12 | 2022-10-21 |  |
| 39 | 9.1 | Special client requests | 5d | 2022-09-12 | 2022-09-16 | 37 |
| 40 | 9.2 | Construction drawings | 25d | 2022-09-19 | 2022-10-21 | 39 |
| 41 | 9.3 | Specifications book | 15d | 2022-09-19 | 2022-10-07 | 40SS |
| 42 | 9.4 | Erection method | 8d | 2022-09-19 | 2022-09-28 | 41SS |
