# NUOVO REPARTO PRODUZIONE E CONFEZIONAMENTO POLVERI

Schedule from GanttProject, 2021-02-01 to 2022-01-25, baseline: 20210204 - REV 00.
Biofarma

## Calendars

- Project calendar: Mon-Fri working; Sat-Sun off.

## Resources

| Resource | Rate |
| --- | --- |
| BIOFARMA |  |
| C&P |  |
| FIDENATO |  |
| IMPRESA CARPENTERIE |  |
| IMPRESA EDILE |  |
| MESTRONI |  |
| METALTOP |  |
| PRAVISANI |  |
| VAPORTERMICA |  |
| BERLASSO | 1 |
| Bertoli |  |
| GAIAMBIENTE |  |
| MESTRONI |  |
| MECC da assegnare |  |
| CARP da assegnare |  |
| ELE da assegnare |  |
| CIVILE FARMA da assegnare |  |

## Schedule

| ID | WBS | Task | Type | Duration | Start | Finish | Predecessors | Baseline start | Baseline finish | Baseline duration | Baseline 1 start | Baseline 1 finish | Resources | Cost |
| --- | --- | --- | --- | --- | --- | --- | --- | --- | --- | --- | --- | --- | --- | --- |
| 1 | 1 | **NUOVI REPARTI+FIALE** |  | 257d | 2021-02-01 | 2022-01-25 |  |  |  |  |  |  |  |  |
| 2 | 1.1 | **INGEGNERIA E SERVIZI** |  | 47d | 2021-03-09 | 2021-05-12 |  |  |  |  |  |  |  |  |
| 3 | 1.1.1 | **ORDINI INGEGNERIA** |  | 23d | 2021-03-09 | 2021-04-08 |  |  |  |  |  |  |  |  |
| 4 | 1.1.1.1 | Progettazione civile | milestone | 0d | 2021-03-09 | 2021-03-09 |  |  |  |  |  |  | PRAVISANI | 26,900 |
| 5 | 1.1.1.2 | Progettazione impianti | milestone | 0d | 2021-03-12 | 2021-03-12 |  |  |  |  |  |  | C&P | 139,000 |
| 6 | 1.1.1.3 | Prestazioni tecniche per modifiche UTA 10 | milestone | 0d | 2021-04-09 | 2021-04-09 |  |  |  |  |  |  | MECC da assegnare | 8,800 |
| 7 | 1.1.2 | **ORDINI PROFESSIONISTI** |  | 13d | 2021-03-09 | 2021-03-25 |  |  |  |  |  |  |  |  |
| 8 | 1.1.2.1 | Resp.Sicurezza | milestone | 0d | 2021-03-09 | 2021-03-09 |  |  |  |  |  |  | Bertoli | 19,000 |
| 9 | 1.1.2.2 | Collaudo statico | milestone | 0d | 2021-03-18 | 2021-03-18 |  |  |  |  |  |  | Bertoli | 1,940 |
| 10 | 1.1.2.3 | Direzione lavori | milestone | 0d | 2021-03-09 | 2021-03-09 |  |  |  |  |  |  | PRAVISANI | 20,500 |
| 11 | 1.1.2.4 | Analisi terreni | milestone | 0d | 2021-03-25 | 2021-03-25 |  |  |  |  |  |  | GAIAMBIENTE | 500 |
| 12 | 1.1.2.5 | Relazione scariche elettriche | milestone | 0d | 2021-03-26 | 2021-03-26 |  |  |  |  |  |  | FIDENATO | 400 |
| 13 | 1.1.3 | **PRATICA VVF** |  | 47d | 2021-03-09 | 2021-05-12 |  |  |  |  |  |  |  |  |
| 14 | 1.1.3.1 | ORDINE PER PRATICHE VVF | milestone | 0d | 2021-03-09 | 2021-03-09 |  | 2021-02-12 | 2021-02-12 | 0d | 2021-02-15 | 2021-02-15 | BERLASSO | 6,760 |
| 15 | 1.1.3.2 | **AUTORIZZAZIONE VVF - parere VVF** |  | 40d | 2021-03-18 | 2021-05-12 | 17 | 2021-02-15 | 2021-03-01 | 11d | 2021-02-15 | 2021-02-26 |  |  |
| 16 | 1.1.3.2.1 | parere VVF |  | 40d | 2021-03-18 | 2021-05-12 | 17 | 2021-02-23 | 2021-03-01 | 5d | 2021-02-23 | 2021-02-26 |  |  |
| 17 | 1.1.3.3 | **AUTORIZZAZIONE VVF - protocollo pratica** |  | 7d | 2021-03-09 | 2021-03-17 | 14 | 2021-02-15 | 2021-02-15 | 0d | 2021-02-15 | 2021-02-15 |  |  |
| 18 | 1.1.3.3.1 | verifica relazione |  | 7d | 2021-03-09 | 2021-03-17 | 14 |  |  |  |  |  |  |  |
| 19 | 1.1.3.3.2 | protocollo pratica | milestone | 0d | 2021-03-18 | 2021-03-18 | 18 |  |  |  |  |  |  |  |
| 20 | 1.1.3.4 | **AUTORIZZAZIONE VVF - riscontro VVF+SUAP** |  | 10d | 2021-03-18 | 2021-03-31 | 17 | 2021-02-15 | 2021-02-22 | 6d | 2021-02-15 | 2021-02-22 |  |  |
| 21 | 1.1.3.4.1 | riscontro VVF |  | 8d | 2021-03-18 | 2021-03-29 | 17 |  |  |  |  |  |  |  |
| 22 | 1.1.3.4.2 | riscontro SUAP |  | 2d | 2021-03-30 | 2021-03-31 | 21 |  |  |  |  |  |  |  |
| 23 | 1.1.4 | **AUTORIZZAZIONE COMUNE** |  | 26d | 2021-03-09 | 2021-04-13 |  |  |  |  |  |  |  |  |
| 24 | 1.1.4.1 | ORDINE PER PRATICHE COMUNE/ASL | milestone | 0d | 2021-03-09 | 2021-03-09 |  | 2021-02-12 | 2021-02-12 | 0d | 2021-02-15 | 2021-02-15 | PRAVISANI | 3,300 |

| ID | WBS | Task | Type | Duration | Start | Finish | Predecessors | Baseline start | Baseline finish | Baseline duration | Baseline 1 start | Baseline 1 finish | Constraint | Resources | Cost | Flag1 | Flag2 | Flag3 | Flag4 | Flag5 | Flag6 | Flag7 | Flag8 | Flag9 | Flag10 | Number1 | Number2 | Number3 | Number4 | Number5 | Budget | Cost3 | Cost4 | Cost5 | Cost6 | Cost7 | Cost8 | Cost9 | Cost10 | Flag11 | Flag12 | Flag13 | Flag14 | Flag15 | Flag16 | Flag17 | Flag18 | Flag19 | Flag20 | Number6 | Number7 | Number8 | Number9 | Number10 | Number11 | Number12 | Number13 | Number14 | Number15 | Number16 | Number17 | Number18 | Number19 | Number20 |
| --- | --- | --- | --- | --- | --- | --- | --- | --- | --- | --- | --- | --- | --- | --- | --- | --- | --- | --- | --- | --- | --- | --- | --- | --- | --- | --- | --- | --- | --- | --- | --- | --- | --- | --- | --- | --- | --- | --- | --- | --- | --- | --- | --- | --- | --- | --- | --- | --- | --- | --- | --- | --- | --- | --- | --- | --- | --- | --- | --- | --- | --- | --- | --- | --- |
| 25 | 1.1.4.2 | **deposito C.A.** |  | 26d | 2021-03-09 | 2021-04-13 | 24 |  |  |  |  |  |  |  |  |  |  |  |  |  |  |  |  |  |  |  |  |  |  |  |  |  |  |  |  |  |  |  |  |  |  |  |  |  |  |  |  |  |  |  |  |  |  |  |  |  |  |  |  |  |  |  |  |  |
| 26 | 1.1.4.2.1 | deposito C.A. |  | 26d | 2021-03-09 | 2021-04-13 | 24 |  |  |  |  |  |  | PRAVISANI |  |  |  |  |  |  |  |  |  |  |  |  |  |  |  |  |  |  |  |  |  |  |  |  |  |  |  |  |  |  |  |  |  |  |  |  |  |  |  |  |  |  |  |  |  |  |  |  |  |  |
| 27 | 1.1.4.3 | **PROGETTI IE per SCIA** |  | 8d | 2021-03-17 | 2021-03-26 |  |  |  |  |  |  |  |  |  |  |  |  |  |  |  |  |  |  |  |  |  |  |  |  |  |  |  |  |  |  |  |  |  |  |  |  |  |  |  |  |  |  |  |  |  |  |  |  |  |  |  |  |  |  |  |  |  |  |
| 28 | 1.1.4.3.1 | PROGETTI IE per SCIA |  | 8d | 2021-03-17 | 2021-03-26 |  |  |  |  |  |  |  | PRAVISANI |  |  |  |  |  |  |  |  |  |  |  |  |  |  |  |  |  |  |  |  |  |  |  |  |  |  |  |  |  |  |  |  |  |  |  |  |  |  |  |  |  |  |  |  |  |  |  |  |  |  |
| 29 | 1.1.4.4 | **PROGETTI IM per SCIA** |  | 8d | 2021-03-17 | 2021-03-26 |  |  |  |  |  |  |  |  |  |  |  |  |  |  |  |  |  |  |  |  |  |  |  |  |  |  |  |  |  |  |  |  |  |  |  |  |  |  |  |  |  |  |  |  |  |  |  |  |  |  |  |  |  |  |  |  |  |  |
| 30 | 1.1.4.4.1 | PROGETTI IM per SCIA |  | 8d | 2021-03-17 | 2021-03-26 |  |  |  |  |  |  |  | C&P |  |  |  |  |  |  |  |  |  |  |  |  |  |  |  |  |  |  |  |  |  |  |  |  |  |  |  |  |  |  |  |  |  |  |  |  |  |  |  |  |  |  |  |  |  |  |  |  |  |  |
| 31 | 1.1.4.5 | AUTORIZZAZIONE COMUNE (SCIA) | milestone | 0d | 2021-04-14 | 2021-04-14 | 17, 25, 27, 29 | 2021-02-12 | 2021-03-01 | 12d | 2021-02-15 | 2021-02-26 |  | PRAVISANI |  |  |  |  |  |  |  |  |  |  |  |  |  |  |  |  |  |  |  |  |  |  |  |  |  |  |  |  |  |  |  |  |  |  |  |  |  |  |  |  |  |  |  |  |  |  |  |  |  |  |
| 32 | 1.2 | **SPOSTAMENTO FIALE** |  | 50d | 2021-05-13 | 2021-07-21 | 13 |  |  |  |  |  |  |  |  |  |  |  |  |  |  |  |  |  |  |  |  |  |  |  |  |  |  |  |  |  |  |  |  |  |  |  |  |  |  |  |  |  |  |  |  |  |  |  |  |  |  |  |  |  |  |  |  |  |
| 33 | 1.2.1 | ORDINE VAPORTERMICA |  | 10d | 2021-05-13 | 2021-05-26 | 13 | 2021-01-14 | 2021-03-10 | 40d | 2021-01-11 | 2021-03-12 |  |  |  |  |  |  |  |  |  |  |  |  |  |  |  |  |  |  |  |  |  |  |  |  |  |  |  |  |  |  |  |  |  |  |  |  |  |  |  |  |  |  |  |  |  |  |  |  |  |  |  |  |
| 34 | 1.2.2 | ORDINE FIDENATO |  | 10d | 2021-05-13 | 2021-05-26 | 13 | 2021-01-14 | 2021-03-10 | 40d | 2021-01-11 | 2021-03-12 |  |  |  |  |  |  |  |  |  |  |  |  |  |  |  |  |  |  |  |  |  |  |  |  |  |  |  |  |  |  |  |  |  |  |  |  |  |  |  |  |  |  |  |  |  |  |  |  |  |  |  |  |
| 35 | 1.2.3 | ORDINE TOPPANO |  | 10d | 2021-05-13 | 2021-05-26 | 13 | 2021-01-14 | 2021-03-10 | 40d | 2021-01-11 | 2021-03-12 |  |  |  |  |  |  |  |  |  |  |  |  |  |  |  |  |  |  |  |  |  |  |  |  |  |  |  |  |  |  |  |  |  |  |  |  |  |  |  |  |  |  |  |  |  |  |  |  |  |  |  |  |
| 36 | 1.2.4 | INIZIO LAVORI FIALE | milestone | 0d | 2021-05-27 | 2021-05-27 | 33, 34, 35 | 2021-03-02 | 2021-03-02 | 0d | 2021-03-01 | 2021-03-01 |  |  |  |  |  |  |  |  |  |  |  |  |  |  |  |  |  |  |  |  |  |  |  |  |  |  |  |  |  |  |  |  |  |  |  |  |  |  |  |  |  |  |  |  |  |  |  |  |  |  |  |  |
| 37 | 1.2.5 | **FASE 2 - PRE - SPOSTAMENTO FIALE - LOCALE** |  | 25d | 2021-05-27 | 2021-06-30 | 36 | 2021-01-14 | 2021-04-28 | 75d | 2021-01-11 | 2021-04-09 |  |  |  |  |  |  |  |  |  |  |  |  |  |  |  |  |  |  |  |  |  |  |  |  |  |  |  |  |  |  |  |  |  |  |  |  |  |  |  |  |  |  |  |  |  |  |  |  |  |  |  |  |
| 38 | 1.2.5.1 | FASE 2 - PRE - SPOSTAMENTO FIALE - PARETI LOCALE |  | 10d | 2021-05-27 | 2021-06-09 | 36 | 2021-03-11 | 2021-03-24 | 10d | 2021-03-15 | 2021-03-26 |  | CARP da assegnare | 8,700 |  |  |  |  |  |  |  |  |  |  |  |  |  |  |  |  |  |  |  |  |  |  |  |  |  |  |  |  |  |  |  |  |  |  |  |  |  |  |  |  |  |  |  |  |  |  |  |  |  |
| 39 | 1.2.5.2 | FASE 2 - PRE - SPOSTAMENTO FIALE - IM |  | 15d | 2021-06-10 | 2021-06-30 | 38 | 2021-03-25 | 2021-04-07 | 10d | 2021-03-29 | 2021-04-09 |  | MECC da assegnare | 24,800 |  |  |  |  |  |  |  |  |  |  |  |  |  |  |  |  |  |  |  |  |  |  |  |  |  |  |  |  |  |  |  |  |  |  |  |  |  |  |  |  |  |  |  |  |  |  |  |  |  |
| 40 | 1.2.5.3 | FASE 2 - PRE - SPOSTAMENTO FIALE - IE |  | 10d | 2021-06-10 | 2021-06-23 | 38 | 2021-03-25 | 2021-04-07 | 10d | 2021-03-29 | 2021-04-09 |  | ELE da assegnare | 15,559 |  |  |  |  |  |  |  |  |  |  |  |  |  |  |  |  |  |  |  |  |  |  |  |  |  |  |  |  |  |  |  |  |  |  |  |  |  |  |  |  |  |  |  |  |  |  |  |  |  |
| 41 | 1.2.6 | **FASE 2 - PRE - SPOSTAMENTO FIALE - LINEE** |  | 15d | 2021-07-01 | 2021-07-21 | 37 |  |  |  |  |  |  |  |  |  |  |  |  |  |  |  |  |  |  |  |  |  |  |  |  |  |  |  |  |  |  |  |  |  |  |  |  |  |  |  |  |  |  |  |  |  |  |  |  |  |  |  |  |  |  |  |  |  |
| 42 | 1.2.6.1 | FASE 2 - PRE - SPOSTAMENTO FIALE - SPOSTAMENTO |  | 5d | 2021-07-01 | 2021-07-07 | 37 | 2021-04-08 | 2021-04-14 | 5d | 2021-04-12 | 2021-04-16 |  | VAPORTERMICA |  |  |  |  |  |  |  |  |  |  |  |  |  |  |  |  |  |  |  |  |  |  |  |  |  |  |  |  |  |  |  |  |  |  |  |  |  |  |  |  |  |  |  |  |  |  |  |  |  |  |
| 43 | 1.2.6.2 | FASE 2 - PRE - SPOSTAMENTO FIALE - RICABLAGGIO |  | 10d | 2021-07-08 | 2021-07-21 | 42 | 2021-04-15 | 2021-04-28 | 10d | 2021-04-19 | 2021-04-30 |  | FIDENATO |  |  |  |  |  |  |  |  |  |  |  |  |  |  |  |  |  |  |  |  |  |  |  |  |  |  |  |  |  |  |  |  |  |  |  |  |  |  |  |  |  |  |  |  |  |  |  |  |  |  |
| 44 | 1.3 | **ATTIVITA' PRELIMINARI E SOPPALCHI** |  | 162d | 2021-02-01 | 2021-09-14 |  |  |  |  |  |  |  |  |  |  |  |  |  |  |  |  |  |  |  |  |  |  |  |  |  |  |  |  |  |  |  |  |  |  |  |  |  |  |  |  |  |  |  |  |  |  |  |  |  |  |  |  |  |  |  |  |  |  |
| 45 | 1.3.1 | **FASE 0 - ORD - RDO E ORD IMPRESE EDILI** |  | 54d | 2021-02-01 | 2021-04-15 |  |  |  |  |  |  |  |  | 155,000 | false | false | false | false | false | false | false | false | false | false | 0.0 | 0.0 | 0.0 | 0.0 | 0.0 | 0.0 | 0.0 | 0.0 | 0.0 | 0.0 | 0.0 | 0.0 | 0.0 | 0.0 | false | false | false | false | false | false | false | false | false | false | 0.0 | 0.0 | 0.0 | 0.0 | 0.0 | 0.0 | 0.0 | 0.0 | 0.0 | 0.0 | 0.0 | 0.0 | 0.0 | 0.0 | 0.0 |
| 46 | 1.3.1.1 | FASE 0 - EDI - RDO IMPRESE EDILI |  | 54d | 2021-02-01 | 2021-04-15 |  |  |  |  |  |  | start no earlier than 2021-02-01 |  |  |  |  |  |  |  |  |  |  |  |  |  |  |  |  |  |  |  |  |  |  |  |  |  |  |  |  |  |  |  |  |  |  |  |  |  |  |  |  |  |  |  |  |  |  |  |  |  |  |  |
| 47 | 1.3.1.2 | FASE 0 - EDI - ORDINE IMPRESE EDILI | milestone | 0d | 2021-04-16 | 2021-04-16 | 46 | 2021-02-26 | 2021-02-26 | 0d | 2021-02-22 | 2021-02-22 |  |  |  | false | false | false | false | false | false | false | false | false | false | 0.0 | 0.0 | 0.0 | 0.0 | 0.0 | 0.0 | 0.0 | 0.0 | 0.0 | 0.0 | 0.0 | 0.0 | 0.0 | 0.0 | false | false | false | false | false | false | false | false | false | false | 0.0 | 0.0 | 0.0 | 0.0 | 0.0 | 0.0 | 0.0 | 0.0 | 0.0 | 0.0 | 0.0 | 0.0 | 0.0 | 0.0 | 0.0 |
| 48 | 1.3.2 | **FASE 1 - PRE - Scotico e ghiaia** |  | 12d | 2021-04-07 | 2021-04-22 |  |  |  |  |  |  |  |  |  |  |  |  |  |  |  |  |  |  |  |  |  |  |  |  |  |  |  |  |  |  |  |  |  |  |  |  |  |  |  |  |  |  |  |  |  |  |  |  |  |  |  |  |  |  |  |  |  |  |
| 49 | 1.3.2.1 | FASE 1 - PRE - Capitolato |  | 5d | 2021-04-07 | 2021-04-13 |  |  |  |  |  |  |  |  |  |  |  |  |  |  |  |  |  |  |  |  |  |  |  |  |  |  |  |  |  |  |  |  |  |  |  |  |  |  |  |  |  |  |  |  |  |  |  |  |  |  |  |  |  |  |  |  |  |  |
| 50 | 1.3.2.2 | FASE 1 - PRE - ORDINE |  | 2d | 2021-04-14 | 2021-04-15 | 49 |  |  |  |  |  |  |  |  |  |  |  |  |  |  |  |  |  |  |  |  |  |  |  |  |  |  |  |  |  |  |  |  |  |  |  |  |  |  |  |  |  |  |  |  |  |  |  |  |  |  |  |  |  |  |  |  |  |
| 51 | 1.3.2.3 | FASE 1 - PRE - Scotico e ghiaia |  | 5d | 2021-04-16 | 2021-04-22 | 50 |  |  |  |  |  |  |  |  |  |  |  |  |  |  |  |  |  |  |  |  |  |  |  |  |  |  |  |  |  |  |  |  |  |  |  |  |  |  |  |  |  |  |  |  |  |  |  |  |  |  |  |  |  |  |  |  |  |

| ID | WBS | Task | Type | Duration | Start | Finish | Predecessors | Baseline start | Baseline finish | Baseline duration | Baseline 1 start | Baseline 1 finish | Constraint | Resources | Cost |
| --- | --- | --- | --- | --- | --- | --- | --- | --- | --- | --- | --- | --- | --- | --- | --- |
| 52 | 1.3.3 | **FASE 1 - PRE - Cantierizzazione** |  | 3d | 2021-04-23 | 2021-04-27 | 45FS+5d, 48 | 2021-03-02 | 2021-03-15 | 10d | 2021-03-01 | 2021-03-12 |  |  |  |
| 53 | 1.3.3.1 | Cantierizzazione |  | 2d | 2021-04-23 | 2021-04-26 | 45FS+5d | 2021-03-02 | 2021-03-15 | 10d | 2021-03-01 | 2021-03-05 |  | IMPRESA EDILE |  |
| 54 | 1.3.3.2 | Cantierizzazione ELE |  | 1d | 2021-04-27 | 2021-04-27 | 53 |  |  |  |  |  |  | FIDENATO | 2,610 |
| 55 | 1.3.4 | **FASE 1 - PRE - Delimitazioni interne** |  | 10d | 2021-03-22 | 2021-04-02 |  |  |  |  | 2021-03-08 | 2021-03-12 |  |  | 11,370 |
| 56 | 1.3.4.1 | FASE 1 - PRE - Delimitazioni interne |  | 10d | 2021-03-22 | 2021-04-02 |  |  |  |  |  |  | start no earlier than 2021-03-22 | MESTRONI | 11,370 |
| 57 | 1.3.5 | **FASE 1 - PRE (IE+im) - opere propedeutiche** |  | 45d | 2021-02-15 | 2021-04-16 |  |  |  |  |  |  |  |  | 376,321 |
| 58 | 1.3.5.1 | eliminazione rete dati, FM, illuminazione, TVCC |  | 45d | 2021-02-15 | 2021-04-16 |  |  |  |  |  |  |  | FIDENATO |  |
| 59 | 1.3.5.2 | RIMOZIONE CONDIZIONATORI ,VAPORE, ECC... |  | 9d | 2021-04-06 | 2021-04-16 |  |  |  |  |  |  |  | VAPORTERMICA |  |
| 60 | 1.3.6 | **FASE 1 - PRE - RIMOZ. UTA ASTUCCIAMENTO (PK1)** |  | 7d | 2021-04-15 | 2021-04-23 |  |  |  |  |  |  |  |  | 7,980 |
| 61 | 1.3.6.1 | rimozione UTA astucc |  | 7d | 2021-04-15 | 2021-04-23 |  |  |  |  |  |  |  | MECC da assegnare | 7,980 |
| 62 | 1.3.7 | **FASE 1 - PRE - porta per via di fuga** |  | 20d | 2021-03-18 | 2021-04-14 |  |  |  |  |  |  |  |  |  |
| 63 | 1.3.7.1 | FASE 1 - PRE - ORDINE PORTA | milestone | 0d | 2021-03-18 | 2021-03-18 |  |  |  |  |  |  |  |  | 2,280 |
| 64 | 1.3.7.2 | FASE 1 - PRE - PREMONTAGGIO porta |  | 18d | 2021-03-18 | 2021-04-12 | 63 |  |  |  |  |  |  |  |  |
| 65 | 1.3.7.3 | FASE 1 - PRE - MONTAGGIO porta |  | 2d | 2021-04-13 | 2021-04-14 | 64 |  |  |  |  |  |  |  |  |
| 66 | 1.3.8 | INIZIO LAVORI EDILI (CANTIERIZZ + SCIA in comune) | milestone | 0d | 2021-04-28 | 2021-04-28 | 23, 52, 55, 60, 62 |  |  |  |  |  | start no earlier than 2021-04-19 |  |  |
| 67 | 1.3.9 | **FASE 1 - PRE - CLIMA D008 (PK1)** |  | 5d | 2021-06-09 | 2021-06-15 | 69 |  |  |  |  |  |  |  | 14,700 |
| 68 | 1.3.9.1 | FASE 1 - PRE - CLIMA D008 (PK1) |  | 5d | 2021-06-09 | 2021-06-15 | 69 |  |  |  |  |  |  | MECC da assegnare | 14,700 |
| 69 | 1.3.10 | **FASE 1 - PRE - MODIFICHE (PK1) + PREDISP (PK4) + PULIZIE (PK7+8)** |  | 30d | 2021-04-28 | 2021-06-08 | 66 |  |  |  |  |  |  |  |  |
| 70 | 1.3.10.1 | **FASE 1 - PRE - CLIMA LAB (PK1)** |  | 5d | 2021-04-28 | 2021-05-04 | 66 |  |  |  |  |  |  | MECC da assegnare | 7,680 |
| 71 | 1.3.10.1.1 | Spostamento unità esterne laboratorio |  | 5d | 2021-04-28 | 2021-05-04 | 66 |  |  |  |  |  |  |  |  |
| 72 | 1.3.10.2 | **FASE 1 - PRE - CLIMA D007 (PK1)** |  | 7d | 2021-05-07 | 2021-05-17 | 70 |  |  |  |  |  |  | MECC da assegnare | 21,300 |
| 73 | 1.3.10.2.1 | Impianti condizionamento ed estrazione D007 |  | 7d | 2021-05-07 | 2021-05-17 |  | 2021-03-02 | 2021-03-08 | 5d | 2021-03-08 | 2021-03-12 |  | VAPORTERMICA |  |
| 74 | 1.3.10.3 | **FASE 1 - PRE - ACQUA e CANALI per UTA 10 + MUNTERS (PK1+PK4)** |  | 25d | 2021-05-05 | 2021-06-08 | 70 |  |  |  |  |  |  | MECC da assegnare | 179,500 |
| 75 | 1.3.10.3.1 | Modifica canali UTA 10, UTA Twin 1 e 2, estrattori |  | 25d | 2021-05-05 | 2021-06-08 | 70 | 2021-03-02 | 2021-03-29 | 20d | 2021-03-01 | 2021-03-12 |  | VAPORTERMICA |  |
| 76 | 1.3.10.3.2 | FASE 1 - PRE - PREDISPOSIZIONI UTA 10 |  | 25d | 2021-05-05 | 2021-06-08 | 70 |  |  |  |  |  |  | VAPORTERMICA |  |

| ID | WBS | Task | Type | Duration | Start | Finish | Predecessors | Baseline start | Baseline finish | Baseline duration | Baseline 1 start | Baseline 1 finish | Resources | Cost |
| --- | --- | --- | --- | --- | --- | --- | --- | --- | --- | --- | --- | --- | --- | --- |
| 77 | 1.3.11 | **FASE 1 -EDI - OPERE EDILI SOPPALCO A** |  | 20d | 2021-04-28 | 2021-05-25 | 66 |  |  |  |  |  |  |  |
| 78 | 1.3.11.1 | FASE 1 - EDI - Fondazioni A (scavi e demolizioni) |  | 10d | 2021-04-28 | 2021-05-11 | 66 |  |  |  |  |  | IMPRESA EDILE |  |
| 79 | 1.3.11.2 | FASE 1 - EDI - Getti e maturazione A |  | 10d | 2021-05-12 | 2021-05-25 | 78 |  |  |  |  |  | IMPRESA EDILE |  |
| 80 | 1.3.12 | **FASE 0 - ORD - RDO E ORD CARPENTERIE SOPPALCO A e B (parti 1e2)** |  | 54d | 2021-02-01 | 2021-04-15 |  | 2021-02-01 | 2021-05-11 | 72d | 2021-02-01 | 2021-04-09 |  | 369,571 |
| 81 | 1.3.12.1 | FASE 0 - STR - RDO CARPENTERIE SOPPALCO A+B |  | 54d | 2021-02-01 | 2021-04-15 |  | 2021-02-01 | 2021-02-26 | 20d | 2021-02-01 | 2021-02-26 |  |  |
| 82 | 1.3.12.2 | FASE 0 - STR - ORDINE CARPENTERIE SOPPALCO A+B | milestone | 0d | 2021-04-16 | 2021-04-16 | 81 | 2021-03-01 | 2021-03-01 | 0d | 2021-03-01 | 2021-03-01 |  |  |
| 83 | 1.3.13 | **FASE 1 - STR -CARPENTERIE SOPPALCO A + GETTO** |  | 20d | 2021-05-26 | 2021-06-22 | 77, 80FS+20d |  |  |  |  |  |  |  |
| 84 | 1.3.13.1 | FASE 1 - STR - CONSEGNA CARPENTERIE SOPPALCO A | milestone | 0d | 2021-05-26 | 2021-05-26 | 77, 80FS+20d | 2021-04-14 | 2021-04-14 | 0d | 2021-04-19 | 2021-04-19 |  |  |
| 85 | 1.3.13.2 | FASE 1 - STR - MONTAGGIO CARPENTERIE SOPPALCO A |  | 5d | 2021-05-26 | 2021-06-01 | 84 | 2021-04-14 | 2021-05-11 | 20d | 2021-04-19 | 2021-05-14 | IMPRESA CARPENTERIE |  |
| 86 | 1.3.13.3 | FASE 1 - STR - COPERTURA E PANNELLI SOPPALCO A |  | 5d | 2021-06-02 | 2021-06-08 | 85 |  |  |  |  |  | IMPRESA CARPENTERIE |  |
| 87 | 1.3.13.4 | FASE 1 - CIV -GETTO IN COPERTURA E MATURAZIONE A |  | 10d | 2021-06-09 | 2021-06-22 | 86 |  |  |  |  |  | IMPRESA EDILE |  |
| 88 | 1.3.13.5 | FASE 1 - STR - FINE SOPPALCO A | milestone | 0d | 2021-06-23 | 2021-06-23 | 87 |  |  |  |  |  |  |  |
| 89 | 1.3.14 | **FASE 1 - PRE - RICOLLOC. UTA 10 (PK1)** |  | 5d | 2021-06-23 | 2021-06-29 | 69, 83 | 2021-05-17 | 2021-06-15 | 22d | 2021-05-17 | 2021-06-04 |  |  |
| 90 | 1.3.14.1 | FASE 1 - PRE - RICOLLOC. UTA 10 (PK1) |  | 5d | 2021-06-23 | 2021-06-29 | 69, 83 | 2021-05-12 | 2021-06-01 | 15d | 2021-05-17 | 2021-05-28 | VAPORTERMICA |  |
| 91 | 1.3.15 | **FASE 1 - EDI - OPERE EDILI SOPPALCO B/1** |  | 25d | 2021-05-26 | 2021-06-29 | 77 |  |  |  |  |  |  |  |
| 92 | 1.3.15.1 | FASE 1 - EDI - Fondazioni B/1 (scavi e demolizioni) |  | 15d | 2021-05-26 | 2021-06-15 | 77 |  |  |  |  |  | IMPRESA EDILE |  |
| 93 | 1.3.15.2 | FASE 1 - EDI - Getti e maturazione FOND B1 |  | 10d | 2021-06-16 | 2021-06-29 | 92 |  |  |  |  |  | IMPRESA EDILE |  |
| 94 | 1.3.16 | **FASE 2 - EDI - OPERE EDILI SOPPALCO B/2** |  | 25d | 2021-06-30 | 2021-08-03 | 89 |  |  |  |  |  |  |  |
| 95 | 1.3.16.1 | FASE 1 - EDI - modfica fondi persi |  | 5d | 2021-06-30 | 2021-07-06 | 89 | 2021-06-02 | 2021-06-15 | 10d | 2021-05-31 | 2021-06-04 | IMPRESA EDILE |  |
| 96 | 1.3.16.2 | FASE 1 - EDI - Fondazioni (scavi, ecc..) |  | 10d | 2021-07-07 | 2021-07-20 | 95 |  |  |  | 2021-06-07 | 2021-06-18 | IMPRESA EDILE |  |
| 97 | 1.3.16.3 | FASE 1 - EDI - getti e maturazione |  | 10d | 2021-07-21 | 2021-08-03 | 96 |  |  |  |  |  | IMPRESA EDILE |  |
| 98 | 1.3.17 | **FASE 1 - STR -CARPENTERIE SOPPALCO B/1 + GETTO** |  | 20d | 2021-06-30 | 2021-07-27 | 89, 91 |  |  |  |  |  |  |  |
| 99 | 1.3.17.1 | FASE 1 - STR - CONSEGNA CARPENTERIE SOPPALCO B/1 | milestone | 0d | 2021-06-30 | 2021-06-30 | 89, 91 |  |  |  |  |  |  |  |
| 100 | 1.3.17.2 | FASE 1 - STR - MONTAGGIO CARPENTERIE SOPPALCO B/1 |  | 5d | 2021-06-30 | 2021-07-06 | 99 |  |  |  |  |  | IMPRESA CARPENTERIE |  |
| 101 | 1.3.17.3 | FASE 1 - STR -COPERTURA E PANNELLI SOPPALCO B/1 |  | 5d | 2021-07-07 | 2021-07-13 | 100 |  |  |  |  |  | IMPRESA CARPENTERIE |  |
| 102 | 1.3.17.4 | FASE 1 - CIV -GETTO IN COPERTURA E MATURAZIONE B/1 |  | 10d | 2021-07-14 | 2021-07-27 | 101 |  |  |  |  |  | IMPRESA EDILE |  |
| 103 | 1.3.17.5 | FASE 1 - STR - FINE SOPPALCO B/1 | milestone | 0d | 2021-07-28 | 2021-07-28 | 102 |  |  |  |  |  |  |  |

Notes:
- 89: Ad AGOSTO saranno attivati: / - la NUOVA SALA di TWIN 1 / - il CORRIDOIO / - la NUOVA SALA lavaggi / E' quindi necessario che per agosto siano attive / - la nuova UTA GEN 2 / - la vecchia UTA 10 / AZIONI / - posizionare UTA 10 sul soppalco A e renderla attiva entro agosto

| ID | WBS | Task | Type | Duration | Start | Finish | Predecessors | Baseline start | Baseline finish | Baseline duration | Baseline 1 start | Baseline 1 finish | Constraint | Resources | Cost | Flag1 | Flag2 | Flag3 | Flag4 | Flag5 | Flag6 | Flag7 | Flag8 | Flag9 | Flag10 | Number1 | Number2 | Number3 | Number4 | Number5 | Budget | Cost3 | Cost4 | Cost5 | Cost6 | Cost7 | Cost8 | Cost9 | Cost10 | Flag11 | Flag12 | Flag13 | Flag14 | Flag15 | Flag16 | Flag17 | Flag18 | Flag19 | Flag20 | Number6 | Number7 | Number8 | Number9 | Number10 | Number11 | Number12 | Number13 | Number14 | Number15 | Number16 | Number17 | Number18 | Number19 | Number20 |
| --- | --- | --- | --- | --- | --- | --- | --- | --- | --- | --- | --- | --- | --- | --- | --- | --- | --- | --- | --- | --- | --- | --- | --- | --- | --- | --- | --- | --- | --- | --- | --- | --- | --- | --- | --- | --- | --- | --- | --- | --- | --- | --- | --- | --- | --- | --- | --- | --- | --- | --- | --- | --- | --- | --- | --- | --- | --- | --- | --- | --- | --- | --- | --- | --- |
| 104 | 1.3.18 | **FASE 1 - CARPENTERIE SOPPALCO B2 + GETTO** |  | 30d | 2021-08-04 | 2021-09-14 | 94, 98 |  |  |  |  |  |  |  |  |  |  |  |  |  |  |  |  |  |  |  |  |  |  |  |  |  |  |  |  |  |  |  |  |  |  |  |  |  |  |  |  |  |  |  |  |  |  |  |  |  |  |  |  |  |  |  |  |  |
| 105 | 1.3.18.1 | FASE 1 - STR - CONSEGNA CARPENTERIE SOPPALCO B/2 | milestone | 0d | 2021-08-04 | 2021-08-04 | 94, 98 |  |  |  |  |  |  |  |  |  |  |  |  |  |  |  |  |  |  |  |  |  |  |  |  |  |  |  |  |  |  |  |  |  |  |  |  |  |  |  |  |  |  |  |  |  |  |  |  |  |  |  |  |  |  |  |  |  |
| 106 | 1.3.18.2 | FASE 1 - STR - MONTAGGIO CARPENTERIE SOPPALCO B/2 |  | 15d | 2021-08-04 | 2021-08-24 | 105 | 2021-07-14 | 2021-08-27 | 33d | 2021-07-05 | 2021-07-30 |  | IMPRESA CARPENTERIE |  |  |  |  |  |  |  |  |  |  |  |  |  |  |  |  |  |  |  |  |  |  |  |  |  |  |  |  |  |  |  |  |  |  |  |  |  |  |  |  |  |  |  |  |  |  |  |  |  |  |
| 107 | 1.3.18.3 | FASE 1 - STR - COPERTURA E PANNELLI SOPPALCO B/2 |  | 5d | 2021-08-21 | 2021-08-27 | 106 |  |  |  |  |  |  | IMPRESA CARPENTERIE |  |  |  |  |  |  |  |  |  |  |  |  |  |  |  |  |  |  |  |  |  |  |  |  |  |  |  |  |  |  |  |  |  |  |  |  |  |  |  |  |  |  |  |  |  |  |  |  |  |  |
| 108 | 1.3.18.4 | FASE 1 - CIV -GETTO IN COPERTURA E MATURAZIONE B/2 |  | 10d | 2021-08-26 | 2021-09-08 | 107 |  |  |  |  |  |  | IMPRESA EDILE |  |  |  |  |  |  |  |  |  |  |  |  |  |  |  |  |  |  |  |  |  |  |  |  |  |  |  |  |  |  |  |  |  |  |  |  |  |  |  |  |  |  |  |  |  |  |  |  |  |  |
| 109 | 1.3.19 | **FASE 1 - PRE - RIMOZIONE IDRANTI+STACCHI (PK0)** |  | 5d | 2021-06-30 | 2021-07-06 | 91 |  |  |  |  |  |  |  |  |  |  |  |  |  |  |  |  |  |  |  |  |  |  |  |  |  |  |  |  |  |  |  |  |  |  |  |  |  |  |  |  |  |  |  |  |  |  |  |  |  |  |  |  |  |  |  |  |  |
| 110 | 1.3.19.1 | FASE 0 - PRE - RIMOZIONE IDRANTI+STACCHI (PK0) |  | 5d | 2021-06-30 | 2021-07-06 | 91 |  |  |  |  |  |  | VAPORTERMICA |  |  |  |  |  |  |  |  |  |  |  |  |  |  |  |  |  |  |  |  |  |  |  |  |  |  |  |  |  |  |  |  |  |  |  |  |  |  |  |  |  |  |  |  |  |  |  |  |  |  |
| 111 | 1.3.20 | **FASE 1 - IM - IMPIANTO A.I. in CANTIERE (PK0)** |  | 10d | 2021-07-07 | 2021-07-20 | 109 |  |  |  |  |  |  |  | 32,800 |  |  |  |  |  |  |  |  |  |  |  |  |  |  |  |  |  |  |  |  |  |  |  |  |  |  |  |  |  |  |  |  |  |  |  |  |  |  |  |  |  |  |  |  |  |  |  |  |  |
| 112 | 1.3.20.1 | FASE 1 - IM - IMPIANTO A.I. in CANTIERE |  | 10d | 2021-07-07 | 2021-07-20 | 109 |  |  |  |  |  |  | MECC da assegnare | 32,800 |  |  |  |  |  |  |  |  |  |  |  |  |  |  |  |  |  |  |  |  |  |  |  |  |  |  |  |  |  |  |  |  |  |  |  |  |  |  |  |  |  |  |  |  |  |  |  |  |  |
| 113 | 1.3.21 | **FASE 2 - PRE - IMPIANTO A.I. in LINZI** |  | 10d | 2021-08-09 | 2021-08-20 | 109 |  |  |  |  |  |  |  |  |  |  |  |  |  |  |  |  |  |  |  |  |  |  |  |  |  |  |  |  |  |  |  |  |  |  |  |  |  |  |  |  |  |  |  |  |  |  |  |  |  |  |  |  |  |  |  |  |  |
| 114 | 1.3.21.1 | FASE 2 - PRE - IMPIANTO A.I. in LINZI |  | 10d | 2021-08-09 | 2021-08-20 | 109 |  |  |  |  |  | start no earlier than 2021-08-09 | VAPORTERMICA |  |  |  |  |  |  |  |  |  |  |  |  |  |  |  |  |  |  |  |  |  |  |  |  |  |  |  |  |  |  |  |  |  |  |  |  |  |  |  |  |  |  |  |  |  |  |  |  |  |  |
| 115 | 1.3.22 | **FASE 0 - IM - RDO-ORDINE-APPROVIG. UTA-GEN2 (APP.CRITICI su SOPPALCO B/1)** |  | 50d | 2021-04-26 | 2021-07-02 | 121 |  |  |  |  |  |  |  |  |  |  |  |  |  |  |  |  |  |  |  |  |  |  |  |  |  |  |  |  |  |  |  |  |  |  |  |  |  |  |  |  |  |  |  |  |  |  |  |  |  |  |  |  |  |  |  |  |  |
| 116 | 1.3.22.1 | FASE 0 - IM - RDO UTA GEN 2 (APP CRITICI) |  | 10d | 2021-04-26 | 2021-05-07 | 121 | 2021-03-18 | 2021-04-30 | 32d | 2021-03-22 | 2021-04-30 |  | C&P |  |  |  |  |  |  |  |  |  |  |  |  |  |  |  |  |  |  |  |  |  |  |  |  |  |  |  |  |  |  |  |  |  |  |  |  |  |  |  |  |  |  |  |  |  |  |  |  |  |  |
| 117 | 1.3.22.2 | FASE 0 - IM - ORDINI UTA GEN 2 (APP CRITICI) | milestone | 0d | 2021-05-10 | 2021-05-10 | 116 | 2021-05-03 | 2021-05-03 | 0d | 2021-05-03 | 2021-05-03 |  |  |  |  |  |  |  |  |  |  |  |  |  |  |  |  |  |  |  |  |  |  |  |  |  |  |  |  |  |  |  |  |  |  |  |  |  |  |  |  |  |  |  |  |  |  |  |  |  |  |  |  |
| 118 | 1.3.22.3 | FASE 0 - IM - APPROVIG. UTA GEN 2 (APP CRITICI) |  | 40d | 2021-05-10 | 2021-07-02 | 117 |  |  |  |  |  |  |  |  |  |  |  |  |  |  |  |  |  |  |  |  |  |  |  |  |  |  |  |  |  |  |  |  |  |  |  |  |  |  |  |  |  |  |  |  |  |  |  |  |  |  |  |  |  |  |  |  |  |
| 119 | 1.3.23 | **FASE 2 - IM - Posizionamento UTA GEN 2** |  | 10d | 2021-07-28 | 2021-08-10 | 98, 115 |  |  |  |  |  |  |  |  |  |  |  |  |  |  |  |  |  |  |  |  |  |  |  |  |  |  |  |  |  |  |  |  |  |  |  |  |  |  |  |  |  |  |  |  |  |  |  |  |  |  |  |  |  |  |  |  |  |
| 120 | 1.3.23.1 | FASE 2 - IM - Posizionamento UTA GEN 2 |  | 10d | 2021-07-28 | 2021-08-10 | 98, 115 |  |  |  |  |  |  | C&P |  |  |  |  |  |  |  |  |  |  |  |  |  |  |  |  |  |  |  |  |  |  |  |  |  |  |  |  |  |  |  |  |  |  |  |  |  |  |  |  |  |  |  |  |  |  |  |  |  |  |
| 121 | 1.3.24 | **FASE 0 - IM/IE - INGEGNERIA DI DETTAGLIO** |  | 34d | 2021-03-09 | 2021-04-23 |  | 2021-02-12 | 2021-08-27 | 141d | 2021-02-15 | 2021-03-19 |  |  |  |  |  |  |  |  |  |  |  |  |  |  |  |  |  |  |  |  |  |  |  |  |  |  |  |  |  |  |  |  |  |  |  |  |  |  |  |  |  |  |  |  |  |  |  |  |  |  |  |  |
| 122 | 1.3.24.1 | FASE 0 - IM/IE/CIV - ORDINE INGEGNERIA | milestone | 0d | 2021-03-09 | 2021-03-09 |  | 2021-02-12 | 2021-02-12 | 0d | 2021-02-15 | 2021-02-15 |  | BIOFARMA |  |  |  |  |  |  |  |  |  |  |  |  |  |  |  |  |  |  |  |  |  |  |  |  |  |  |  |  |  |  |  |  |  |  |  |  |  |  |  |  |  |  |  |  |  |  |  |  |  |  |
| 123 | 1.3.24.2 | FASE 0 - IM/IE/CIV - INGEGNERIA MECC/ELE/CIV (APP CRITICI-PRINCIPALI-ALTRI) |  | 34d | 2021-03-09 | 2021-04-23 | 122 |  |  |  |  |  |  | C&P |  |  |  |  |  |  |  |  |  |  |  |  |  |  |  |  |  |  |  |  |  |  |  |  |  |  |  |  |  |  |  |  |  |  |  |  |  |  |  |  |  |  |  |  |  |  |  |  |  |  |
| 124 | 1.3.24.3 | FASE 0 - IM/IE - Definizioni ing. e app. I livello |  | 34d | 2021-03-09 | 2021-04-23 | 122 |  |  |  |  |  |  | C&P |  | false | false | false | false | false | false | false | false | false | false | 0.0 | 0.0 | 0.0 | 0.0 | 0.0 | 0.0 | 0.0 | 0.0 | 0.0 | 0.0 | 0.0 | 0.0 | 0.0 | 0.0 | false | false | false | false | false | false | false | false | false | false | 0.0 | 0.0 | 0.0 | 0.0 | 0.0 | 0.0 | 0.0 | 0.0 | 0.0 | 0.0 | 0.0 | 0.0 | 0.0 | 0.0 | 0.0 |
| 125 | 1.3.24.4 | FASE 0 - IM - Definizioni apparecchiature II livello |  | 34d | 2021-03-09 | 2021-04-23 | 122 |  |  |  |  |  |  | C&P |  |  |  |  |  |  |  |  |  |  |  |  |  |  |  |  |  |  |  |  |  |  |  |  |  |  |  |  |  |  |  |  |  |  |  |  |  |  |  |  |  |  |  |  |  |  |  |  |  |  |
| 126 | 1.3.24.5 | FASE 0 - IM - INGEGNERIA APP.PRINCIPALI (SOPPALCO B/2) |  | 34d | 2021-03-09 | 2021-04-23 | 122 |  |  |  |  |  |  | C&P |  |  |  |  |  |  |  |  |  |  |  |  |  |  |  |  |  |  |  |  |  |  |  |  |  |  |  |  |  |  |  |  |  |  |  |  |  |  |  |  |  |  |  |  |  |  |  |  |  |  |
| 127 | 1.3.24.6 | FASE 0 - IE - INGEGNERIA DISTRIBUZIONE (MATERIALI) |  | 30d | 2021-03-09 | 2021-04-19 | 122 |  |  |  |  |  |  | C&P |  |  |  |  |  |  |  |  |  |  |  |  |  |  |  |  |  |  |  |  |  |  |  |  |  |  |  |  |  |  |  |  |  |  |  |  |  |  |  |  |  |  |  |  |  |  |  |  |  |  |
| 128 | 1.3.24.7 | FASE 0 - IM - Completamento progettazione capitolati |  | 15d | 2021-03-09 | 2021-03-29 | 122 |  |  |  |  |  |  | C&P |  | false | false | false | false | false | false | false | false | false | false | 0.0 | 0.0 | 0.0 | 0.0 | 0.0 | 0.0 | 0.0 | 0.0 | 0.0 | 0.0 | 0.0 | 0.0 | 0.0 | 0.0 | false | false | false | false | false | false | false | false | false | false | 0.0 | 0.0 | 0.0 | 0.0 | 0.0 | 0.0 | 0.0 | 0.0 | 0.0 | 0.0 | 0.0 | 0.0 | 0.0 | 0.0 | 0.0 |
| 129 | 1.3.24.8 | FASE 0 - IM - Definizione forniture |  | 19d | 2021-03-30 | 2021-04-23 | 128 |  |  |  |  |  |  | C&P |  | false | false | false | false | false | false | false | false | false | false | 0.0 | 0.0 | 0.0 | 0.0 | 0.0 | 0.0 | 0.0 | 0.0 | 0.0 | 0.0 | 0.0 | 0.0 | 0.0 | 0.0 | false | false | false | false | false | false | false | false | false | false | 0.0 | 0.0 | 0.0 | 0.0 | 0.0 | 0.0 | 0.0 | 0.0 | 0.0 | 0.0 | 0.0 | 0.0 | 0.0 | 0.0 | 0.0 |
| 130 | 1.3.24.9 | FASE 0 - CIV - ING e CAPITOLATI (MATERIALI) |  | 30d | 2021-03-09 | 2021-04-19 | 122 |  |  |  |  |  |  | C&P |  |  |  |  |  |  |  |  |  |  |  |  |  |  |  |  |  |  |  |  |  |  |  |  |  |  |  |  |  |  |  |  |  |  |  |  |  |  |  |  |  |  |  |  |  |  |  |  |  |  |

Notes:
- 121: Ad AGOSTO saranno attivati: / - la NUOVA SALA di TWIN 1 / - il CORRIDOIO / - la NUOVA SALA lavaggi / E' quindi necessario che per agosto siano attive / - la nuova UTA GEN 2 / - la vecchia UTA 10 / AZIONI / - anticipare l'ingegneria e la consegna di UTA GEN 2 / - anticipare l'ingegneria di UTA 10 / - posizionare UTA GEN 2 sul soppalco B/1 (anziché B/2) / - anticipare i collegamenti idraulici di UTA 10 / - anticipare i collegamenti idraulici di UTA GEN 2

| ID | WBS | Task | Type | Duration | Start | Finish | Predecessors | Baseline start | Baseline finish | Baseline duration | Baseline 1 start | Baseline 1 finish | Constraint | Resources | Cost |
| --- | --- | --- | --- | --- | --- | --- | --- | --- | --- | --- | --- | --- | --- | --- | --- |
| 131 | 1.3.25 | **FASE 0 - PRE - RDO-ORD-APPROVIG. MATERIALI DISTRIBUZIONE (PK 5-6)** |  | 40d | 2021-04-26 | 2021-06-18 | 121 |  |  |  |  |  |  |  |  |
| 132 | 1.3.25.1 | FASE 0 - IM - RDO-ORD-APPROVIG. MATERIALI DISTRIBUZIONE |  | 40d | 2021-04-26 | 2021-06-18 | 121 |  |  |  |  |  |  |  |  |
| 133 | 1.3.26 | **FASE 2 - PRE - DISTRIBUZIONE DEFINITIVA ACQUA GELIDA e AC** |  | 20d | 2021-06-21 | 2021-07-16 | 131 | 2021-08-02 | 2021-08-27 | 20d | 2021-05-03 | 2021-05-28 |  |  |  |
| 134 | 1.3.26.1 | FASE 2 - PRE - DISTRIBUZIONE DEFINITIVA ACQUA GELIDA e AC |  | 20d | 2021-06-21 | 2021-07-16 | 131 |  |  |  |  |  |  | VAPORTERMICA |  |
| 135 | 1.3.27 | **FASE 0 - PRE - RDO-ORD-APPROVIG. MATERIALI CRITICI PER QC/QD** |  | 40d | 2021-04-26 | 2021-06-18 | 121 |  |  |  |  |  |  |  |  |
| 136 | 1.3.27.1 | FASE 0 - PRE - RDO-ORD-APPROVIG. MATERIALI CRITICI PER QC/QD |  | 40d | 2021-04-26 | 2021-06-18 | 121 |  |  |  |  |  |  |  |  |
| 137 | 1.3.28 | **FERMATA DI AGOSTO** |  | 14d | 2021-08-11 | 2021-08-30 | 119, 133, 135 |  |  |  |  |  |  |  |  |
| 138 | 1.3.28.1 | INIZIO FERMATA DI AGOSTO | milestone | 0d | 2021-08-11 | 2021-08-11 | 119, 133, 135, 146 |  |  |  |  |  | start no earlier than 2021-08-09 |  |  |
| 139 | 1.3.28.2 | **FASE 2 - PRE - Adeguamento quadri QC-QD** |  | 14d | 2021-08-11 | 2021-08-30 | 138 | 2021-08-02 | 2021-08-27 | 20d | 2021-05-03 | 2021-05-28 |  | ELE da assegnare | 19,901 |
| 140 | 1.3.28.2.1 | FASE 2 - PRE - Adeguamento quadri QC-QD |  | 14d | 2021-08-11 | 2021-08-30 | 138 |  |  |  |  |  |  |  |  |
| 141 | 1.3.28.3 | **FASE 2 - IM - COLLEGAMENTO APP.CRITICI (SOPPALCO A e B1)** |  | 14d | 2021-08-11 | 2021-08-30 | 138 |  |  |  | 2021-08-02 | 2021-08-02 |  |  |  |
| 142 | 1.3.28.3.1 | FASE 2 - IM - ALLACCIAMENTI UTA GEN 2 |  | 14d | 2021-08-11 | 2021-08-30 | 138 |  |  |  |  |  |  | VAPORTERMICA |  |
| 143 | 1.3.28.4 | **FASE 2 - PRE - TIE-INS SU COLLETTORI** |  | 14d | 2021-08-11 | 2021-08-30 | 138 |  |  |  |  |  |  |  |  |
| 144 | 1.3.28.4.1 | FASE 2 - PRE - TIE-INS SU COLLETTORI |  | 14d | 2021-08-11 | 2021-08-30 | 138 |  |  |  |  |  |  | VAPORTERMICA |  |
| 145 | 1.3.28.5 | FINE FERMATA=INIZIO PRODUZIONE | milestone | 0d | 2021-08-20 | 2021-08-20 | 138FS+9d |  |  |  |  |  |  |  |  |
| 146 | 1.3.29 | **LOCALI TWIN 1** |  | 30d | 2021-06-23 | 2021-08-03 | 88 |  |  |  |  |  |  |  |  |
| 147 | 1.3.29.1 | **FASE 2 - CIV - TWIN 1 (locale)** |  | 10d | 2021-06-23 | 2021-07-06 | 88 |  |  |  |  |  |  |  |  |
| 148 | 1.3.29.1.1 | FASE 2 - CIV - LOCALE PER TWIN 1 |  | 10d | 2021-06-23 | 2021-07-06 | 88 |  |  |  |  |  |  |  |  |
| 149 | 1.3.29.2 | **FASE 2 - IM - IMPIANTI MECC PER TWIN 1** |  | 10d | 2021-07-07 | 2021-07-20 | 147 |  |  |  |  |  |  |  |  |
| 150 | 1.3.29.2.1 | FASE 2 - IM - IMPIANTI MECC PER TWIN 1 |  | 10d | 2021-07-07 | 2021-07-20 | 147 |  |  |  |  |  |  | C&P |  |
| 151 | 1.3.29.3 | **FASE 2 - IE - IMPIANTI ELE PER TWIN 1** |  | 10d | 2021-07-21 | 2021-08-03 | 149 |  |  |  |  |  |  |  |  |
| 152 | 1.3.29.3.1 | FASE 2 - IE - IMPIANTI ELE PER TWIN 1 |  | 10d | 2021-07-21 | 2021-08-03 | 149 |  |  |  |  |  |  | C&P |  |
| 153 | 1.3.30 | **TWIN 1 + SALA LAVAGGI + CORRIDOIO** |  | 26d | 2021-08-06 | 2021-09-10 | 146 |  |  |  |  |  |  |  |  |
| 154 | 1.3.30.1 | **FASE 2 - MACC - TWIN 1 (macchina)** |  | 2d | 2021-08-06 | 2021-08-09 |  | 2021-09-27 | 2021-10-08 | 10d | 2021-08-02 | 2021-08-13 | start no earlier than 2021-08-02 |  |  |
| 155 | 1.3.30.1.1 | FASE 2 - MACC - posizionamento TWIN 1 |  | 2d | 2021-08-06 | 2021-08-09 |  |  |  |  |  |  | start no earlier than 2021-08-02 | VAPORTERMICA |  |

Notes:
- 131: Ad AGOSTO saranno attivati: / - la NUOVA SALA di TWIN 1 / - il CORRIDOIO / - la NUOVA SALA lavaggi / E' quindi necessario che per agosto siano attive / - la nuova UTA GEN 2 / - la vecchia UTA 10 / AZIONI / - anticipare la relativa distribuzione fluidi
- 147: Ad AGOSTO saranno attivati: / - la NUOVA SALA di TWIN 1 / - il CORRIDOIO / - la NUOVA SALA lavaggi / E' quindi necessario che per agosto sia pronta la NUOVA stanza della TWIN 1 / AZIONI / - anticipare realizzazione del LOCALE

| ID | WBS | Task | Type | Duration | Start | Finish | Predecessors | Constraint | Resources |
| --- | --- | --- | --- | --- | --- | --- | --- | --- | --- |
| 156 | 1.3.30.2 | **FASE 2 - MACC - allaccio TWIN 1** |  | 24d | 2021-08-10 | 2021-09-10 | 154 | start no earlier than 2021-08-02 |  |
| 157 | 1.3.30.2.1 | FASE 2 - MACC - allaccio TWIN 1 |  | 24d | 2021-08-10 | 2021-09-10 | 154 | start no earlier than 2021-08-02 | VAPORTERMICA |
| 158 | 1.3.30.3 | **FASE 2 - IE - SALA LAVAGGI** |  | 5d | 2021-08-10 | 2021-08-16 | 154 | start no earlier than 2021-08-04 |  |
| 159 | 1.3.30.3.1 | FASE 2 - IE - SALA LAVAGGI |  | 5d | 2021-08-10 | 2021-08-16 | 154 | start no earlier than 2021-08-04 | C&P |
| 160 | 1.3.30.4 | **FASE 2 - IM - SALA LAVAGGI** |  | 5d | 2021-08-10 | 2021-08-16 | 154 | start no earlier than 2021-08-04 |  |
| 161 | 1.3.30.4.1 | FASE 2 - IM - SALA LAVAGGI |  | 5d | 2021-08-10 | 2021-08-16 | 154 | start no earlier than 2021-08-04 | C&P |
| 162 | 1.3.30.5 | **FASE 2 - EDI - SCARICHI SALA LAVAGGI** |  | 5d | 2021-08-15 | 2021-08-20 | 158, 160 |  |  |
| 163 | 1.3.30.5.1 | FASE 2 - EDI - SCARICHI SALA LAVAGGI |  | 5d | 2021-08-15 | 2021-08-20 | 158, 160 |  |  |
| 164 | 1.3.30.6 | **FASE 2 - IE - CORRIDOIO** |  | 10d | 2021-08-10 | 2021-08-23 | 154 | start no earlier than 2021-08-02 |  |
| 165 | 1.3.30.6.1 | FASE 2 - IE - CORRIDOIO |  | 10d | 2021-08-10 | 2021-08-23 | 154 | start no earlier than 2021-08-02 | C&P |
| 166 | 1.3.30.7 | **FASE 2 - IM - CORRIDOIO** |  | 10d | 2021-08-10 | 2021-08-23 | 154 | start no earlier than 2021-08-02 |  |
| 167 | 1.3.30.7.1 | FASE 2 - IM - CORRIDOIO |  | 10d | 2021-08-10 | 2021-08-23 | 154 | start no earlier than 2021-08-02 | C&P |
| 168 | 1.3.31 | **RDO APPARECCHI E MATERIALI** |  | 70d | 2021-04-26 | 2021-07-30 | 121 |  |  |
| 169 | 1.3.31.1 | INIZIO RDO | milestone | 0d | 2021-04-26 | 2021-04-26 | 121 |  |  |
| 170 | 1.3.31.2 | **FASE 0 - IM - RDO-ORDINE-COSTRUZIONE APP.PRINCIPALI** |  | 70d | 2021-04-26 | 2021-07-30 | 169 |  |  |
| 171 | 1.3.31.2.1 | FASE 0 - IM - RDO APP PRINCIPALI |  | 20d | 2021-04-26 | 2021-05-21 | 169 |  |  |
| 172 | 1.3.31.2.2 | FASE 0 - IM - ORDINI APP PRINCIPALI | milestone | 0d | 2021-05-24 | 2021-05-24 | 171 |  |  |
| 173 | 1.3.31.2.3 | FASE 0 - IM - Preparazione APP PRINCIPALI |  | 50d | 2021-05-24 | 2021-07-30 | 172 |  |  |
| 174 | 1.3.31.3 | **FASE 0 - IM - RDO-ORDINE-APPROVIG. MATERIALI DORSALI PRINCIPALI** |  | 30d | 2021-04-26 | 2021-06-04 | 169 |  |  |
| 175 | 1.3.31.3.1 | FASE 0 - IM - RDO-ORDINE-APPROVIG. MATERIALI DORSALI PRINCIPALI |  | 30d | 2021-04-26 | 2021-06-04 | 169 |  |  |
| 176 | 1.3.31.4 | **FASE 0 - IM - RDO-ORDINE-APPROVIG. MATERIALI** |  | 40d | 2021-04-26 | 2021-06-18 | 169 |  |  |
| 177 | 1.3.31.4.1 | FASE 0 - IM - RDO MATERIALI |  | 20d | 2021-04-26 | 2021-05-21 | 169 |  |  |
| 178 | 1.3.31.4.2 | FASE 0 - IM - ORDINI MATERIALI | milestone | 0d | 2021-05-24 | 2021-05-24 | 177 |  |  |
| 179 | 1.3.31.4.3 | FASE 0 - IM - PREPARAZIONE MATERIALI |  | 20d | 2021-05-24 | 2021-06-18 | 178 |  |  |

| ID | WBS | Task | Type | Duration | Start | Finish | Predecessors | Baseline start | Baseline finish | Baseline duration | Baseline 1 start | Baseline 1 finish | Resources | Cost | Flag1 | Flag2 | Flag3 | Flag4 | Flag5 | Flag6 | Flag7 | Flag8 | Flag9 | Flag10 | Number1 | Number2 | Number3 | Number4 | Number5 | Budget | Cost3 | Cost4 | Cost5 | Cost6 | Cost7 | Cost8 | Cost9 | Cost10 | Flag11 | Flag12 | Flag13 | Flag14 | Flag15 | Flag16 | Flag17 | Flag18 | Flag19 | Flag20 | Number6 | Number7 | Number8 | Number9 | Number10 | Number11 | Number12 | Number13 | Number14 | Number15 | Number16 | Number17 | Number18 | Number19 | Number20 |
| --- | --- | --- | --- | --- | --- | --- | --- | --- | --- | --- | --- | --- | --- | --- | --- | --- | --- | --- | --- | --- | --- | --- | --- | --- | --- | --- | --- | --- | --- | --- | --- | --- | --- | --- | --- | --- | --- | --- | --- | --- | --- | --- | --- | --- | --- | --- | --- | --- | --- | --- | --- | --- | --- | --- | --- | --- | --- | --- | --- | --- | --- | --- | --- |
| 180 | 1.3.31.5 | **FASE 2 - IE - RDO-ORDINE-APPROVIG. DIST PRINCIPALE** |  | 40d | 2021-04-26 | 2021-06-18 | 169 |  |  |  |  |  |  |  |  |  |  |  |  |  |  |  |  |  |  |  |  |  |  |  |  |  |  |  |  |  |  |  |  |  |  |  |  |  |  |  |  |  |  |  |  |  |  |  |  |  |  |  |  |  |  |  |  |
| 181 | 1.3.31.5.1 | FASE 2 - IE - RDO-ORDINE-APPROVIG. DIST PRINCIPALE |  | 40d | 2021-04-26 | 2021-06-18 | 169 |  |  |  |  |  |  |  |  |  |  |  |  |  |  |  |  |  |  |  |  |  |  |  |  |  |  |  |  |  |  |  |  |  |  |  |  |  |  |  |  |  |  |  |  |  |  |  |  |  |  |  |  |  |  |  |  |
| 182 | 1.3.31.6 | **FASE 0 - IE - RDO-ORDINE-APPROVIG. MATERIALI** |  | 50d | 2021-04-26 | 2021-07-02 | 169 |  |  |  |  |  |  |  |  |  |  |  |  |  |  |  |  |  |  |  |  |  |  |  |  |  |  |  |  |  |  |  |  |  |  |  |  |  |  |  |  |  |  |  |  |  |  |  |  |  |  |  |  |  |  |  |  |
| 183 | 1.3.31.6.1 | FASE 0 - IE - RDO MATERIALI |  | 15d | 2021-04-26 | 2021-05-14 | 169 |  |  |  |  |  |  |  |  |  |  |  |  |  |  |  |  |  |  |  |  |  |  |  |  |  |  |  |  |  |  |  |  |  |  |  |  |  |  |  |  |  |  |  |  |  |  |  |  |  |  |  |  |  |  |  |  |
| 184 | 1.3.31.6.2 | FASE 0 - IE - ORDINI MATERIALI | milestone | 0d | 2021-05-17 | 2021-05-17 | 183 |  |  |  |  |  |  |  |  |  |  |  |  |  |  |  |  |  |  |  |  |  |  |  |  |  |  |  |  |  |  |  |  |  |  |  |  |  |  |  |  |  |  |  |  |  |  |  |  |  |  |  |  |  |  |  |  |
| 185 | 1.3.31.6.3 | FASE 0 - IE - PREPARAZIONE MATERIALI |  | 35d | 2021-05-17 | 2021-07-02 | 184 |  |  |  |  |  |  |  |  |  |  |  |  |  |  |  |  |  |  |  |  |  |  |  |  |  |  |  |  |  |  |  |  |  |  |  |  |  |  |  |  |  |  |  |  |  |  |  |  |  |  |  |  |  |  |  |  |
| 186 | 1.3.31.7 | **FASE 0 - CIV - RDO-ORDINE-APPROVIG. MATERIALI** |  | 45d | 2021-04-26 | 2021-06-25 | 169 |  |  |  |  |  |  |  |  |  |  |  |  |  |  |  |  |  |  |  |  |  |  |  |  |  |  |  |  |  |  |  |  |  |  |  |  |  |  |  |  |  |  |  |  |  |  |  |  |  |  |  |  |  |  |  |  |
| 187 | 1.3.31.7.1 | FASE 0 - CIV - RDO-ORDINE-APPROVIG. MATERIALI |  | 45d | 2021-04-26 | 2021-06-25 | 169 |  |  |  |  |  |  |  |  |  |  |  |  |  |  |  |  |  |  |  |  |  |  |  |  |  |  |  |  |  |  |  |  |  |  |  |  |  |  |  |  |  |  |  |  |  |  |  |  |  |  |  |  |  |  |  |  |
| 188 | 1.4 | **REALIZZAZIONE NUOVI REPARTI** |  | 95d | 2021-09-09 | 2022-01-19 |  |  |  |  |  |  |  |  |  |  |  |  |  |  |  |  |  |  |  |  |  |  |  |  |  |  |  |  |  |  |  |  |  |  |  |  |  |  |  |  |  |  |  |  |  |  |  |  |  |  |  |  |  |  |  |  |  |
| 189 | 1.4.1 | inizio posizionamenti | milestone | 0d | 2021-09-09 | 2021-09-09 | 104, 137, 168 |  |  |  |  |  |  |  |  |  |  |  |  |  |  |  |  |  |  |  |  |  |  |  |  |  |  |  |  |  |  |  |  |  |  |  |  |  |  |  |  |  |  |  |  |  |  |  |  |  |  |  |  |  |  |  |  |
| 190 | 1.4.2 | **FASE 2 - IM - Posizionamento APP PRINCIPALI** |  | 95d | 2021-09-09 | 2022-01-19 | 189 |  |  |  |  |  |  |  |  |  |  |  |  |  |  |  |  |  |  |  |  |  |  |  |  |  |  |  |  |  |  |  |  |  |  |  |  |  |  |  |  |  |  |  |  |  |  |  |  |  |  |  |  |  |  |  |  |
| 191 | 1.4.2.1 | cantierizzazione MECc |  | 5d | 2021-09-09 | 2021-09-15 | 189 |  |  |  |  |  | MECC da assegnare | 6,000 |  |  |  |  |  |  |  |  |  |  |  |  |  |  |  |  |  |  |  |  |  |  |  |  |  |  |  |  |  |  |  |  |  |  |  |  |  |  |  |  |  |  |  |  |  |  |  |  |  |
| 192 | 1.4.2.2 | UTA |  | 15d | 2021-09-16 | 2021-10-06 | 191 | 2021-08-30 | 2021-10-22 | 40d | 2021-08-02 | 2021-09-24 | MECC da assegnare | 194,000 |  |  |  |  |  |  |  |  |  |  |  |  |  |  |  |  |  |  |  |  |  |  |  |  |  |  |  |  |  |  |  |  |  |  |  |  |  |  |  |  |  |  |  |  |  |  |  |  |  |
| 193 | 1.4.2.3 | abbattimento polveri |  | 10d | 2021-10-07 | 2021-10-20 | 192 | 2021-08-30 | 2021-09-24 | 20d | 2021-08-02 | 2021-08-27 | MECC da assegnare | 250,000 |  |  |  |  |  |  |  |  |  |  |  |  |  |  |  |  |  |  |  |  |  |  |  |  |  |  |  |  |  |  |  |  |  |  |  |  |  |  |  |  |  |  |  |  |  |  |  |  |  |
| 194 | 1.4.2.4 | Deumidificatori chimici |  | 65d | 2021-10-21 | 2022-01-19 | 193 | 2021-08-30 | 2021-09-24 | 20d | 2021-08-02 | 2021-08-27 | MECC da assegnare | 197,020 |  |  |  |  |  |  |  |  |  |  |  |  |  |  |  |  |  |  |  |  |  |  |  |  |  |  |  |  |  |  |  |  |  |  |  |  |  |  |  |  |  |  |  |  |  |  |  |  |  |
| 195 | 1.4.3 | **FASE 2 - IM -DORSALI PRINCIPALI** |  | 60d | 2021-09-09 | 2021-12-01 | 189 | 2021-08-30 | 2021-09-24 | 20d | 2021-08-02 | 2021-08-27 |  |  | false | false | false | false | false | false | false | false | false | false | 0.0 | 0.0 | 0.0 | 0.0 | 0.0 | 0.0 | 0.0 | 0.0 | 0.0 | 0.0 | 0.0 | 0.0 | 0.0 | 0.0 | false | false | false | false | false | false | false | false | false | false | 0.0 | 0.0 | 0.0 | 0.0 | 0.0 | 0.0 | 0.0 | 0.0 | 0.0 | 0.0 | 0.0 | 0.0 | 0.0 | 0.0 | 0.0 |
| 196 | 1.4.3.1 | acqua refrigerata |  | 40d | 2021-09-09 | 2021-11-03 | 189 | 2021-08-30 | 2021-09-24 | 20d | 2021-08-02 | 2021-08-27 |  |  | false | false | false | false | false | false | false | false | false | false | 0.0 | 0.0 | 0.0 | 0.0 | 0.0 | 0.0 | 0.0 | 0.0 | 0.0 | 0.0 | 0.0 | 0.0 | 0.0 | 0.0 | false | false | false | false | false | false | false | false | false | false | 0.0 | 0.0 | 0.0 | 0.0 | 0.0 | 0.0 | 0.0 | 0.0 | 0.0 | 0.0 | 0.0 | 0.0 | 0.0 | 0.0 | 0.0 |
| 197 | 1.4.3.2 | acqua calda |  | 20d | 2021-11-04 | 2021-12-01 | 196 | 2021-08-30 | 2021-09-24 | 20d | 2021-08-02 | 2021-08-27 |  |  | false | false | false | false | false | false | false | false | false | false | 0.0 | 0.0 | 0.0 | 0.0 | 0.0 | 0.0 | 0.0 | 0.0 | 0.0 | 0.0 | 0.0 | 0.0 | 0.0 | 0.0 | false | false | false | false | false | false | false | false | false | false | 0.0 | 0.0 | 0.0 | 0.0 | 0.0 | 0.0 | 0.0 | 0.0 | 0.0 | 0.0 | 0.0 | 0.0 | 0.0 | 0.0 | 0.0 |
| 198 | 1.4.3.3 | acqua sanitaria calda-fredda |  | 20d | 2021-11-04 | 2021-12-01 | 196 | 2021-08-30 | 2021-09-24 | 20d | 2021-08-02 | 2021-08-27 |  |  |  |  |  |  |  |  |  |  |  |  |  |  |  |  |  |  |  |  |  |  |  |  |  |  |  |  |  |  |  |  |  |  |  |  |  |  |  |  |  |  |  |  |  |  |  |  |  |  |  |
| 199 | 1.4.3.4 | vapore |  | 20d | 2021-11-04 | 2021-12-01 | 196 | 2021-08-30 | 2021-09-24 | 20d | 2021-08-02 | 2021-08-27 |  |  | false | false | false | false | false | false | false | false | false | false | 0.0 | 0.0 | 0.0 | 0.0 | 0.0 | 0.0 | 0.0 | 0.0 | 0.0 | 0.0 | 0.0 | 0.0 | 0.0 | 0.0 | false | false | false | false | false | false | false | false | false | false | 0.0 | 0.0 | 0.0 | 0.0 | 0.0 | 0.0 | 0.0 | 0.0 | 0.0 | 0.0 | 0.0 | 0.0 | 0.0 | 0.0 | 0.0 |
| 200 | 1.4.3.5 | gas compressi |  | 20d | 2021-11-04 | 2021-12-01 | 196 | 2021-08-30 | 2021-09-24 | 20d | 2021-08-02 | 2021-08-27 | MECC da assegnare | 62,000 |  |  |  |  |  |  |  |  |  |  |  |  |  |  |  |  |  |  |  |  |  |  |  |  |  |  |  |  |  |  |  |  |  |  |  |  |  |  |  |  |  |  |  |  |  |  |  |  |  |
| 201 | 1.4.4 | **FASE 2 -IM - MONTAGGI** |  | 95d | 2021-09-09 | 2022-01-19 | 189 | 2021-08-30 | 2021-10-22 | 40d | 2021-08-02 | 2021-09-24 |  |  | false | false | false | false | false | false | false | false | false | false | 0.0 | 0.0 | 0.0 | 0.0 | 0.0 | 0.0 | 0.0 | 0.0 | 0.0 | 0.0 | 0.0 | 0.0 | 0.0 | 0.0 | false | false | false | false | false | false | false | false | false | false | 0.0 | 0.0 | 0.0 | 0.0 | 0.0 | 0.0 | 0.0 | 0.0 | 0.0 | 0.0 | 0.0 | 0.0 | 0.0 | 0.0 | 0.0 |
| 202 | 1.4.4.1 | FASE 2 - IM - CONSEGNA MATERIALI IMPIANTI | milestone | 0d | 2021-09-09 | 2021-09-09 | 189 |  |  |  |  |  |  |  |  |  |  |  |  |  |  |  |  |  |  |  |  |  |  |  |  |  |  |  |  |  |  |  |  |  |  |  |  |  |  |  |  |  |  |  |  |  |  |  |  |  |  |  |  |  |  |  |  |
| 203 | 1.4.4.2 | impianto HVAC - montaggio distribuzione aeraulica |  | 95d | 2021-09-09 | 2022-01-19 | 202 | 2021-08-30 | 2021-10-22 | 40d | 2021-08-02 | 2021-09-24 | MECC da assegnare | 488,000 | false | false | false | false | false | false | false | false | false | false | 0.0 | 0.0 | 0.0 | 0.0 | 0.0 | 430000.0 | 0.0 | 0.0 | 0.0 | 0.0 | 0.0 | 0.0 | 0.0 | 0.0 | false | false | false | false | false | false | false | false | false | false | 0.0 | 0.0 | 0.0 | 0.0 | 0.0 | 0.0 | 0.0 | 0.0 | 0.0 | 0.0 | 0.0 | 0.0 | 0.0 | 0.0 | 0.0 |
| 204 | 1.4.4.3 | piping |  | 20d | 2021-09-09 | 2021-10-06 | 202 | 2021-08-30 | 2021-09-24 | 20d | 2021-08-02 | 2021-08-27 |  |  | false | false | false | false | false | false | false | false | false | false | 0.0 | 0.0 | 0.0 | 0.0 | 0.0 | 0.0 | 0.0 | 0.0 | 0.0 | 0.0 | 0.0 | 0.0 | 0.0 | 0.0 | false | false | false | false | false | false | false | false | false | false | 0.0 | 0.0 | 0.0 | 0.0 | 0.0 | 0.0 | 0.0 | 0.0 | 0.0 | 0.0 | 0.0 | 0.0 | 0.0 | 0.0 | 0.0 |
| 205 | 1.4.4.4 | corpi meccanici per supervisione e regolazione |  | 1d | 2021-09-09 | 2021-09-09 | 202 | 2021-08-30 | 2021-08-30 | 1d | 2021-08-02 | 2021-08-02 | MECC da assegnare | 218,000 |  |  |  |  |  |  |  |  |  |  |  |  |  |  |  |  |  |  |  |  |  |  |  |  |  |  |  |  |  |  |  |  |  |  |  |  |  |  |  |  |  |  |  |  |  |  |  |  |  |

| ID | WBS | Task | Type | Duration | Start | Finish | Predecessors | Baseline start | Baseline finish | Baseline duration | Baseline 1 start | Baseline 1 finish | Resources | Cost | Flag1 | Flag2 | Flag3 | Flag4 | Flag5 | Flag6 | Flag7 | Flag8 | Flag9 | Flag10 | Number1 | Number2 | Number3 | Number4 | Number5 | Budget | Cost3 | Cost4 | Cost5 | Cost6 | Cost7 | Cost8 | Cost9 | Cost10 | Flag11 | Flag12 | Flag13 | Flag14 | Flag15 | Flag16 | Flag17 | Flag18 | Flag19 | Flag20 | Number6 | Number7 | Number8 | Number9 | Number10 | Number11 | Number12 | Number13 | Number14 | Number15 | Number16 | Number17 | Number18 | Number19 | Number20 |
| --- | --- | --- | --- | --- | --- | --- | --- | --- | --- | --- | --- | --- | --- | --- | --- | --- | --- | --- | --- | --- | --- | --- | --- | --- | --- | --- | --- | --- | --- | --- | --- | --- | --- | --- | --- | --- | --- | --- | --- | --- | --- | --- | --- | --- | --- | --- | --- | --- | --- | --- | --- | --- | --- | --- | --- | --- | --- | --- | --- | --- | --- | --- | --- |
| 206 | 1.4.5 | **FASE 2 - IE - DISTRIBUZIONE PRINCIPALE A Q.E. DI REPARTO** |  | 60d | 2021-09-09 | 2021-12-01 | 189 |  |  |  |  |  |  |  |  |  |  |  |  |  |  |  |  |  |  |  |  |  |  |  |  |  |  |  |  |  |  |  |  |  |  |  |  |  |  |  |  |  |  |  |  |  |  |  |  |  |  |  |  |  |  |  |  |
| 207 | 1.4.5.1 | distribuzione elettrica principale |  | 60d | 2021-09-09 | 2021-12-01 | 189 | 2021-08-30 | 2021-10-22 | 40d | 2021-08-02 | 2021-09-24 |  |  | false | false | false | false | false | false | false | false | false | false | 0.0 | 0.0 | 0.0 | 0.0 | 0.0 | 86300.0 | 0.0 | 0.0 | 0.0 | 0.0 | 0.0 | 0.0 | 0.0 | 0.0 | false | false | false | false | false | false | false | false | false | false | 0.0 | 0.0 | 0.0 | 0.0 | 0.0 | 0.0 | 0.0 | 0.0 | 0.0 | 0.0 | 0.0 | 0.0 | 0.0 | 0.0 | 0.0 |
| 208 | 1.4.6 | **FASE 2 - IE - DISTRIBUZIONE REPARTO** |  | 95d | 2021-09-09 | 2022-01-19 | 189 | 2021-08-30 | 2021-11-12 | 55d | 2021-08-02 | 2021-10-15 |  | 508,800 |  |  |  |  |  |  |  |  |  |  |  |  |  |  |  |  |  |  |  |  |  |  |  |  |  |  |  |  |  |  |  |  |  |  |  |  |  |  |  |  |  |  |  |  |  |  |  |  |  |
| 209 | 1.4.6.1 | inizio montaggi elettrici | milestone | 0d | 2021-09-09 | 2021-09-09 | 189 |  |  |  |  |  |  |  |  |  |  |  |  |  |  |  |  |  |  |  |  |  |  |  |  |  |  |  |  |  |  |  |  |  |  |  |  |  |  |  |  |  |  |  |  |  |  |  |  |  |  |  |  |  |  |  |  |
| 210 | 1.4.6.2 | posizionamento quadri elettrici di reparto |  | 5d | 2021-09-09 | 2021-09-15 | 209 | 2021-08-30 | 2021-09-03 | 5d | 2021-08-02 | 2021-08-06 | ELE da assegnare | 83,000 | false | false | false | false | false | false | false | false | false | false | 0.0 | 0.0 | 0.0 | 0.0 | 0.0 | 350000.0 | 0.0 | 0.0 | 0.0 | 0.0 | 0.0 | 0.0 | 0.0 | 0.0 | false | false | false | false | false | false | false | false | false | false | 0.0 | 0.0 | 0.0 | 0.0 | 0.0 | 0.0 | 0.0 | 0.0 | 0.0 | 0.0 | 0.0 | 0.0 | 0.0 | 0.0 | 0.0 |
| 211 | 1.4.6.3 | FM |  | 5d | 2021-09-09 | 2021-09-15 | 209 | 2021-08-30 | 2021-09-03 | 5d | 2021-08-02 | 2021-08-06 | ELE da assegnare | 77,300 | false | false | false | false | false | false | false | false | false | false | 0.0 | 0.0 | 0.0 | 0.0 | 0.0 | 350000.0 | 0.0 | 0.0 | 0.0 | 0.0 | 0.0 | 0.0 | 0.0 | 0.0 | false | false | false | false | false | false | false | false | false | false | 0.0 | 0.0 | 0.0 | 0.0 | 0.0 | 0.0 | 0.0 | 0.0 | 0.0 | 0.0 | 0.0 | 0.0 | 0.0 | 0.0 | 0.0 |
| 212 | 1.4.6.4 | quadri di termoregolazione |  | 5d | 2021-09-09 | 2021-09-15 | 209 | 2021-08-30 | 2021-09-03 | 5d | 2021-08-02 | 2021-08-06 |  |  | false | false | false | false | false | false | false | false | false | false | 0.0 | 0.0 | 0.0 | 0.0 | 0.0 | 350000.0 | 0.0 | 0.0 | 0.0 | 0.0 | 0.0 | 0.0 | 0.0 | 0.0 | false | false | false | false | false | false | false | false | false | false | 0.0 | 0.0 | 0.0 | 0.0 | 0.0 | 0.0 | 0.0 | 0.0 | 0.0 | 0.0 | 0.0 | 0.0 | 0.0 | 0.0 | 0.0 |
| 213 | 1.4.6.5 | postazioni di lavoro |  | 5d | 2021-09-09 | 2021-09-15 | 209 | 2021-08-30 | 2021-09-03 | 5d | 2021-08-02 | 2021-08-06 |  |  | false | false | false | false | false | false | false | false | false | false | 0.0 | 0.0 | 0.0 | 0.0 | 0.0 | 350000.0 | 0.0 | 0.0 | 0.0 | 0.0 | 0.0 | 0.0 | 0.0 | 0.0 | false | false | false | false | false | false | false | false | false | false | 0.0 | 0.0 | 0.0 | 0.0 | 0.0 | 0.0 | 0.0 | 0.0 | 0.0 | 0.0 | 0.0 | 0.0 | 0.0 | 0.0 | 0.0 |
| 214 | 1.4.6.6 | distribuzione elettrica secondaria |  | 95d | 2021-09-09 | 2022-01-19 | 209 | 2021-08-30 | 2021-10-22 | 40d | 2021-08-02 | 2021-09-24 | ELE da assegnare | 207,000 | false | false | false | false | false | false | false | false | false | false | 0.0 | 0.0 | 0.0 | 0.0 | 0.0 | 86300.0 | 0.0 | 0.0 | 0.0 | 0.0 | 0.0 | 0.0 | 0.0 | 0.0 | false | false | false | false | false | false | false | false | false | false | 0.0 | 0.0 | 0.0 | 0.0 | 0.0 | 0.0 | 0.0 | 0.0 | 0.0 | 0.0 | 0.0 | 0.0 | 0.0 | 0.0 | 0.0 |
| 215 | 1.4.6.7 | Illuminazione ordinaria+emergenza |  | 55d | 2021-09-09 | 2021-11-24 | 209 | 2021-08-30 | 2021-11-12 | 55d | 2021-08-02 | 2021-10-15 | ELE da assegnare | 141,500 |  |  |  |  |  |  |  |  |  |  |  |  |  |  |  |  |  |  |  |  |  |  |  |  |  |  |  |  |  |  |  |  |  |  |  |  |  |  |  |  |  |  |  |  |  |  |  |  |  |
| 216 | 1.4.7 | **FASE 2 - IE - IMPIANTI SPECIALI E DI REGOLAZIONE** |  | 95d | 2021-09-09 | 2022-01-19 | 189 | 2021-08-30 | 2021-12-10 | 75d | 2021-08-02 | 2021-10-08 |  |  |  |  |  |  |  |  |  |  |  |  |  |  |  |  |  |  |  |  |  |  |  |  |  |  |  |  |  |  |  |  |  |  |  |  |  |  |  |  |  |  |  |  |  |  |  |  |  |  |  |
| 217 | 1.4.7.1 | inizio impianti speciali | milestone | 0d | 2021-09-09 | 2021-09-09 | 189 |  |  |  |  |  |  |  |  |  |  |  |  |  |  |  |  |  |  |  |  |  |  |  |  |  |  |  |  |  |  |  |  |  |  |  |  |  |  |  |  |  |  |  |  |  |  |  |  |  |  |  |  |  |  |  |  |
| 218 | 1.4.7.2 | Rete dati per Regolazione e controllo (QE-> Armadio di rete) |  | 50d | 2021-09-09 | 2021-11-17 | 217 | 2021-08-30 | 2021-12-10 | 75d | 2021-08-02 | 2021-10-08 | ELE da assegnare | 152,000 |  |  |  |  |  |  |  |  |  |  |  |  |  |  |  |  |  |  |  |  |  |  |  |  |  |  |  |  |  |  |  |  |  |  |  |  |  |  |  |  |  |  |  |  |  |  |  |  |  |
| 219 | 1.4.7.3 | Rete dati per Monitoraggio energia (QE-> Armadio di rete) |  | 1d | 2021-09-09 | 2021-09-09 | 217 | 2021-08-30 | 2021-08-30 | 1d | 2021-08-30 | 2021-08-30 |  |  |  |  |  |  |  |  |  |  |  |  |  |  |  |  |  |  |  |  |  |  |  |  |  |  |  |  |  |  |  |  |  |  |  |  |  |  |  |  |  |  |  |  |  |  |  |  |  |  |  |
| 220 | 1.4.7.4 | Rete dati Fonia, TVCC, controllo accessi |  | 1d | 2021-09-09 | 2021-09-09 | 217 | 2021-08-30 | 2021-08-30 | 1d | 2021-08-30 | 2021-08-30 |  |  |  |  |  |  |  |  |  |  |  |  |  |  |  |  |  |  |  |  |  |  |  |  |  |  |  |  |  |  |  |  |  |  |  |  |  |  |  |  |  |  |  |  |  |  |  |  |  |  |  |
| 221 | 1.4.7.5 | Armadi di rete |  | 1d | 2021-09-09 | 2021-09-09 | 217 | 2021-08-30 | 2021-08-30 | 1d | 2021-08-30 | 2021-08-30 |  |  |  |  |  |  |  |  |  |  |  |  |  |  |  |  |  |  |  |  |  |  |  |  |  |  |  |  |  |  |  |  |  |  |  |  |  |  |  |  |  |  |  |  |  |  |  |  |  |  |  |
| 222 | 1.4.7.6 | Fonia |  | 1d | 2021-09-09 | 2021-09-09 | 217 | 2021-08-30 | 2021-08-30 | 1d | 2021-08-30 | 2021-08-30 |  |  |  |  |  |  |  |  |  |  |  |  |  |  |  |  |  |  |  |  |  |  |  |  |  |  |  |  |  |  |  |  |  |  |  |  |  |  |  |  |  |  |  |  |  |  |  |  |  |  |  |
| 223 | 1.4.7.7 | TVCC |  | 1d | 2021-09-09 | 2021-09-09 | 217 | 2021-08-30 | 2021-08-30 | 1d | 2021-08-30 | 2021-08-30 |  |  |  |  |  |  |  |  |  |  |  |  |  |  |  |  |  |  |  |  |  |  |  |  |  |  |  |  |  |  |  |  |  |  |  |  |  |  |  |  |  |  |  |  |  |  |  |  |  |  |  |
| 224 | 1.4.7.8 | LICENZA ACRON (Estensione) |  | 1d | 2021-09-09 | 2021-09-09 | 217 | 2021-08-30 | 2021-08-30 | 1d | 2021-08-30 | 2021-08-30 |  |  |  |  |  |  |  |  |  |  |  |  |  |  |  |  |  |  |  |  |  |  |  |  |  |  |  |  |  |  |  |  |  |  |  |  |  |  |  |  |  |  |  |  |  |  |  |  |  |  |  |
| 225 | 1.4.7.9 | Monitoraggio ambientale |  | 1d | 2021-09-09 | 2021-09-09 | 217 | 2021-08-30 | 2021-08-30 | 1d | 2021-08-30 | 2021-08-30 |  |  |  |  |  |  |  |  |  |  |  |  |  |  |  |  |  |  |  |  |  |  |  |  |  |  |  |  |  |  |  |  |  |  |  |  |  |  |  |  |  |  |  |  |  |  |  |  |  |  |  |
| 226 | 1.4.7.10 | Rilevazione incendi e centrale DEF |  | 95d | 2021-09-09 | 2022-01-19 | 217 | 2021-08-30 | 2021-10-08 | 30d | 2021-08-30 | 2021-10-08 | ELE da assegnare | 35,458 |  |  |  |  |  |  |  |  |  |  |  |  |  |  |  |  |  |  |  |  |  |  |  |  |  |  |  |  |  |  |  |  |  |  |  |  |  |  |  |  |  |  |  |  |  |  |  |  |  |
| 227 | 1.4.7.11 | Monitoraggio energia |  | 1d | 2021-09-09 | 2021-09-09 | 217 | 2021-08-30 | 2021-08-30 | 1d | 2021-08-30 | 2021-08-30 |  |  |  |  |  |  |  |  |  |  |  |  |  |  |  |  |  |  |  |  |  |  |  |  |  |  |  |  |  |  |  |  |  |  |  |  |  |  |  |  |  |  |  |  |  |  |  |  |  |  |  |
| 228 | 1.4.8 | **FASE 3- IE - COLLEGAMENTI "ULTIMO METRO"** |  | 95d | 2021-09-09 | 2022-01-19 | 189 |  |  |  |  |  |  |  |  |  |  |  |  |  |  |  |  |  |  |  |  |  |  |  |  |  |  |  |  |  |  |  |  |  |  |  |  |  |  |  |  |  |  |  |  |  |  |  |  |  |  |  |  |  |  |  |  |
| 229 | 1.4.8.1 | Distribuzione elettrica-ultimo metro a FM |  | 95d | 2021-09-09 | 2022-01-19 | 189 | 2021-08-30 | 2021-08-30 | 1d | 2021-08-02 | 2021-08-02 |  |  |  |  |  |  |  |  |  |  |  |  |  |  |  |  |  |  |  |  |  |  |  |  |  |  |  |  |  |  |  |  |  |  |  |  |  |  |  |  |  |  |  |  |  |  |  |  |  |  |  |
| 230 | 1.4.8.2 | Distribuzione elettrica-ultimo metro a macchine |  | 95d | 2021-09-09 | 2022-01-19 | 189 | 2021-08-30 | 2021-08-30 | 1d | 2021-08-02 | 2021-08-02 |  |  |  |  |  |  |  |  |  |  |  |  |  |  |  |  |  |  |  |  |  |  |  |  |  |  |  |  |  |  |  |  |  |  |  |  |  |  |  |  |  |  |  |  |  |  |  |  |  |  |  |

| ID | WBS | Task | Duration | Start | Finish | Predecessors | Baseline start | Baseline finish | Baseline duration | Baseline 1 start | Baseline 1 finish | Resources | Cost | Flag1 | Flag2 | Flag3 | Flag4 | Flag5 | Flag6 | Flag7 | Flag8 | Flag9 | Flag10 | Number1 | Number2 | Number3 | Number4 | Number5 | Budget | Cost3 | Cost4 | Cost5 | Cost6 | Cost7 | Cost8 | Cost9 | Cost10 | Flag11 | Flag12 | Flag13 | Flag14 | Flag15 | Flag16 | Flag17 | Flag18 | Flag19 | Flag20 | Number6 | Number7 | Number8 | Number9 | Number10 | Number11 | Number12 | Number13 | Number14 | Number15 | Number16 | Number17 | Number18 | Number19 | Number20 |
| --- | --- | --- | --- | --- | --- | --- | --- | --- | --- | --- | --- | --- | --- | --- | --- | --- | --- | --- | --- | --- | --- | --- | --- | --- | --- | --- | --- | --- | --- | --- | --- | --- | --- | --- | --- | --- | --- | --- | --- | --- | --- | --- | --- | --- | --- | --- | --- | --- | --- | --- | --- | --- | --- | --- | --- | --- | --- | --- | --- | --- | --- | --- |
| 231 | 1.4.9 | **FASE 2 - CIV - MONTAGGI e POSA (finiture)** | 85d | 2021-09-09 | 2022-01-05 | 189 | 2021-08-30 | 2021-11-05 | 50d | 2021-08-02 | 2021-10-22 |  |  |  |  |  |  |  |  |  |  |  |  |  |  |  |  |  |  |  |  |  |  |  |  |  |  |  |  |  |  |  |  |  |  |  |  |  |  |  |  |  |  |  |  |  |  |  |  |  |  |  |
| 232 | 1.4.9.1 | inizio attività civili | 10d | 2021-09-09 | 2021-09-22 | 189 | 2021-09-13 | 2021-09-24 | 10d | 2021-08-16 | 2021-08-27 |  |  |  |  |  |  |  |  |  |  |  |  |  |  |  |  |  |  |  |  |  |  |  |  |  |  |  |  |  |  |  |  |  |  |  |  |  |  |  |  |  |  |  |  |  |  |  |  |  |  |  |
| 233 | 1.4.9.2 | bussole ed interblocchi | 75d | 2021-09-23 | 2022-01-05 | 232 | 2021-09-27 | 2021-10-01 | 5d | 2021-08-30 | 2021-09-03 |  |  |  |  |  |  |  |  |  |  |  |  |  |  |  |  |  |  |  |  |  |  |  |  |  |  |  |  |  |  |  |  |  |  |  |  |  |  |  |  |  |  |  |  |  |  |  |  |  |  |  |
| 234 | 1.4.9.3 | civile farma | 40d | 2021-09-23 | 2021-11-17 | 232 | 2021-09-27 | 2021-10-22 | 20d | 2021-08-30 | 2021-10-22 | CIVILE FARMA da assegnare | 755,000 | false | false | false | false | false | false | false | false | false | false | 0.0 | 0.0 | 0.0 | 0.0 | 0.0 | 680000.0 | 0.0 | 0.0 | 0.0 | 0.0 | 0.0 | 0.0 | 0.0 | 0.0 | false | false | false | false | false | false | false | false | false | false | 0.0 | 0.0 | 0.0 | 0.0 | 0.0 | 0.0 | 0.0 | 0.0 | 0.0 | 0.0 | 0.0 | 0.0 | 0.0 | 0.0 | 0.0 |
| 235 | 1.4.9.4 | resinatura | 30d | 2021-09-23 | 2021-11-03 | 232 | 2021-09-27 | 2021-11-05 | 30d | 2021-08-30 | 2021-10-08 | CIVILE FARMA da assegnare | 121,000 | false | false | false | false | false | false | false | false | false | false | 0.0 | 0.0 | 0.0 | 0.0 | 0.0 | 144000.0 | 0.0 | 0.0 | 0.0 | 0.0 | 0.0 | 0.0 | 0.0 | 0.0 | false | false | false | false | false | false | false | false | false | false | 0.0 | 0.0 | 0.0 | 0.0 | 0.0 | 0.0 | 0.0 | 0.0 | 0.0 | 0.0 | 0.0 | 0.0 | 0.0 | 0.0 | 0.0 |
| 236 | 1.4.9.5 | attività_7981 | 1d | 2021-09-13 | 2021-09-13 |  |  |  |  |  |  |  |  |  |  |  |  |  |  |  |  |  |  |  |  |  |  |  |  |  |  |  |  |  |  |  |  |  |  |  |  |  |  |  |  |  |  |  |  |  |  |  |  |  |  |  |  |  |  |  |  |  |
