# BKLM Sanierung Großküche 2204 und Bistro 2205

Schedule from GanttProject, 2023-06-19 to 2023-08-11.
Kreis Borken Hochbau 8150

## Calendars

- Project calendar: Mon-Fri working; Sat-Sun off.

## Schedule

| ID | Task | Duration | Start | Finish | Predecessors |
| --- | --- | --- | --- | --- | --- |
| 1 | Sommerferien NRW 2023 | 32d | 2023-06-22 | 2023-08-04 |  |
| 2 | Leerräumen der Küche Theke | 3d | 2023-06-19 | 2023-06-21 |  |
| 3 | HLSE abklemmen | 2d | 2023-06-22 | 2023-06-23 |  |
| 4 | Rückbau Küche +Theke Bistro | 5d | 2023-06-26 | 2023-06-30 |  |
| 5 | Rückbau Abhangdecken | 2d | 2023-07-03 | 2023-07-04 |  |
| 6 | Gerüstbau | 3d | 2023-06-22 | 2023-06-26 |  |
| 7 | PV-Anlage Demontieren | 3d | 2023-06-27 | 2023-06-29 |  |
| 8 | Flachdachsanierung | 15d | 2023-06-29 | 2023-07-19 |  |
| 9 | Stahlkonstruktion aufstellen | 3d | 2023-07-10 | 2023-07-12 |  |
| 10 | Absturzsicherung | 4d | 2023-07-20 | 2023-07-25 |  |
| 11 | Montage Lüftungsanlage | 10d | 2023-07-26 | 2023-08-08 |  |
| 12 | Grobinstallation HLSE | 10d | 2023-07-05 | 2023-07-18 | 5 |
| 13 | Neue Fensterbänke | 2d | 2023-07-05 | 2023-07-06 |  |
| 14 | Trockenbau Neue Decken Schächte schließen | 5d | 2023-07-10 | 2023-07-14 |  |
| 15 | Wandverkleidung Kunststoff | 5d | 2023-07-17 | 2023-07-21 |  |
| 16 | Neuer Bodenbelag | 5d | 2023-07-24 | 2023-07-28 |  |
| 17 | Malerarbeiten | 5d | 2023-07-31 | 2023-08-04 |  |
| 18 | Montage Küche | 5d | 2023-08-07 | 2023-08-11 |  |
| 19 | Feininstallation HLSE | 3d | 2023-08-09 | 2023-08-11 |  |
