Schedule from GanttProject, 2023-02-01 to 2024-05-06.

## Calendars

- Project calendar: Mon-Fri working; Sat-Sun off.

## Schedule

| ID | WBS | Task | Type | Duration | Start | Finish | Predecessors | ID |
| --- | --- | --- | --- | --- | --- | --- | --- | --- |
| 1 | 1 | **PROCESS FLOWSHEET** |  | 329d | 2023-02-01 | 2024-05-06 |  | 82 |
| 2 | 1.1 | Licitacion y contrato |  | 107d | 2023-02-01 | 2023-06-29 |  | 83 |
| 3 | 1.2 | **Fase 1** |  | 43d | 2023-07-03 | 2023-08-30 | 2 | 84 |
| 4 | 1.2.1 | Envio muestras |  | 6d | 2023-07-03 | 2023-07-10 |  | 85 |
| 5 | 1.2.2 | Pruebas mineralogicas |  | 32d | 2023-07-11 | 2023-08-23 | 4 | 86 |
| 6 | 1.2.3 | Informe final |  | 5d | 2023-08-24 | 2023-08-30 | 5 | 87 |
| 7 | 1.3 | **Fase 2** |  | 96d | 2023-10-02 | 2024-02-12 | 3 | 88 |
| 8 | 1.3.1 | Envio muestras |  | 6d | 2023-10-02 | 2023-10-09 |  | 89 |
| 9 | 1.3.2 | Realizacion pruebas metalurgicas |  | 75d | 2023-10-10 | 2024-01-22 | 8 | 90 |
| 10 | 1.3.3 | Informe final |  | 15d | 2024-01-23 | 2024-02-12 | 9 | 91 |
| 11 | 1.3.4 | Block Flow & Design Criteria | milestone | 0d | 2023-11-28 | 2023-11-28 | 9SS+35d |  |
| 12 | 1.4 | **Fase 4 - Variability testing** |  | 50d | 2024-02-27 | 2024-05-06 | 7 | 92 |
| 13 | 1.4.1 | Preparacion e inicio |  | 15d | 2024-02-27 | 2024-03-18 |  | 93 |
| 14 | 1.4.2 | Tests sobre concentrado |  | 25d | 2024-03-19 | 2024-04-22 | 13 | 94 |
| 15 | 1.4.3 | Informe final Flowsheet |  | 10d | 2024-04-23 | 2024-05-06 | 14 | 95 |
