# PLANEAMENTO

Schedule from GanttProject, 2023-04-14 to 2024-11-12.
ON-LIFT

## Calendars

- Project calendar: Mon-Sun working.

## Resources

| Resource |
| --- |
| ATR |
| AND |
| VTR |
| GON |
| SUB |
| AE |
| JC |
| N/A |
| SCA |

## Schedule

| ID | WBS | Task | Type | Duration | Start | Finish | Complete | Resources | Cost | CLIENTE | EQPMTO | FT/PGM | LOCALIDADE |
| --- | --- | --- | --- | --- | --- | --- | --- | --- | --- | --- | --- | --- | --- |
| 1 | 1 | **ON ENCOMENDAR** |  | 49d | 2024-07-29 | 2024-09-15 |  |  |  | NOME |  |  |  |
| 2 | 1.1 | 113CP23 | milestone | 0d | 2024-07-29 | 2024-07-29 |  |  |  | FRANCISCO PEDREIRA FILHOS | GMV | 45/0 | MONÇÃO |
| 3 | 1.2 | 171CP24 | milestone | 0d | 2024-09-16 | 2024-09-16 |  |  |  | ESCALA GLOBAL | GMV | 45/0 | PORTO |
| 4 | 1.3 | 183RB23 | milestone | 0d | 2024-09-12 | 2024-09-12 |  |  |  | MARGARIDA BRAZ BORGES | SUPRA LINEA | 65/0 | SINTRA |
| 5 | 1.4 | 225RB23 | milestone | 0d | 2024-07-29 | 2024-07-29 |  |  |  | CONDOMINIO BARAO DO CORVO | GMV | 45/45 | VILA NOVA GAIA |
| 6 | 1.5 | 216RB21 | milestone | 0d | 2024-07-29 | 2024-07-29 |  | AE |  | OLIVIA CASTRO | MC | 40/40 | OVAR |
| 7 | 1.6 | 175RB23 | milestone | 0d | 2024-07-29 | 2024-07-29 |  |  |  | CRESCER COM SAUDE | GMV | 40/40 | COIMBRA |
| 8 | 1.7 | 114RB21 | milestone | 0d | 2024-07-29 | 2024-07-29 |  | AE |  | ANTONIO ASCENÇÃO COELHO FILHOS | MONTA CARGAS PLH200 | 10/10 | TEIXOSO |
| 9 | 1.8 | 068RB20 | milestone | 0d | 2024-07-29 | 2024-07-29 |  |  |  | FABRICA DE HEUS | GMV | 60/60 | CARTAXO |
| 10 | 1.9 | 174CP24 | milestone | 0d | 2024-08-26 | 2024-08-26 |  |  |  | JOSE SILVA | GMV | 45/45 | VALBOM |
| 11 | 2 | **ON PRODUÇÃO** |  | 149d | 2024-06-17 | 2024-11-12 |  |  |  | NOME |  |  |  |
| 12 | 2.1 | 204RB22 |  | 65d | 2024-09-09 | 2024-11-12 |  |  |  | LUCIANA AUGUSTA CARVALHO DA SILVA | GMV | 45/45 | PAÇOS FERREIRA |
| 13 | 2.2 | 131RB23 |  | 89d | 2024-07-22 | 2024-10-18 |  |  |  | INTERLOVERS (2P/AUTO) | GMV | 45/45 | RIO MAIOR |
| 14 | 2.3 | 011RB20 |  | 101d | 2024-06-17 | 2024-09-25 |  |  |  | ANTONIO ASCENSÃO COELHO E FILHOS (2P/AUTO) | MONTA MACAS GMV 600KG/8 P | 40/40 | TEIXOSO |
| 15 | 2.4 | 014RB24 |  | 95d | 2024-06-17 | 2024-09-19 |  |  |  | EFIMA (2P/BAT) | H200 | 40/40 | SERTÃ |
| 16 | 2.5 | 106RB23 |  | 95d | 2024-06-17 | 2024-09-19 |  |  |  | CASASIMETRICA (4P/BAT) | H200 | 40/40 | MAFRA |
| 17 | 3 | **!!! ON POR CONCLUIR !!!** |  | 4d | 2024-09-13 | 2024-09-16 |  |  |  |  |  |  |  |
| 18 | 3.1 | 183CP23 | milestone | 0d | 2024-09-13 | 2024-09-13 | 100% | ATR; GON | 100.1 | CM CARREGAL DO SAL - MONTAGEM | GMV | 100/100 | CARREGAL DO SAL |
| 19 | 3.2 | 159RB22 | milestone | 0d | 2024-09-13 | 2024-09-13 |  | GON |  | CONSTRU - CONCLUSÃO (1D/1H) | H200 | 100/95 | BRAGA |
| 20 | 3.3 | 139DM20 | milestone | 0d | 2024-09-13 | 2024-09-13 |  |  |  | CERVIMAT (?VISITAR?) | DOMOSTEP | 95/95 | ALIJO |
| 21 | 3.4 | 037DM21 | milestone | 0d | 2024-09-13 | 2024-09-13 |  |  |  | NORCEP (1D/1H) | MC | 95/95 | PORTO |
| 22 | 3.5 | 130RB21 | milestone | 0d | 2024-09-13 | 2024-09-13 |  |  |  | FLORESTABEMCUIDADA (7D/2H) | GMV | 90/90 | GUARDA |
| 23 | 3.6 | 011RB22 | milestone | 0d | 2024-09-13 | 2024-09-13 |  | AE |  | CARI CONST. (LUCIANO CORDEIRO) - FALTA AUTO | MONTA AUTOS 3000KG | 95/95 | LISBOA |
| 24 | 3.7 | 093RB22 | milestone | 0d | 2024-09-13 | 2024-09-13 |  | GON |  | ROSA AFONSO (1D/1H) | H200 | 95/95 | MELGAÇO |
| 25 | 3.8 | 156DM20 | milestone | 0d | 2024-09-13 | 2024-09-13 |  | GON |  | ALCADO PONTUAL (2D/2H) | GMV | 100/95 | VIEIRA MINHO |

Notes:
- 2: 02/9/24 / CPI PASSOU NA OBRA AINDA EM DEMOLIÇÕES / 23/4/24 / CPI ENVIOU SMS PARA ENG GABINETE A SOLICITAR INFO
- 5: 15/7/24 / HOMELIFT COM ESTRUTURA, N TEMOS CONDIÇÕES PARA INSTALARMOS À DATA. / 07/7/24 / MANTEM-SE INFO ABAIXO / 25/6/24 / MANTEM-SE INFO ABAIXO / 17/6/24 / MANTEM-SE INFO ABAIXO / 29/4/24 / MANTEM-SE INFO ABAIXO / 19/1/24 / CLIENTE RESPONDEU A DIZER QUE AGUARDA PARECER TEC DO ENG / 11/9/23 / PROBLEMAS COM CRGAS NA LAJE
- 6: 16/7/24 / Boa tarde Eng. Carlos Pinto . / Estas obras que lhe estou enviar não tem condições pra se encomendar, já falei com os clientes para serem contactados a partir de 15-9-24 ok / 07/7/24 / JC VAI PASSAR PARA AVALIAR SITUAÇÃO DE OBRA / 25/6/24 / MESMO ESTADO / 29/4/24 / MESMO ESTADO / 29/4/24 / JC VISITOU OBRA, AINDA ATRASADA / 01/03/24 / JC VISITOU OBRA, AINDA ATRASADA / 19/01/24 / RF CONFIRMA ORDEM DE FABRICO PELA PARTE DE RB. / JÁ PAGÁMOS 35% À AUTOELEVAÇÃO / 15/12/23 / CLIENTE INFORMOU JC + RB QUE OBRA ESTÁ EMBARGADA / 07/12/23 / JC+CP VISITARAMOBRA DIA 06/12, AINDA SEM JANELAS / JC VAI ENVIAR EMAIL AO CLIENTE / 30/11/23 / JC VAI VISITAR OBRA / 10/11/23 / INSTALAÇÃO AE / 25/8/23 / SEM CONDIÇÕES OBRA PARA APROVAR / RB EM MAR23 CONFIRMA MEDIDAS À AE / RB EM NOV22 PEDIU INFO À AE / RB EM JUN22 CANCELOU PEDIDO À HIDRAL
- 7: 16/7/24 / Boa tarde Eng. Carlos Pinto . / Estas obras que lhe estou enviar não tem condições pra se encomendar, já falei com os clientes para serem contactados a partir de 15-9-24 ok / 08/7/24 / JC VAI FALAR COM CLIENTE ESTA WK / 25/6/24 / JC DISSE A RB PARA N ENCOMENDAR / CLIENTE DISSE AO JC Q OBRA ESTÁ PREVISTA PARA OUTUBRO / 17/6/24 / VAMOS ENCOMENDAR ESTA WK / 29/4/24 / JC VISITOU OBRA / ENCOMENDAR PARA JULHO / 16/2/24 / JC CONFIRMA OBRA ATRASADA, SO PARA MAIO / 19/1/24 / JC CONFIRMA OBRA ATRADA, SÓ DAQUI A 6M / 30/11/23 / JC DIZ Q OBRA ESTÁ ATRASADA
- 8: 29/7/24 / ENCOMENDAR EM SETEMBRO / 17/6/24 / ESTA OBRA N É NO MESMO EDIFICIO DO GMV / OBRA ATRASADA / 29/4/24 / AINDA SEM INFO PARA AVANÇAR
- 9: 02/9/24 / CLIENTE PAGOU ADJ A 28/8/24 / AGENDAR VISITA À OBRA
- 12: 29/7/24 / VISITA AGENDADA PARA 9/8/24 / 08/7/24 / CLIENTE PEDE CONTATO DE SUPERVISOR / JC FICOU DE AGENDAR VISITA / 17/6/24 / JC LIGOU MAS CLINET EN DEVOLVEU CHAMADA / 29/4/24 / MANTEM-SE INFO ANTERIOR / 08/3/24 / -apos visita à obra, ficou agendada visita´para 15/5 / -cliente ainda n sabe se pretende obra em agosto ououtubro / 05/7/23 / -visita à obra c/JC / -verificação de medidas no poço, OK / -nova reunião agendada p/NOV / -cliente ficou de decidir q tipo de portas vai escolher
- 13: 09/9/24 / RF FICOU DE REENVIAR EMAIL PARA CONFIRMAR ENTREGA / 02/9/24 / CLIENTE ENVIOU EMAIL COM QUESTÕES / 01/7/24 / ENVIAMOS EMAIL PARA SICMALEVA "SUSPENDER PROD" ATÉ PAGAMENTO DE ADJ / NS S24395
- 14: 09/9/24 / RF FICOU DE REENVIAR EMAIL PARA CONFIRMAR ENTREGA / 17/6/24 / ESTA WK VAMOS ENCOMENDAR / 29/4/24 / AINDA SEM INFO PARA AVANÇAR
- 15: 02/9/24 / RF FICOU DE ENVIAR EMAIL PARA SABER ENTREGA / 29/7/24 / JC INFORMOU CLIENTE FINAL DE SET / 17/6/24 / previsão de encomenda para esta wk
- 16: 09/9/24 / RF VAI ENVIAR EMAIL PARA CONFIRMAR RECOLHA COM OBRA EFIMA / 17/6/24 / vamos encomendar esta wk
- 18: 13/9/24 / RF PEDIU FOTOS DOS REMATES / 29/7/24 / CLIENTE AINDA N FEZ REMATES DE PORTAS
- 19: 09/9/24 / RF JÁ SOLICITOU PAGAMENTO DA CONCLUSÃO / 07/8/24 / reunião em obra com arq vilaca / tec tem de passar para retirar espelhos e botão
- 20: 24/7/24 / VISITA À OBRA, AINDA FECHADA / 17/6/24 / JC DIZ Q ENG FRANCISCO N DIZ NADA / DECIIDIDO FATURAR A 3ª TRANCHE / 27/5/24 / CERVIMAT C/PROBLEMAS C/CLIENTE FINAL / 20/5/24 / JC VAI FALAR COM ENG FRANCISCO / 06/5/24 / JC VAI TRNTAR NOVO CONTATO COM ENG FRANCISCO / 29/4/24 / JC VAI LIGAR COM ENG FRANCISCO / 26/01/24 / JC VAI FALAR C/ENG RODRIGUES PARA CONCLUIR / 01/09/23 / INSTALAR FECHADURA ELETRICA / 30/06/23 / 1 DIA DE TRABALHO
- 21: 22/7/24 / TEMOS MATERIAIS EM ARMAZEM PARA COLOCA NA OBRA / 25/6/24 / S/FEEDBACK / 06/5/24 / S/FEEDBACK / 26/2/24 / JC ENVIOU EMAIL A CLIENTE, CLIENTE N DEU FEEDBACK / 16/2/24 / CLIENTE LIGOU A JC A INFORMAR QUE ENTROU AGUA NA PLATAFORMA / 17/11/23 / JC VAI AGENDAR VISITA COM CLIENTE / 10/11/23 / JC VAI FAZER VISITA À OBRA 13/11/23 / 18/8/23 / CLIENTE TEM DE LIQUIDAR MATERIAIS ATÉ 24/8/23 / RF VAI FATURAR ARMAZENAMENTO NO FINAL MONTAGEM / 04/8/23 / INFORMAR CLIENTE ATÉ 18/8 / 30/6/23 / JC FEZ VISITA A OBRA, CLIENTE VAI LIGAR DIA 17/7 / OBRA SEM CONDIÇÕES / MATERIAL EM ARMAZEM
- 22: 17/6/24 / JC VISITOU OBRA / FAZER ORÇAMENTO PARA REPARAÇÃO E CONCLUSÃO / PINTAR PISTÃO / PINTAR ARCADA / SUBSTITUIR CABOS / PREPARAR CENTRAL / 27/5/24 / CLIENTE PEDIU A JC UMA VISITA / VAI AGENDAR VISITA / 29/4/24 / JC TEM DE AGENDAR VISITA À OBRA / 07/12/23 / JC VAI ANALISAR PARA POSSIVEL VISITA NO INICIO DE 2024 / 20/10/23 / Exmos, / No passado dia 27/9/23, realizamos uma visita à obra para perceber a possibilidade de calendarizar a conclusão dos trabalhos, por parte da On-Lift. / Anexamos fotos, tiradas no dia da visita. O equipamento encontra-se com sinais de elevada deterioração. / Aproveitamos para informar que a On-Lift, não se responsabiliza pelos danos apresentados em anexo. / 29/9/23 / ANDRE FEZ VISITA, MATERIAIS COM FERRUGEM E SEM CONDIÇÕES PARA CONCLUIR / 01/9/23 / FAZER VISITA À OBRA / 15/6/23 / CLIENTE SEM CONDIÇÕES DE OBRA PARA CONCLUIR / +-4 DIAS / 09/9/22 / Como sabido de vossa parte ontem entramos em obra para fazer a montagem do Homelift . / Verificarmos que estrutura não esta fechada ,e divido a pressão exercida para o inicio da montagem ,e mesmo analisando o que inicialmente referi ,iniciamos a montagem . / Devido ao motivo acima por mim referido ,alertarmos que declinamos qualquer prejuízo no nosso equipamento montado . / Como por exemplo entrada de agua devido a chuva que pode ocorrer .
- 23: 05/8/24 / cliente quer certificados antes do pagamento final / 29/7/24 / RF ENVIOU EMAIL PARA GERAL / VAI LIGAR PARA REFORÇAR / 08/7/24 / RF JÁ SOLIUCITOU AUTO PARA PODERMOS FATURAR CONCLUSÃO / 25/6/24 / AINDA N TEMOS CONDIÇÕES PARA CONCLUIR, INFO JC / 27/5/24 / AINDA N TEMOS CONDIÇÕES PARA CONCLUIR, INFO JC / 20/5/24 / JC INFORMOU QUE CLIENTE AINDA N NOS DÁ CONDIÇÕES PARA ACABAR OBRA / CLIENTE AINDA COM TRANSITO DE MATERIAIS / 13/5/24 / JC VAI LIGAR COM AE, PARA SABER DATA DE COMCLUSÃO EM OBRA / 06/5/24 / JC VAI LIGAR COM AE, PARA SABER DATA DE COMCLUSÃO EM OBRA / 29/4/29 / JC VAI LIGAR COM AE, PARA SABER DATA DE COMCLUSÃO EM OBRA / 19/4/24 / JC VAI LIGAR COM AE, PARA SABER DATA DE COMCLUSÃO EM OBRA / 01/3/24 / JC VAI CONFIRMAR ENTRADA DE OBRA COM AE / 12/1/24 / N ENTRAMOS NA WK2 CONFORME AE. / JC AGUARDA INFO DA AE / 07/12/23 / AGUARDAMOS PAGAMENTO DOS MATERIAIS / 10/11/23 / JC EVIOU EMAIL PARA AE A CONFIRMAR ENTRADA EM OBRA PARA 20/11/23 / AE TEM DE ENVIAR DOCUMENTAÇÃO DE TÉCNICOS / 28/8/23 / CLIENTE PAGOU MAIOR VALIA EM AGOSTO / ENCOMENDADO NO INICIO DE MARÇO / JC ESTEVE EM OBRA E DISSE AO FORN QUE A INSTALAÇÃO ESTARIA PREVISTA PARA JUNHO23
- 24: 25/6/24 / VISITA À OBRA DIA 18/6/24, VISITA À OBRA JC+CP / ACORDADO EM REPARAR A PORTA, PINTOR ENVIA FATURA DE REPARAÇÃO DA PORTA / FICA A FALTAR LIMPEZAS E AFINAÇÕES FINAIS / 27/5/24 / PASSAR EM OBRA NA MONTAGEM DA MEZESI / 01/03/24 / 2D+2H / DIA 22/2/24, JC E CP, VISITARAM OBRA, AINDA SEM ACABEMENTO DE CHAO NA GARAGEM. / AGUARDAMOS REGRESSO DO CLIENTE, EM FINAIS DE MARÇO PARA CONCLUIR A RECLAMAÇÃO. / 13/10/23 / CLIENTE ENVIOU FOTOS 04/10/23, AINDA FALTAM TRABALHOS DE REMATE / 25/9/23 / ANDRÉ INFORMOU QUE SÓ FALTAM LIMPEZAS E AFINAÇÕES / ANDRÉ TBM DIZ Q FALTAM PUXADORES / CLIENTE TEM DE FECHAR REMATES / 11/9 / REPORTE ADR, FALTA MONTAR CABINA E ELETRIFICAÇÃO, 1DIA / PORTA DANIFICADA / 25/8 / AGUARDAMOS AUTO DE ANDRE / AGUARDAMOS CONTATO CLIENTE PARA CONFIRMAR NOVA COLOCAÇÃO DE PRUMOS / 30/6 / COM CONDIÇOES PARA CONCLUIR / -3 DIAS / 1/6 / MATERIAL EM OBRA / SEM CONDIÇÕES DE OBRA P/INICIAR TRABALHOS
- 25: 09/9/24 / RF VAI PREPARAR PROCESSO PARA INJUNÇÃO / 08/8/24 / RF VAI ENVIAR CARTA REG / 22/7/24 / FALTA COLOCAR BETONEIRAS / CLIENTE FICOU DE FORRAR CABINA / 27/5/24 / RF VAI ANALISAR PROCESSO / FATURAMOS CONCLUSÃO A SET23 / 20/5/24 / ENVIAR CARTA? / MONTADO EM NOV21 / 17/5/23 / CLIENTE INFORMOU VIA TELEFONE (OUTUBRO) QUE N TEM CONDIÇÕES PARA CONCLUIR A OBRA / 20/10/23 / SÓ VAMOS MONTAR QUANDO CLIENTE PAGAR. / 01/9/23 / MONTADO EM NOV21 / FATURAR CONCLUSÃO / 15/6 / FALTA 2 DIAS / FALTAM ACABAMENTOS POR PARTE DO CLIENTE

| ID | WBS | Task | Type | Duration | Start | Finish | Predecessors | Resources | CLIENTE | EQPMTO | FT/PGM | LOCALIDADE |
| --- | --- | --- | --- | --- | --- | --- | --- | --- | --- | --- | --- | --- |
| 26 | 4 | **ON MONTAGEM / SERVIÇO** |  | 70d | 2024-07-24 | 2024-10-01 |  |  |  |  |  |  |
| 27 | 4.1 | 136CP24 | milestone | 0d | 2024-09-20 | 2024-09-20 |  | GON | BRUNO SOUSA - MONTAGEM | GMV | 80/80 | CAMINHA |
| 28 | 4.2 | 075LG22 |  | 5d | 2024-09-23 | 2024-09-27 |  | ATR | JOSE ALMEIDA (2P/AUTO) | H200 | 95/95 | CESAR |
| 29 | 4.3 | 164RB22 |  | 5d | 2024-09-23 | 2024-09-27 |  | ATR | DGPW (2P/AUTO) | GMV | 40/40 | SEIA |
| 30 | 4.4 | 132RB22 |  | 2d | 2024-09-23 | 2024-09-24 |  | ATR | JORGE MANUEL SÁ M. GOUVEIA (2P) | PH300 | 100/100 | VILA NOVA GAIA |
| 31 | 4.5 | 215RB22 |  | 4d | 2024-09-23 | 2024-09-26 |  | ATR | MARIA JOSE TEIXEIRA FERNANDES FERREIRA (2P) | SUPRA | 100/80 | RIO TINTO |
| 32 | 4.6 | 167RB21 |  | 5d | 2024-09-23 | 2024-09-27 |  | ATR | CARMA COSTA (3P/AUTO) | GMV | 100/100 | ALVERCA |
| 33 | 4.7 | 057RB20 |  | 1d | 2024-10-01 | 2024-10-01 |  | GON | JOSE ROSA - CONCLUSÃO (1D/2H) | H200 | 100/95 | AVEIRO |
| 34 | 4.8 | 062RB21 |  | 1d | 2024-09-25 | 2024-09-25 | 35 | GON | NOVA GENTE (BLOCO2) - CONCLUSÃO (1D/1H) | H200 | 95/95 | LEIRIA |
| 35 | 4.9 | 062RB21 |  | 1d | 2024-09-24 | 2024-09-24 |  | GON | NOVA GENTE (BLOCO1) - CONCLUSÃO (1D/1H) | H200 | 95/95 | LEIRIA |
| 36 | 4.10 | 011RB23 |  | 1d | 2024-09-19 | 2024-09-19 |  | GON | TEAGA II - CONCLUSÃO (1D/1H) | DOMOFLEX 2 | 100/100 | OLIVEIRA FRADES |
| 37 | 4.11 | 229RB23 |  | 3d | 2024-09-20 | 2024-09-22 |  | ATR | ANTONIO JOAQUIM FERREIRA (2P/MEIAPORTA) | DOMOFLEX | 95/95 | MOSTEIRO DE FRAGUAS |
| 38 | 4.12 | 227RB23 |  | 2d | 2024-09-17 | 2024-09-18 | 39 | GON; SUB | EFIMA (MIRA SINTRA) - MONTAGEM (2D/2H) | SUPRA | 95/40 | AGUALVA - CACEM |
| 39 | 4.13 | 227RB23 |  | 1d | 2024-09-16 | 2024-09-16 |  | GON; SUB | EFIMA (MIRA SINTRA) - MONTAGEM (1D/2H) | FLOW X | 40/40 | AGUALVA - CACEM |
| 40 | 4.14 | 164CP24 | milestone | 0d | 2024-09-16 | 2024-09-16 |  |  | DESCARGA DGPW |  |  |  |
| 41 | 4.15 | OT |  | 1d | 2024-09-11 | 2024-09-11 |  | GON | SERVIÇO AV/REP | VARIOS |  |  |
| 42 | 4.16 | 032RB24 |  | 14d | 2024-09-04 | 2024-09-17 |  | ATR | CONST. SANTOVAIENSE - MONTAGEM (2P/AUTO/ESTRUTURA) | GMV + ESTRT. | 95/95 | AVEIRO |
| 43 | 4.17 | 208RB23 |  | 2d | 2024-09-11 | 2024-09-12 |  | SUB | COSTEIRA - MONTAGEM | HDP-V | 50/50 | SÃO MAMEDE INFESTA |
| 44 | 4.18 | OT |  | 2d | 2024-09-02 | 2024-09-03 |  | GON | SERVIÇO AV/REP | VARIOS |  |  |
| 45 | 4.19 | 144CP24 |  | 2d | 2024-08-26 | 2024-08-27 | 53 | AE | FLOPONOR - MONTAGEM | MC | 100/45 |  |
| 46 | 4.20 | 221RB23 |  | 1d | 2024-08-08 | 2024-08-08 |  | GON | EFIMA (AUDITORIO MAFRA) - CONCLUSÃO (1D/1H) | GMV | 100/95 | MAFRA |
| 47 | 4.21 | 187CP23 |  | 14d | 2024-07-24 | 2024-08-06 |  | ATR; GON | CONSTRUÇÕES MAZESI - MONTAGEM | GMV | 100/90 | MONÇÃO |
| 48 | 5 | **ON CONCLUIDAS** |  | 498d | 2023-04-14 | 2024-08-23 |  |  |  |  |  |  |
| 49 | 5.1 | 136CP24 |  | 9d | 2024-07-15 | 2024-07-23 |  |  | BRUNO SOUSA - MONTAGEM | GMV | 100/80 | CAMINHA |
| 50 | 5.2 | 079RB23 |  | 1d | 2024-08-12 | 2024-08-12 | 55 | ATR; GON | FLOPONOR | SUPRA L | 100/100 | TONDELA |
| 51 | 5.3 | 032RB24 | milestone | 0d | 2024-08-01 | 2024-08-01 |  |  | DESCARGA SANTOVAIENSE |  |  |  |

Notes:
- 27: 20/9/24 / GR VAI SUBSTITUIR A PLACA / 20/5/24 / PRONTO EM ITALIA 6/6 / 23/4/24 / CPI R JC FAZEM VISITA À FAZINVENTA PARA VERIFICAR CABINA E PORTAS
- 28: 08/7/24 / 2PISOS PORTAS AUTOMÁTICAS / MANTEM-SE INFO ANTERIOR / 25/6/24 / JC VAI AVISAR CLIENTE Q SÓ TEMOS CONDIÇOES PARA SETEMBRO / 07/6/24 / VAI MARCAR COM SERRALHEIRO / JC FEZ VISITA E SEM CONDIÇÕES / 27/5/24 / JC DIZ Q VAI AGENDAR VISITA / 20/5/24 / JC DIZ Q VAI AGENDAR VISITA / 06/5/24 / CLIENTE RESPONDEU A PEDIR REUNIÃO EM OBRA / 29/4/24 / RF ENVIOU EMAIL PARA CLIENTE A INFORMAR QUE NECESSITAMOS DE 3MESES PARA PROGRAMAR ENTRADA EM OBRA / 01/3/24 / ENVIAMOS EMAIL AO CLIENTE, RF TEM RESPOSTA SEM DATA POR PARTE DO CLIENTE / 07/12/23 / JC VAI ENVIAR INFO A CLIENTE / 17/11/23 / JC+CP PASSARAM NA OBRA A 15/11/23 OBRA AINDA POR FECHAR E SEM CONDIÇÕES / 11/9/23 / 2 stop / ENTREGAMOS MATERIAL / OBRA AINDA TODA ABERTA SEM JANELAS / 04/8/23 / AINDA SEM CONDIÇÕES DE ENTREGA NA OBRA / 29/7/23 / VAMOS DESCARREGAR MATERIAIS WK32 / 07/7/23 / MATERIAL EM ARMAZEM
- 29: 08/8/24 / CLIENTE QUER MATERIAIS E 2 SEMANDAS DE CALENDARIO PARA INICIO MONTAGEM / PREVISÃO WK38 / 25/6/24 / JS VAI ENVIAR EMAIL PARA CLIENTE A CONFIRMAR MONTAGEM / 20/5/24 / PRONTO EM ITALIA A 6/6
- 30: 22/7/24 / AGENDAR PARA SETEMBRO / MANUEL COSTA APPC 933 341 457 / 13/5/24 / CLIENTE ENVIOU SMS PARA JC A PEDIR MONTAGEM APENAS PARA JUNHO / JÁ AGENDAMOS A UM SABADO E N TIVEMOS ABERTURA POR PARTE DA CLIENTE / 2 A 3 DIAS 2HOMENS / 31/11/23 / JC VAI REUNIR C/RESPONSAVEL PRESCRITOR / 17/11/23 / ENVIAR CARTA REGISTADA? / 20/10/23 / CLIENTE N RESPONDEU A O EMAIL. / 25/9/23 / VITOR PASSOU NA OBRA, ENVIOU FOTOS PARA MIM, MATERIAL À INTEMPÉRIE / VERIFICAR INICIO DE GARANTIA / 15/9/23 / ANDRÉ PASSOU DIA 14/9, NINGUEM ESTAVA NA OBRA NEM ATENDERAM CHAMADAS. / 11/9/23 / PASSAR PARA VER SE EXISTEM CONDIÇÕES / 07/7/23 / CLIENTE N TEM CONDIÇÕES P/REALIZAR OBRAS / 30/6/23 / APENAS ENTREGAR / N SE CONSEGUE CONTATAR CLIENTE / JC VAI PASSAR NA CASA DO CLIENTE
- 31: 08/7/24 / JC VAI ENVIAR NOVAMENTE EMAIL PARA MONTORO / 25/6/24 / JC VAI ENVIAR EMAIL PARA MONTORO / 17/6/24 / AGURDAMOS DECISÃO DA ACCESS / 27/5/24 / JC ENVIOU MENSAGEM AO MONTORO / JC VAI FALAR COM CB / 20/5/24 / JC INFORMOU Q RB VAI FALAR COM MONTORO / 2 DIAS 2 HOMENS / 06/5/24 / PROBLEMAS DE MONTAGEM / JC E RB VÃO VISITAR OBRA / 23/2/24 / alterar configuração da plt / sem flap traseiro / 16/2/24 / FALTA APROVAÇÃO JC / alterar configuração da plt / sem flap traseiro
- 32: 12/8/24 / VER POSSIBILIADE DE FATURAR BATERIAS DE EMERGÊNCIA / FALEI C/CLIENTE, VAMOS REUNIR NA 1ªWK DE SET / TEM QUESTÕES COM AUTONIVELAMENTO (+3MM) + CHÃO(15MM) / FICOU DE ENVIAR FOTOS DA ZONA PERTO DAS PORTAS / 29/9/23 / 3 STOPS - PORTAS AUTOMATICAS / OBRA ZERO MONTAGEM / RB ESTEVE COM CLIENTE / MATERIAIS NO ARMAZEM DO CLIENTE / OBRA AINDA ABERTA E ATRASADA / 17/7/23 / 3 STOPS - PORTAS AUTOMATICAS / JC PASSOU EM OBRA, AINDA SEM CONDIÇÕES, ACORDADO C/CLIENTE PARA SET / 30/6/23 / CLIENTE JÁ LIQUIDOU ENTREGA MATERIAIS / CLIENTE SEM CONDIÇÕES DE OBRA
- 33: 12/8/24 / FALEI HJ C/CLIENTE, TROCOU DE EMPRESA DE CONSTRUÇÃO, VAO AVANÇAR COM OS RESTANTES TRABALHOS EM SETEMBRO. / PREVÊ TERMOS CONDIÇÕES EM INICIO DE OUTUBRO / POÇO COM AGUA / 08/7/24 / TEMOS CONDIÇÕES PARA ACABAR / SENSOR INDUTIVO PARA SUBSTITUIR - CABINA / PEDIR COR RAL PAR APORTAS / 27/5/24 / SENSOR INDUTIVO PARA SUBSTITUIR - CABINA / 20/5/24 / SENSOR INDUTIVO PARA SUBSTITUIR / 16/2/24 / FICA A FALTAR 1 DIA 2H / 07/12/23 / JC FICOU DE AGENDAR COM CLIENTE NOVA VISITA / 10/11/23 / PROBLEMAS NA DESCARGA, MATEIAL N FOI ENTREGUE NO DIA PEDIDO / 29/9/23 / RF FATUROU ENTREGA / 01/9/23 / MATERIAL EM ARMAZÉM / FATURAR ENTREGA + CUSTOS ARMAZENAMENTO / RF FICOU DE FALAR COM CLIENTE / 30/6/23 / JC VAI FALAR C/CLIENTE, P/FAZER ENTREGA / MATERIAL EM ARMAZEM / OBRA SEM CONDIÇÕES PARA ENTRAR EM OBRA / DT ENVIAR EMAIL P/ALERTAR CUSTOS DE ARMAZENAMENTO
- 34: 22/7/24 / ENTREGAR ATÉ SETEMBRO / COLOCAR CALHA / 08/7/24 / CLIENTE LIGOU A JC / PEDE VISITA A OBRA / 27/5/24 / CLIENTE PEDE CONCLUSÃO PARA SETEMBRO / 06/5/24 / JC VAI PASSAR ESTA WK / 15/12/23 / JC COMBINOU COM CLIENTE QUE FAZIA A DESCARGA / 20/5/24 / JC FEZ VISITA À OBRA , CLIENTE PEDIU Q A GARANTIA DO EQUIPAMENTO COMECE EM SET, NO ARRANQUE DA ESCOLA / FALTAM LIMPEZAS / 06/5/24 / JC VAI PASSAR ESTA WK / 15/12/23 / JC COMBINOU COM CLIENTE QUE FAZIA A DESCARGA
- 35: 22/7/24 / ENTREGAR ATÉ SETEMBRO / COLOCAR CALHA / 08/7/24 / CLIENTE LIGOU A JC / PEDE VISITA A OBRA / 27/5/24 / CLIENTE PEDE CONCLUSÃO PARA SETEMBRO / 06/5/24 / JC VAI PASSAR ESTA WK / 15/12/23 / JC COMBINOU COM CLIENTE QUE FAZIA A DESCARGA / 20/5/24 / JC FEZ VISITA À OBRA , CLIENTE PEDIU Q A GARANTIA DO EQUIPAMENTO COMECE EM SET, NO ARRANQUE DA ESCOLA / FALTAM LIMPEZAS / 06/5/24 / JC VAI PASSAR ESTA WK / 15/12/23 / JC COMBINOU COM CLIENTE QUE FAZIA A DESCARGA
- 36: 08/7/24 / OBRA OK PARA FINALIZAR / 25/6/24 / JÁ RECEBEMOS PLACA / SEM DATA PARA FAZER TRABALHOS / 27/5/24 / AGUARDAMOS PLACA DA FABRICA / 20/5/24 / FALTA SUBSTITUIR PLACA DE PISO / RF PEDE À FABRICA / 06/5/24 / JC INFORMA Q CLIENTE NOS CONTACTE PARA CONCLUIR / FALTA METER PORTAS E LIGAR / 3D/2H / 02/5/24 / ENTRAMOS E VAMOS CONCLUIR EM FINAIS DE MAIO / 05/4/24 / RF INFORMA QUE VAI COMEÇAR A SER COBRADO ARMAZENAMENTO A PARTIR DE 01/4 / 19/1/24 / RB PEDIU À FÁBRICA PARA ENTREGAR NA 1ª WK DE ABRIL
- 37: 08/7/24 / CLIENTE LIGOU JC VAI FAZER VISITA A OBRA / 17/6/24 / MATERIAL ENTREGUE / 27/5/24 / JC VAI AGENDAR VISITA PARA ENTREGAR MATERIAI / 20/5/24 / JC VAI AGENDAR VISITA PARA ENTREGAR MATERIAIS / 06/5/24 / JC VAI AGENDAR VISITA PARA ENTREGAR MATERIAIS / 29/4/24 / JC VAI AGENDAR VISITA PARA ENTREGAR MATERIAIS / 12/4/24 / JC ESTEVE NA OBRA MAS N APARECEU NINGUEM / 05/4/24 / RF INFORMA QUE VAI COMEÇAR A SER COBRADO ARMAZENAMENTO A PARTIR DE 01/422/3/24 / MATERIAL EM ARMAZEM €€ / 08/03/34 / CLIENTE SÓ ARRANCA OBRA EM FINAIS DE MARÇO / 02/02/24 / JC VAI LIGAR A CLIENTE PARA ENTREGAR EQ. / 26/01/24 / JC VAI LIGAR A CLIENTE PARA ENTREGAR EQ. / 05/01/24 / CLIENTES FORAM PARA O BRASIL / JC VAI LIGAR C/DIREÇÃO DE OBRA PARA ENTREGAR EQUIPAMENTO / 15/12/23 / JC FEZ VISITA À OBRA, MAS SEM SUCESSO, NINGUÉM ATENDEU / 17/11/23 / RB DIZ Q CLIENTE SÓ TEM CONDIÇÕES A PARTIR 15/1/23
- 38: 15/7/24 / JC FICOU DE VER CUSTOS DE MONTAGEM COM AE / 08/7/24 / CLIENTE PEDIU PARA INICIAR MONTAGEM SEMANA 29 / 27/5/24 / VAI SER DESCARREGADA EM OBRA / 15/3/24 / pagamento a 90D / podemos antecipar o pagamento a 60D, ver necessidade na wk anterior a montagem
- 39: 15/7/24 / JC FICOU DE VER CUSTOS DE MONTAGEM COM AE
- 40: 29/7/24 / Bom dia Sr.º Jorge, / Conforme combinado através de nossa conversa ocorrida na passada sexta, venho indicar a morada da entrega do equipamento sobre o cliente acima indicado: / - Centro Paroquial de Seia / Rua da Carvalha do Outeiro / 6270-500 Seia / https://maps.app.goo.gl/3sca7emmUX7tFxEZ7 / O transporte e como já tinha sido adiantado pelo Sr.º Jose Costa, será acordado entre o Sr.º Jorge e o nosso fornecedor. / O valor acordado e na sequência dos anteriores equipamentos, será de 150,,00€.
- 41: . BOMBEIROS / . MONTEMOR / . CLIENTE MAN COIMBRA
- 42: 25/6/24 / CLIENTE TEM DE "PARTIR" JC VAI FALAR QDO MATERIAL ESTIVER CONFIRMADO EM TRANSITO / 15/5/24 / ESCOLA TEM DE SER FINALIZADO ANTES DO INICIO DO ANO LETIVO / 06/5/24 / RB ESTÁ A ESPERA DE PROJETO PARA FAZER ENCOMENDA / 29/4/24 / JC VAI COM RB PARA RETIFICAR MEDIDAS
- 43: 13/9/24 / FALTA RECEBER AUTO / 29/7/24 / RF VAI PEDIR ORÇAMENTO À AE / 08/7/24 / JC FICOU DE FALAR COM AUTOELEVAÇÃO PARA SABER SE PODIA FAZER INSTALAÇÃO / 20/5/24 / JC TENTOU MARCAR REUNIÃO, CLIENTE INFORMOU QUE SÓ APLICA DATAS SE A CM MATOSINHOS APLICAR AS MULTAS. / AE INFORMOU Q EQUPAMENTO VAI ESTAR PRONTO NA WK27 / 06/5/24 / JC VAI ENVIAR EMAIL PARA SOLICITAR DATA DE ENTREGA / JC CONFIRMADO O PROCESSO DE INICIO DE FABRICO / JC TELEFONOU A CLIENTE, O ENG ESTÁ EMBRA PARA ZONA DE LISBOA / 29/4/24 / AR CONFIRMA 8 WKS DE PROD
- 45: 26/8/24 / RF VAI PEDIR AUTO / 05/7/24 / voltamos a solicitar datas / 29/7/24 / solicitamos entrega
- 46: 13/9/24 / RF FICOU DE EXECUTAR CONFIRMING / 29/7/24 / faturação final em 22/4/24 - fim 22/8/24 / CLIENTE PEDIU PARA CONCLUIR / Ex.mos Senhores / No seguimento do V. fornecimento e instalação de plataforma na obra supra citada, vimos pelo presente solicitar V. deslocação para a ligação, colocação em marcha e entrega de certificados. / Face a estar próxima a entrega do edifico ao Dono de Obra solicitamos que esta seja feita sem falta antes do dia 09.08.2024. / 08/7/24 / JC DIZ Q SO FALTA LIMPAR E AFINAR / 25/6/24 / MANTEM INFO ANTERIOR / 27/5/24 / JC PASSOU EM OBRA 23/6/24, OBRA ATRASADA / 20/5/24 / JC INFORMOU Q CLIENTE N DISSE NADA / 22/3/24 / FALTAM LIPEZAS E AJUSTES FINAIS - 1D1H / 26/2/24 / AGUARDAMOS AUTO PARA FATURAR / JC VAI PASSAR NA OBRA / 04/11/23 / DLINE 31/1/24
- 47: 20/5/24 / PRONTO EM ITALIA A 06/6 / 31/10/23 / data de reunião em obra / . Carlos Pinto / José Costa / Engª Virgina / Sr Manuel / . previsão de entrada em obra Mai'24 / . previsão de conclusão de obra Jul'24
- 49: 02/9/24 / PRECISAMOS DA PLACA PARA ACABAR / 20/5/24 / PRONTO EM ITALIA 6/6 / 23/4/24 / CPI R JC FAZEM VISITA À FAZINVENTA PARA VERIFICAR CABINA E PORTAS
- 50: 08/8/24 / 50% a pp com auto e data de receção da fatura na empresa / rf vai pedir auto
- 51: 24/7/24 / Total de volumes: 17 / MUITO IMPORTANTE VERIFICAR VIDROS SE ESTÁ TUDO BEM – MATERIAL MUITO FRÁGIL / Bom dia Sr.º Jorge, / Conforme combinado através de nossa conversa ocorrida na passada sexta, venho indicar a morada da entrega do equipamento sobre o cliente acima indicado: / - Escola Ensino Básico 2º e 3º Ciclo de Aradas / Rua da Maurícia – Aradas / 3810-433 Aveiro / https://maps.app.goo.gl/hmvmXWEcqws5hBkq8 / Pela informação transmitida pelo Eng.º Leitão, a entrega está apontada para a parte da tarde. / O valor acordado e na sequência dos anteriores equipamentos e sua constituição (estrutura autoportante), será de 200,00€. / 16/7/24 / Boa tarde Sr. Eng. Jorge Leitao. / Preciso que o material do On acima referido seja descarregado entre o dia 26-7 e o dia 29-7-24 o limite máximo, se for antes melhor , temos multas grandes preciso mesmo da sua ajuda pra esta obra ok

| ID | WBS | Task | Type | Duration | Start | Finish | Predecessors | Resources | CLIENTE | EQPMTO | FT/PGM | LOCALIDADE |
| --- | --- | --- | --- | --- | --- | --- | --- | --- | --- | --- | --- | --- |
| 52 | 5.4 | **144CP24** |  | 31d | 2024-07-24 | 2024-08-23 |  | AE | FLOPONOR | MC | 45/45 |  |
| 53 | 5.4.1 | 144CP24 |  | 31d | 2024-07-24 | 2024-08-23 |  | AE | FLOPONOR | MC | 45/0 |  |
| 54 | 5.5 | OT | milestone | 0d | 2024-07-31 | 2024-07-31 |  | GON | MAN/AV/REP | VARIOS | 0/0 | NRT |
| 55 | 5.6 | 079RB23 |  | 24d | 2024-07-15 | 2024-08-07 |  |  | FLOPONOR | SUPRA L | 50/50 | TONDELA |
| 56 | 5.7 | ON | milestone | 0d | 2024-07-29 | 2024-07-29 |  | AE | ENTREGAR COMANDOS + FORMAÇÃO (?VISITAR?) | SUPRA L | 100/100 | FOZ COA |
| 57 | 5.8 | 187CP23 | milestone | 0d | 2024-07-10 | 2024-07-10 |  |  | DESCARGA MAZESI |  |  |  |
| 58 | 5.9 | OT |  | 1d | 2024-07-08 | 2024-07-08 |  | ATR; GON | MAN/AV/REP - MEIRINHOS | VARIOS | 0/0 | NRT |
| 59 | 5.10 | **032RB24** |  | 59d | 2024-05-13 | 2024-07-10 |  |  | CONST. SANTOVAIENSE | GMV + ESTRT. | 40/40 | AVEIRO |
| 60 | 5.10.1 | 032RB24 |  | 59d | 2024-05-13 | 2024-07-10 |  |  | CONST. SANTOVAIENSE | GMV + ESTRT. | 40/40 | AVEIRO |
| 61 | 5.11 | **136CP24** |  | 109d | 2024-04-01 | 2024-07-18 |  |  | BRUNO SOUSA | GMV | 80/80 | CAMINHA |
| 62 | 5.11.1 | 136CP24 |  | 109d | 2024-04-01 | 2024-07-18 |  |  | BRUNO SOUSA | GMV | 80/80 | CAMINHA |
| 63 | 5.12 | 115RB23 |  | 11d | 2024-06-21 | 2024-07-01 |  |  | CERVIMAT (FRANCELOS) | GMV | 100/100 | VILA NOVA GAIA |
| 64 | 5.13 | 090DM20 | milestone | 0d | 2024-05-29 | 2024-05-29 |  | ATR; VTR | BEHIND SOLUTIONS - INEM | MONTA AUTOS - AE | 100/100 | PORTO |
| 65 | 5.14 | OT |  | 2d | 2024-05-27 | 2024-05-28 |  | ATR; VTR | MAN/AV/REP - CASA AMARELA | VARIOS | 0/0 | SUL-SINTRA |
| 66 | 5.15 | 078RB22 |  | 9d | 2024-05-28 | 2024-06-05 | 116 | AND; GON | CERVIMAT (ESC. BAS. CORREIOS) - MONTAGEM | GMV | 100/65 | PORTO |
| 67 | 5.16 | OT |  | 1d | 2024-07-03 | 2024-07-03 |  | GON | MAN/AV/REP | VARIOS | 0/0 | SUL-SINTRA |
| 68 | 5.17 | **187CP23** |  | 97d | 2024-03-22 | 2024-06-26 |  |  | CONSTRUÇÕES MAZESI | GMV | 90/90 | MONÇÃO |
| 69 | 5.17.1 | 187CP23 |  | 97d | 2024-03-22 | 2024-06-26 |  |  | CONSTRUÇÕES MAZESI | GMV | 90/90 | MONÇÃO |
| 70 | 5.18 | **164RB22** |  | 83d | 2024-04-05 | 2024-06-26 |  |  | DGPW | GMV | 40/40 | SEIA |
| 71 | 5.18.1 | 164RB22 |  | 83d | 2024-04-05 | 2024-06-26 |  |  | DGPW | GMV | 40/40 | SEIA |
| 72 | 5.19 | **208RB23** |  | 101d | 2024-04-01 | 2024-07-10 |  |  | COSTEIRA | HDP-V | 50/50 | SÃO MAMEDE INFESTA |
| 73 | 5.19.1 | 208RB23 |  | 101d | 2024-04-01 | 2024-07-10 |  |  | COSTEIRA | HDP-V | 50/50 | SÃO MAMEDE INFESTA |
| 74 | 5.20 | **183CP23** |  | 80d | 2024-04-08 | 2024-06-26 |  |  | CM CARREGAL DO SAL | GMV | 0/0 | CARREGAL DO SAL |
| 75 | 5.20.1 | 183CP23 |  | 80d | 2024-04-08 | 2024-06-26 |  |  | CM CARREGAL DO SAL | GMV | 0/0 | CARREGAL DO SAL |
| 76 | 5.21 | OT |  | 1d | 2024-06-04 | 2024-06-04 |  | ATR; VTR | MAN/AV/REP - FARIA DE BAIXO | VARIOS | 0/0 | SUL-SINTRA |
| 77 | 5.22 | OT |  | 1d | 2024-06-20 | 2024-06-20 |  | ATR; GON | MAN/AV/REP - RECLAMAÇÃO | VARIOS | 0/0 | SUL-SARDOAL |
| 78 | 5.23 | OT |  | 1d | 2024-06-19 | 2024-06-19 |  | ATR; GON | MAN/AV/REP - CM MOGADOURO | VARIOS | 0/0 | SUL-SINTRA |
| 79 | 5.24 | OT |  | 1d | 2024-06-18 | 2024-06-18 |  | ATR; GON | MAN/AV/REP | VARIOS | 0/0 | SUL-SINTRA |
| 80 | 5.25 | 043RB21 |  | 1d | 2024-06-17 | 2024-06-17 |  | ATR; GON | CAPSULA SOLIDARIA | FLOW X | 50/50 | MAIA |
| 81 | 5.26 | OT |  | 1d | 2024-06-17 | 2024-06-17 |  | VTR | MAN/AV/REP | VARIOS | 0/0 | SUL-SINTRA |
| 82 | 5.27 | OT |  | 1d | 2024-06-07 | 2024-06-07 |  | VTR | MAN/AV/REP | VARIOS | 0/0 | SUL-SINTRA |
| 83 | 5.28 | 184CP23 |  | 2d | 2024-06-15 | 2024-06-16 |  | ATR; SUB | CM CARREGAL DO SAL - MONTAGEM ( ESCOLA ) | SUPRA | 0/0 | CARREGAL DO SAL |
| 84 | 5.29 | 184CP23 |  | 2d | 2024-06-13 | 2024-06-14 |  | ATR; VTR; GON | CM CARREGAL DO SAL - MONTAGEM (J FREG BEIJOS) | SUPRA | 0/0 | CARREGAL DO SAL |
| 85 | 5.30 | 214RB22 |  | 2d | 2024-06-05 | 2024-06-06 |  | ATR; VTR | BERNARDINO DE BRITO | SUPRA | 80/80 | PAREDES |
| 86 | 5.31 | OT |  | 1d | 2024-06-03 | 2024-06-03 |  | ATR; VTR | MAN/AV/REP - IELAC | VARIOS | 0/0 | SUL-SINTRA |
| 87 | 5.32 | 160CP23 | milestone | 0d | 2024-05-27 | 2024-05-27 |  | AND; GON | OLINDA MARIA DUARTE COSTA VAREJÃO | GMV-E | 100/100 | PORTO |
| 88 | 5.33 | OT |  | 1d | 2024-04-08 | 2024-04-08 |  | AND | MAN/AV/REP - RECLAMAÇÃO | VARIOS | 0/0 | SUL-SARDOAL |
| 89 | 5.34 | 043RB21 |  | 23d | 2024-05-13 | 2024-06-04 |  |  | CAPSULA SOLIDARIA | FLOW X | 50/50 | MAIA |
| 90 | 5.35 | 227RB23 |  | 52d | 2024-04-08 | 2024-05-29 |  |  | EFIMA (MIRA SINTRA) | SUPRA | 40/0 | AGUALVA - CACEM |
| 91 | 5.36 | 184CP23 |  | 43d | 2024-04-17 | 2024-05-29 |  |  | CM CARREGAL DO SAL - J FREG BEIJOS | SUPRA | 0/0 | CARREGAL DO SAL |
| 92 | 5.37 | 160RB23 |  | 43d | 2024-04-17 | 2024-05-29 |  |  | CM CARREGAL DO SAL - ESCOLA BASICA | SUPRA | 0/0 | CARREGAL DO SAL |
| 93 | 5.38 | 214RB22 |  | 61d | 2024-04-05 | 2024-06-04 |  |  | BERNARDINO DE BRITO | SUPRA | 100/100 | PAREDES |
| 94 | 5.39 | OT |  | 1d | 2024-05-22 | 2024-05-22 |  | AND; GON | MAN/AV/REP | VARIOS | 0/0 | SUL-SINTRA |
| 95 | 5.40 | OT |  | 1d | 2024-05-21 | 2024-05-21 |  | AND; GON | MAN/AV/REP - RECLAMAÇÃO PÉS GAIA | VARIOS | 0/0 | SUL-SINTRA |
| 96 | 5.41 | OT |  | 1d | 2024-05-20 | 2024-05-20 |  | AND; GON | MAN/AV/REP - CASTRO VERDE | VARIOS | 0/0 | SUL-SINTRA |
| 97 | 5.42 | 017DM22 |  | 1d | 2024-05-24 | 2024-05-24 |  | AND; GON | ANA SOFIA ALVES COSTA | FLOW X | 100/100 | PENAFIEL |
| 98 | 5.43 | 124CP24 |  | 1d | 2024-05-23 | 2024-05-23 |  | ATR; AND; GON | MARIA ALICE - MONTAGEM | RC260 | 100/100 | CANDAL |
| 99 | 5.44 | 138RB23 |  | 1d | 2024-05-21 | 2024-05-21 |  | ATR; VTR | WINTEAM - MONTAGEM | PLG7 | 100/100 | PRIOR VELHO |
| 100 | 5.45 | 144RB22 |  | 1d | 2024-05-20 | 2024-05-20 |  | ATR; VTR | SANDRA GONÇALVES - 2F | H200 | 100/100 | VILA NOVA GAIA |
| 101 | 5.46 | 115RB23/078RB22 | milestone | 0d | 2024-05-20 | 2024-05-20 |  | SUB | CERVIMAT (FRANCELOS/ESC. BAS. CORREIOR) - DESCARGA | GMV | 30/30 | VILA NOVA GAIA |
| 102 | 5.47 | 227RB23 |  | 46d | 2024-04-08 | 2024-05-23 |  |  | EFIMA (MIRA SINTRA) | FLOW X | 40/0 | AGUALVA - CACEM |
| 103 | 5.48 | 011RB23 |  | 3d | 2024-05-15 | 2024-05-17 |  | AND; GON | TEAGA II - CONCLUSÃO | DOMOFLEX 2 | 100/100 | OLIVEIRA FRADES |
| 104 | 5.49 | OT |  | 1d | 2024-05-13 | 2024-05-13 |  | AND; GON | MAN/AV/REP | VARIOS | 0/0 | SUL-SINTRA |
| 105 | 5.50 | 174RB22 |  | 2d | 2024-05-15 | 2024-05-16 |  | ATR; VTR | CERVIMAT (ESC. BAS. SABARIZ) | SUPRA LINEA | 100/100 | CASTELO DE PAIVA |
| 106 | 5.51 | OT |  | 1d | 2024-05-14 | 2024-05-14 |  | ATR; VTR | MAN/AV/REP - MICHAEL | VARIOS | 0/0 | SUL-SINTRA |
| 107 | 5.52 | OT |  | 1d | 2024-05-13 | 2024-05-13 |  | ATR; VTR | MAN/AV/REP | VARIOS | 0/0 | SUL-SINTRA |
| 108 | 5.53 | OT |  | 1d | 2024-05-13 | 2024-05-13 |  | ATR; VTR | MAN/AV/REP - LEIRIA | VARIOS | 0/0 | SUL-SINTRA |

Notes:
- 56: 08/7/24 / RF JÁ SOLIUCITOU AUTO PARA PODERMOS FATURAR CONCLUSÃO / 25/6/24 / AINDA N TEMOS CONDIÇÕES PARA CONCLUIR, INFO JC / 27/5/24 / AINDA N TEMOS CONDIÇÕES PARA CONCLUIR, INFO JC / 20/5/24 / JC INFORMOU QUE CLIENTE AINDA N NOS DÁ CONDIÇÕES PARA ACABAR OBRA / CLIENTE AINDA COM TRANSITO DE MATERIAIS / 13/5/24 / JC VAI LIGAR COM AE, PARA SABER DATA DE COMCLUSÃO EM OBRA / 06/5/24 / JC VAI LIGAR COM AE, PARA SABER DATA DE COMCLUSÃO EM OBRA / 29/4/29 / JC VAI LIGAR COM AE, PARA SABER DATA DE COMCLUSÃO EM OBRA / 19/4/24 / JC VAI LIGAR COM AE, PARA SABER DATA DE COMCLUSÃO EM OBRA / 01/3/24 / JC VAI CONFIRMAR ENTRADA DE OBRA COM AE / 12/1/24 / N ENTRAMOS NA WK2 CONFORME AE. / JC AGUARDA INFO DA AE / 07/12/23 / AGUARDAMOS PAGAMENTO DOS MATERIAIS / 10/11/23 / JC EVIOU EMAIL PARA AE A CONFIRMAR ENTRADA EM OBRA PARA 20/11/23 / AE TEM DE ENVIAR DOCUMENTAÇÃO DE TÉCNICOS / 28/8/23 / CLIENTE PAGOU MAIOR VALIA EM AGOSTO / ENCOMENDADO NO INICIO DE MARÇO / JC ESTEVE EM OBRA E DISSE AO FORN QUE A INSTALAÇÃO ESTARIA PREVISTA PARA JUNHO23
- 59: 15/5/24 / ESCOLA TEM DE SER FINALIZADO ANTES DO ANO LETIVO / 06/5/24 / RB ESTÁ A ESPERA DE PROJETO PARA FAZER ENCOMENDA / 29/4/24 / JC VAI COM RB PARA RETIFICAR MEDIDAS
- 60: 15/5/24 / ESCOLA TEM DE SER FINALIZADO ANTES DO ANO LETIVO / 06/5/24 / RB ESTÁ A ESPERA DE PROJETO PARA FAZER ENCOMENDA / 29/4/24 / JC VAI COM RB PARA RETIFICAR MEDIDAS
- 61: 20/5/24 / 23/4/24 / CPI E JC FAZEM VISITA À FAZINVENTA PARA VERIFICAR CABINA E PORTAS
- 62: 23/4/24 / CPI R JC FAZEM VISITA À FAZINVENTA PARA VERIFICAR CABINA E PORTAS
- 63: 23/2/24 / JC DIZ QUE É PARA APROVAR
- 64: 17/6/24 / SEM CORRENTE DEFINITIVA / N FOI POSSIVEL COLOCAR CHAPA / 27/5/24 / COLOCAR CHAPA / 15/12/23 / FALTA 1 DIA SEGUNDO INFO AE / 17/11/23 / JC VAI REUNIR COM AE EM OBRA 21/11/23 / 10/10/23 / NOVA VISITA À OBRA PARA VERIFICAR CONDIÇÕES / AE, ANTECIPOU UMA WK, PASSOU PARA 16/10/23 / 19/9/23 / VISITA EM OBRA, SEM CONDIÇÕES, AGUA NO POÇO / AGENDAR NOVA VISITA / 07/7/23 / JC VAI TER REUNIÃO EM OBRA / MATERIAIS PRONTOS NO FORN
- 66: 23/2/24 / JC CONFIRMA OBRA ATRSADA / VERIFICAR EM ABRIL / 2 PISOS PORTAS AUTOMATICAS
- 68: 31/10/23 / data de reunião em obra / . Carlos Pinto / José Costa / Engª Virgina / Sr Manuel / . previsão de entrada em obra Mai'24 / . previsão de conclusão de obra Jul'24
- 69: 31/10/23 / data de reunião em obra / . Carlos Pinto / José Costa / Engª Virgina / Sr Manuel / . previsão de entrada em obra Mai'24 / . previsão de conclusão de obra Jul'24
- 73: 06/5/24 / JC VAI ENVIAR EMAIL PARA SOLICITAR DATA DE ENTREGA / JC CONFIRMADO O PROCESSO DE INICIO DE FABRICO / JC TELEFONOU A CLIENTE, O ENG ESTÁ EMBRA PARA ZONA DE LISBOA / 29/4/24 / AR CONFIRMA 8 WKS DE PROD
- 85: 27/5/24 / EQUIPAMENTO A SER DESCARREGADO EM OBRA / 12/4/24 / JC JÁ APROVOU
- 87: 30/11/23 / GMV NOS ARMAZENS DA FIGUEIRA, FALTA ESTRUTURA
- 90: 15/3/24 / pagamento a 90D / podemos antecipar o pagamento a 60D, ver necessidade na wk anterior a montagem
- 93: 12/4/24 / JC JÁ APROVOU
- 99: 16/2/24 / FALTA APROVAÇÃO JC
- 100: 05/01/24 / RECEBEMOS MAT. 20/10/23 / ESTAMOS A FATURAR A TAXA DE ARMAZENAMENTO / AINDA N FATURAMOS MATERIAIS / 15/12/23 / JC COMBINOU FATURAÇÃO ARMAZENAMENTO COM CLIENTE
- 101: 23/2/24 / JC DIZ QUE É PARA APROVAR
- 103: 20/5/24 / FALTA SUBSTITUIR PLACA DE PISO / RF PEDE À FABRICA / 06/5/24 / JC INFORMA Q CLIENTE NOS CONTACTE PARA CONCLUIR / FALTA METER PORTAS E LIGAR / 3D/2H / 02/5/24 / ENTRAMOS E VAMOS CONCLUIR EM FINAIS DE MAIO / 05/4/24 / RF INFORMA QUE VAI COMEÇAR A SER COBRADO ARMAZENAMENTO A PARTIR DE 01/4 / 19/1/24 / RB PEDIU À FÁBRICA PARA ENTREGAR NA 1ª WK DE ABRIL
- 105: 26/02/24 / OBRA ATRASADA INFO JC / 10/11/23 / RF VAI ENVIAR EMAIL PARA COMBINAR ENTREGA E AVISAR DE CUSTO ADICIONAL PARA ENTREGA EM OBRA 350€ / 15/9/23 / CLIENTE DEU INFO QUE INICIO DE OUT PODIAMOS MONTAR / 01/9/23 / RF FICOU DE ENVIAR EMAIL A INFROMAR COBRANÇA DE MATERIAIS / 18/8/23 / OBRAS FECHADA SEM CONDIÇÕES / JC VAI ENVIAR EMAIL A CLIENTE A MARCAR ENTREGA NA WK 35 / 04/8/23 / JC VAI PASSAR NA OBRA NA WK 32 / 29/7/23 / jJC VAI FAZER VISITA À OBRA / PRAZO 10 SEMANAS / ADJUDICAÇÃO NÃO LIQUIDADA

| ID | WBS | Task | Type | Duration | Start | Finish | Predecessors | Resources | CLIENTE | EQPMTO | FT/PGM | LOCALIDADE |
| --- | --- | --- | --- | --- | --- | --- | --- | --- | --- | --- | --- | --- |
| 109 | 5.54 | **017DM22** |  | 29d | 2024-04-16 | 2024-05-14 |  |  | ANA SOFIA ALVES COSTA | FLOW X | 80/80 | PENAFIEL |
| 110 | 5.54.1 | 017DM22 |  | 29d | 2024-04-16 | 2024-05-14 |  |  | ANA SOFIA ALVES COSTA | FLOW X | 80/80 | PENAFIEL |
| 111 | 5.55 | **124CP24** |  | 51d | 2024-04-01 | 2024-05-21 |  |  | MARIA ALICE | RC260 | 50/50 | CANDAL |
| 112 | 5.55.1 | 124CP24 |  | 51d | 2024-04-01 | 2024-05-21 |  |  | MARIA ALICE | RC260 | 50/50 | CANDAL |
| 113 | 5.56 | **115RB23** |  | 73d | 2024-03-04 | 2024-05-15 |  |  | CERVIMAT (FRANCELOS) | GMV | 65/65 | VILA NOVA GAIA |
| 114 | 5.56.1 | 115RB23 |  | 73d | 2024-03-04 | 2024-05-15 |  |  | CERVIMAT (FRANCELOS) | GMV | 65/30 | VILA NOVA GAIA |
| 115 | 5.57 | **078RB22** |  | 73d | 2024-03-04 | 2024-05-15 |  |  | CERVIMAT (ESC. BAS. CORREIOS) | GMV | 65/30 | PORTO |
| 116 | 5.57.1 | 078RB22 |  | 73d | 2024-03-04 | 2024-05-15 |  |  | CERVIMAT (ESC. BAS. CORREIOS) | GMV | 65/30 | PORTO |
| 117 | 5.58 | 148RB23 |  | 3d | 2024-05-06 | 2024-05-08 |  | AND; VTR | CONSTRUÇÕES CASTANHEIRA & JOAQUIM - CONCLUSÃO | GMV | 100/100 | AGUEDA |
| 118 | 5.59 | 148RB20 | milestone | 0d | 2024-05-14 | 2024-05-14 |  | SCA | CARI CONST. (RESID. ALAMEDA LISBOA) | MONTA CARGAS TESOURA - SMECA | 100/100 | LISBOA |
| 119 | 5.60 | 035RB24 |  | 2d | 2024-05-06 | 2024-05-07 |  | AE | KORNIMPRIME | PLH750 | 100/100 | LOURES |
| 120 | 5.61 | 140CP23 |  | 2d | 2024-05-09 | 2024-05-10 |  | AND; VTR | CONG. CARIDADE BOM PASTOR (EXT. M. DROSTE) | SUPRA | 100/100 | ERMESINDE |
| 121 | 5.62 | 152RB22 |  | 1d | 2024-05-06 | 2024-05-06 |  | ATR; GON | ANGELO MEIRA | SUPRA LINEA | 100/100 | PORTO |
| 122 | 5.63 | 025DM22 |  | 5d | 2024-04-29 | 2024-05-03 | 124 | ATR; GON | TOME CARNEIRO SA | DOMOFLEX | 100/100 | ESPOSENDE |
| 123 | 5.64 | 011RB23 |  | 2d | 2024-04-29 | 2024-04-30 |  | AND; VTR | TEAGA II | DOMOFLEX 2 | 95/95 | OLIVEIRA FRADES |
| 124 | 5.65 | 025DM22 |  | 5d | 2024-04-22 | 2024-04-26 |  | ATR; VTR; GON | TOME CARNEIRO SA | DOMOFLEX | 100/80 | ESPOSENDE |
| 125 | 5.66 | OT |  | 1d | 2024-04-24 | 2024-04-24 |  | ATR; GON | MAN/AV/REP | FLOW | 0/0 | SUL-SINTRA |
| 126 | 5.67 | 189RB23 |  | 1d | 2024-04-22 | 2024-04-22 | 127 | ATR; GON | BRITACOSTA | GMV | 100/90 | OVAR |
| 127 | 5.68 | 189RB23 |  | 4d | 2024-04-15 | 2024-04-18 |  | ATR; GON | BRITACOSTA | GMV | 90/90 | OVAR |
| 128 | 5.69 | **138RB23** |  | 66d | 2024-03-04 | 2024-05-08 |  |  | WINTEAM | PLG7 | 50/50 | PRIOR VELHO |
| 129 | 5.69.1 | 138RB23 |  | 66d | 2024-03-04 | 2024-05-08 |  |  | WINTEAM | PLG7 | 50/50 | PRIOR VELHO |
| 130 | 5.70 | 025DM22 | milestone | 0d | 2024-04-18 | 2024-04-18 |  | AND | TOME CARNEIRO SA - DESCARGA | DOMOFLEX | 80/80 | ESPOSENDE |
| 131 | 5.71 | 011RB23 | milestone | 0d | 2024-04-17 | 2024-04-17 |  |  | TEAGA II - DESCARGA | DOMOFLEX 2 | 95/95 | OLIVEIRA FRADES |
| 132 | 5.72 | OT |  | 1d | 2024-04-16 | 2024-04-16 |  | AND | MAN/AV/REP | SUPRA | 100/0 | CARAMULO |
| 133 | 5.73 | 188RB21 |  | 1d | 2024-04-15 | 2024-04-15 |  | AND | JOANA COUTINHO GUIMARÃES - 2F | GMV | 100/95 | AVEIRO |
| 134 | 5.74 | OT |  | 1d | 2024-04-09 | 2024-04-09 |  | AND | MAN/AV/REP | HIDRAL | 0/0 | SUL-ALCOBAÇA |
| 135 | 5.75 | OT |  | 1d | 2024-04-08 | 2024-04-08 |  | AND | MAN/AV/REP | SUPRA | 0/0 | SUL-MOITA |
| 136 | 5.76 | RP01023 |  | 1d | 2024-04-02 | 2024-04-02 |  | AND | CASA AMARELA | H200 | 50/50 | PORTO |
| 137 | 5.77 | OT |  | 1d | 2024-04-04 | 2024-04-04 |  | AND | MAN/AV/REP - RECLAMAÇÃO | VARIOS | 0/0 | SUL |
| 138 | 5.78 | REP00624 |  | 2d | 2024-03-26 | 2024-03-27 |  | AND | MAN/AV/REP | VARIOS | 0/0 | VALADARES |
| 139 | 5.79 | 083DM20 |  | 2d | 2024-04-01 | 2024-04-02 |  | AND; VTR | BEHIND SOLUTIONS - TEAGA | MC | 100/100 | PORTO |
| 140 | 5.80 | OT |  | 1d | 2024-03-25 | 2024-03-25 |  | AND | MAN/AV/REP | VARIOS | 0/0 | SUL |
| 141 | 5.81 | OT |  | 1d | 2024-03-26 | 2024-03-26 |  | ATR; VTR | LINHAS GERAIS | H200 | 0/0 | LISBOA |
| 142 | 5.82 | 062RB20 |  | 2d | 2024-03-25 | 2024-03-26 |  | ATR; VTR | BIMETRICO | H200 | 100/100 | LISBOA |
| 143 | 5.83 | 151RB21 | milestone | 0d | 2024-03-22 | 2024-03-22 |  |  | SOCIBEIRAL | H200 | 40/40 | PORTO |
| 144 | 5.84 | 102DM21 |  | 2d | 2024-02-21 | 2024-02-22 |  | AND; GON | CERVIMAT - 2F | H200 | 100/100 | PORTO |
| 145 | 5.85 | 023RB23 | milestone | 0d | 2024-02-02 | 2024-02-02 |  |  | INOVAENERGIA | MONTA-CARGAS 1000KG | 45/0 | BRAGA |
| 146 | 5.86 | 159RB22 |  | 2d | 2024-03-14 | 2024-03-15 |  | AND; GON | CONSTRUBYCASAIS - CONCLUSÃO | H200 | 95/95 | BRAGA |
| 147 | 5.87 | OT |  | 1d | 2024-03-13 | 2024-03-13 |  | ATR | MAN/AV/REP | VARIOS | 0/0 | NORTE |
| 148 | 5.88 | 182RB22 |  | 1d | 2024-03-12 | 2024-03-12 |  | ATR; VTR | MANUEL BOTELHO | FLOW X | 100/100 | SINTRA |
| 149 | 5.89 | OT |  | 1d | 2024-03-11 | 2024-03-11 |  | VTR | MAN/AV/REP | VARIOS | 0/0 | SUL |
| 150 | 5.90 | 106CP24 |  | 1d | 2024-03-11 | 2024-03-11 |  | ATR; GON | JOSE BRITO | RC 260 | 100/100 | ALCABIDECHE |
| 151 | 5.91 | 062RB21 |  | 2d | 2024-03-12 | 2024-03-13 |  | ATR; GON | NOVA GENTE | SUPRA | 95/95 | LEIRIA |
| 152 | 5.92 | 159RB22 |  | 4d | 2024-03-08 | 2024-03-11 |  | AND; GON | CONSTRUBYCASAIS - 1F | H200 | 95/95 | BRAGA |
| 153 | 5.93 | 083DM20 |  | 3d | 2024-03-06 | 2024-03-08 |  | ATR; VTR | BEHIND SOLUTIONS - TEAGA | MC | 100/100 | PORTO |
| 154 | 5.94 | OT |  | 1d | 2024-03-04 | 2024-03-04 |  | ATR; VTR | MANUTENÇÃO | VARIOS | 100/100 | NORTE |
| 155 | 5.95 | 166CP23 |  | 2d | 2024-03-01 | 2024-03-02 |  | SUB | ASSOCIAÇÃO MEIRINHOS | GMV | 100/100 | MEIRINHOS |
| 156 | 5.96 | OT |  | 1d | 2024-03-01 | 2024-03-01 |  | VTR | MANUTENÇÃO | VARIOS | 100/100 | NORTE |
| 157 | 5.97 | RP01024 |  | 1d | 2024-03-01 | 2024-03-01 |  | VTR | MANUTENÇÃO | FABOC | 100/100 | NORTE |
| 158 | 5.98 | OT |  | 1d | 2024-02-29 | 2024-02-29 |  | AND | CENTRO SOCIAL | GMV | 100/100 | CALVÃO |
| 159 | 5.99 | 067ALG22 |  | 1d | 2024-02-24 | 2024-02-24 |  | AND; GON | MARIA LUISA FERNANDES | FLOW X | 100/100 | COIMBRA |
| 160 | 5.100 | 159RB22 |  | 6d | 2024-02-16 | 2024-02-21 |  | AND; GON | CONSTRUBYCASAIS - 1F | H200 | 95/95 | BRAGA |
| 161 | 5.101 | 220/19 | milestone | 0d | 2023-12-11 | 2023-12-11 |  |  | JOANA SOUSA | SUPRA L | 100/100 | MAIA |
| 162 | 5.102 | 268/19-OT | milestone | 0d | 2024-02-12 | 2024-02-12 |  | VTR | NORDICA - TG | GMV |  | ALVARENGA |
| 163 | 5.103 | 177RB23 |  | 1d | 2024-02-14 | 2024-02-14 |  | AND; GON | UNIÃO FREG. PESO E VALES DO RIO | FLOW X | 100/100 | PESO |
| 164 | 5.104 | 153DM20-OT | milestone | 0d | 2024-02-09 | 2024-02-09 |  | AND; GON | ANTONIO HENRRIQUES - TG | GMV | 100/100 | PORTO |
| 165 | 5.105 | 025RB22 |  | 3d | 2024-01-29 | 2024-01-31 |  | AND; VTR; GON | PINHEIRO & PEDROSO | GMV | 100/100 | BATALHA |
| 166 | 5.106 | 221RB23 | milestone | 0d | 2024-01-25 | 2024-01-25 |  |  | EFIMA (AUDITORIO MAFRA) - DESCARGA | GMV | 40/0 | MAFRA |
| 167 | 5.107 | 154RB23 |  | 3d | 2024-01-24 | 2024-01-26 |  | AND; VTR | LILIANA SOUSA (SUSP+PRT) | GMV | 100/100 | GAIA |
| 168 | 5.108 | OT |  | 2d | 2024-01-29 | 2024-01-30 |  | VTR | MANUTENÇÃO | VARIOS |  | CENTRO/NORTE |
| 169 | 5.109 | 089RB23 |  | 1d | 2024-01-26 | 2024-01-26 |  | ATR; GON | CUNHA & ANTUNES - REMATES | DOMOFLEX 2 | 100/95 | CANAS SENHORIM |
| 170 | 5.110 | 148RB23 | milestone | 0d | 2024-01-24 | 2024-01-24 |  |  | CONSTRUÇÕES CASTANHEIRA & JOAQUIM - DESCARGA | GMV | 100/100 | AGUEDA |
| 171 | 5.111 | OT |  | 1d | 2024-01-22 | 2024-01-22 |  | VTR | MANUTENÇÃO | VARIOS |  | LEIRIA |
| 172 | 5.112 | 198/19 |  | 2d | 2024-01-23 | 2024-01-24 |  | ATR; GON | ISABEL CRISTINA CARVALHO | LIFTINGITALIA | 100/100 | AVEIRO |
| 173 | 5.113 | 171RB22 |  | 1d | 2024-01-20 | 2024-01-20 |  | AND; VTR | C. M. VILA CONDE (JI Sº LAZARO) | FLOW X | 100/100 | VILA DO CONDE |
| 174 | 5.114 | RP035/23 |  | 1d | 2024-01-22 | 2024-01-22 |  | AND | JUNTA DE FREG. PENHA FRANÇA | DOMOFLEX | 100/100 | LISBOA |
| 175 | 5.115 | 089RB23 |  | 1d | 2024-01-26 | 2024-01-26 |  | ATR; GON | CUNHA & ANTUNES - TRAB À GARANTIA | DOMOFLEX 2 | 95/95 | CANAS SENHORIM |
| 176 | 5.116 | 153RB23 |  | 2d | 2024-01-18 | 2024-01-19 |  | AND; VTR | DAVID SOUSA (SUSP+PRT) | GMV | 100/100 | GAIA |
| 177 | 5.117 | 052RB23 |  | 1d | 2024-01-11 | 2024-01-11 |  | AND; VTR | TEIXAEIRA DUARTE | SUPRA - L | 100/100 | LISBOA |
| 178 | 5.118 | 113RB23 |  | 1d | 2024-01-09 | 2024-01-09 |  | AND; VTR | AGRUPAMENTO ESCOLAS FARIA BAIXO | DOMOFLEX - E | 100/100 | CUCUJAES |

Notes:
- 113: 23/2/24 / JC DIZ QUE É PARA APROVAR
- 114: 23/2/24 / JC DIZ QUE É PARA APROVAR
- 115: 23/2/24 / JC CONFIRMA OBRA ATRSADA / VERIFICAR EM ABRIL
- 116: 23/2/24 / JC CONFIRMA OBRA ATRSADA / VERIFICAR EM ABRIL
- 117: 08/3/24 / 3D/2H / AINDA SEM LUZ / 15/12/23 / CLIENTE LIGOU C/JC PARA AGENDAR ENTRADA / SEM CORRENTE DEFINITIVA AINDA EM OBRA / 07/12/23 / SICMALEVA ENVIA INFO PARA CARREGAR EM 12/1 / ENTRADA EM OBRA SEGUNDO CONTRATO NA 1ª OU 2ª WK DE JANEIRO / 27/10/23 / CLIENTE PAGOU ADJ
- 118: 08/3/24 / JC VISITOU OBRA, PREVISÃO DE CONCLUSÃO NA WK11 / 01/3/24 / JC VAI VISITAR OBRA PROXIMA WK. / 23/2/24 / JC DIZ Q CLIENTE N TEM ATENDIDO OS CONTATOS / 02/2/24 / JC VAI CONTATAR CLIENTE PARA TER INFO DA OBRA / 12/01/24 / 22/3/24 / CLIENTE AINDA N FEZ FRENTE PARA COLOCAR AS PORTAS / SICMALEVA VAI PASSAR NA OBRA / 07/12/23 / JC VAI FALAR C/JOAO SEMECA E ENG OBRA (ENVIAR EMAIL) / 24/11/23 / AGUARDAMOS QUE CLIENTE CONCLUA TRABALHOS / 17/11/23 / AGUARDAMOS QUE CLIENTE CONCLUA TRABALHOS / 10/11/23 / SEMECA AGUARDA CONCLUSÃO DE UM PORTÃO PARA VOLTAR A ENTRAR EM OBRA / 01/11/23 / SEMECA N TERMINOU / CLIENTE TEM DE FAZER REMATES PARA RECEBER PORTÃO / 29/9/23 / RB COORDENOU COM JOAO DA SEMECA MONTAGEM E DESCARGA POR PARTE DELE / RB ESTA A GERIR PROCESSO C/CLIENTE / 28/8/23 / JÁ PAGAMOS ADJUDICAÇÃO À SMECA / EM MARÇO DE 2022 RB PEDIU À SMECA PARA N PRODUZIR / PAGAMOS EM JUNHO DE 22 A FATURA DE INICIO DE PRODUÇÃO
- 119: 23/4/24 / MONTAGEM PELA AE / PROCESSO N ESTA NA REDE MONTAGENS EM CURSO / 19/4/24 / JC VAI FALAR COM VASSALO E SABER PRAZOS E MONTAGEM / 23/4/24 / PROCESSO N ESTA NA REDE MONTAGENS EM CURSO / 19/4/24 / JC VAI FALAR COM VASSALO E SABER PRAZOS E MONTAGEM
- 120: 29/2/24 / Por favor, vea la lista de empaque y la factura comercial adjunta para SL-336752. Actualmente la fecha estimada de entrega de este pedido es el 18/03/2024. Tenga en cuenta que se trata de una fecha estimada y puede estar sujeta a cambios. / 19/1/24 / INSTALAÇÃO ENTRE DIA 02 A 05 DE ABRIL
- 122: 05/4/24 / RF INFORMA QUE VAI COMEÇAR A SER COBRADO ARMAZENAMENTO A PARTIR DE 01/4
- 123: 06/5/24 / JC INFORMA Q CLIENTE NOS CONTACTE PARA CONCLUIR / FALTA METER PORTAS E LIGAR / 3D/2H / 02/5/24 / ENTRAMOS E VAMOS CONCLUIR EM FINAIS DE MAIO / 05/4/24 / RF INFORMA QUE VAI COMEÇAR A SER COBRADO ARMAZENAMENTO A PARTIR DE 01/4 / 19/1/24 / RB PEDIU À FÁBRICA PARA ENTREGAR NA 1ª WK DE ABRIL
- 124: 05/4/24 / RF INFORMA QUE VAI COMEÇAR A SER COBRADO ARMAZENAMENTO A PARTIR DE 01/4
- 125: MOTOR SUPRA
- 128: 16/2/24 / FALTA APROVAÇÃO JC
- 129: 16/2/24 / FALTA APROVAÇÃO JC
- 130: 05/4/24 / RF INFORMA QUE VAI COMEÇAR A SER COBRADO ARMAZENAMENTO A PARTIR DE 01/4
- 131: 05/4/24 / RF INFORMA QUE VAI COMEÇAR A SER COBRADO ARMAZENAMENTO A PARTIR DE 01/4 / 19/1/24 / RB PEDIU À FÁBRICA PARA ENTREGAR NA 1ª WK DE ABRIL
- 132: MOTOR SUPRA
- 133: 08/3/24 / JC INFORMOU CLIENTE QUE SO PODEMOS PARA ABRIL / Informo que está previsto ser carregado no próximo dia 20-10-2023 em Itália com data prevista de chagada à figueira da foz no dia 25-10-2023, a encomenda: / OBRA S-23417/ ON-188BRB21 AVEIRO / Necessito que me informe o dia para organizar a entrega / 13/10/24 / 3P - CAIXA ALVENARIA / DATA REUNIÃO OBRA: 17/05/2023
- 134: MOTOR SUPRA
- 135: MOTOR SUPRA
- 136: TIRAR RODAS / LIGAR PARA FURAR PORTAS / FAZER MANUTENÇÃO SUPRA / HA 2 QUE N SE CONSEGUE ABRIR AS PORTAS
- 139: 05/4/24 / FALTA PEÇA PARA QUADRO ELETRICO / 08/3/24 / FALTAM PEÇAS PARA COLOCAR PEÇAS NOS PORTÕES / 17/11/23 / JC VAI REUNIR DIA 20/11 / 03/11/23 / JC MARCOU VISITA À OBRA P/15/11/23 / 24//7/23 / FALTA LIQUIDAR PARTE DE MATERIAIS / PORTAS NO FORN, SMECA / 1/7 /23 / EQUIPAMENTO PRONTO PARA ENTREGA
- 142: 01/3/24 / CLIENTE CONFIRMA OBRA, JC VAI VISITAR OBRA. / 02/2/24 / JC CONFIRMA OBRA SEM CORRENTE DEFINITIVA / 20/10/23 / RF VAI FATURAR 27,5% / N ACABAMOS, ART TEM DE COMUNICAR , 1D+2H / 29/9/23 / TEM DE REMOVER PAINEIS QUE ESTÃO A ROUBAR 3CM À CAIXA / RB ESTEVE C/CLIENTE, PENDENTES NA CAIXA / CLIENTE VAI TER DE FAZER ACABAMENTOS / À DATA DE HOJE N É CRITICO / 18/8/23 / 4 STOPS - PORTAS BATENTE / ENTREGA DE MATERIAIS PELO DIAMÂNITINO NA SEXTA FEIRA ANTERIOR / 04/8/23 / JC INFORMOU CLIENTE PREVISÃO PARA SET / FOCOU DE INFORMAR 18/8 / 01/7/23 / CLIENTE JÁ TEMM CONDIÇÕES PARA INSTALAR / MATERIAL NO DIAMANTINO
- 143: 01/9/23 / CLIENTE N ACEITOU O N/ULTIMA PROPOSTA / RF FICOU DE COORDENAR ENTREGA DO EQ NO ARMAZEM / 30/6/23 / FALTA MONTAGEM INTEGRAL / AGUARDAMOS CONTATO DO N/ADVOGADO, VAI FAZER ABORDAGEM C/SOCIBEIRAL / VAMOS RESCINDIR C/CONTRUTORA E FAZER NOVO CONTRATO C/CLIENTE FINAL / MATERIAL EM ARMAZEM / DO N QUER TRABALHOS COM SOCIBEIRAL / TENTAR GERIR DIRETAMENTE C/DO
- 144: 02/2/24 / JC ESTEVE EM OBRA, CLIENTE A PREPARAR INFRAESTRUTURA PARA COLOCAÇÃO DA CENTRAL / 07/12/23 / CLIENTE LIGOU PARA JC, INFORMOU Q FALTA PAGAR MATERIAIS / 20/10/23 / OBRA SEM CORRENTE DEFINITIVA / FALTA LIMPEZA GERAL E AFINAÇÕES 2D / FATURAR CONCLUSÃO / 01/9/23 / AGENDAR PASSAGEM NA OBRA P/CONCLUIR / 07/7/23 / SEM CONDIÇÕES OBRA / 15/6/23 / 2 DIAS DE TRABALHO / EMQUIPAMENTO EM OBRA
- 145: 22/3/24 / NUNCA PAGARAM ADJ NEM RESPONDEU A CONTATOS / 25/8/23 / CLIENTE AINDA N PAGOU A ADJ / CLIENTE VOLTOU A CONTATAR, CP INFORMOU PARA PAGAR ADJUDICAÇÃO
- 146: 15/12/23 / JC VISITOU OBRA, AINDA SSEM JANELAS / ACORDOU C/ENGº EMANUEL A DESCARGA EM OBRA. / 17/11/23 / Boa tarde Raúl e José. / Falei agora com o Eng.º Emanuel Roleira e o que o mesmo pretende é: / 1Que o José visite a obra para conhecer o ponto de situação da mesma e se existem condições para deixar o material na obra ou no estaleiro da Casais (responsabilidade de transporte posterior para a obra da responsabilidade da CONSTRU); / 2Que o Raúl o informe da previsão de entrega do material em obra e envie o Packing List para o Eng.º Emanuel; / 3O pagamento da Adjudicação está em fase de ser efetuado e a garantia bancária não se vai renovar. / DATA LIMITE ENTREGA EQUIPAMENTO EM OBRA: 19/01/24
- 147: GAIA
- 152: 15/12/23 / JC VISITOU OBRA, AINDA SSEM JANELAS / ACORDOU C/ENGº EMANUEL A DESCARGA EM OBRA. / 17/11/23 / Boa tarde Raúl e José. / Falei agora com o Eng.º Emanuel Roleira e o que o mesmo pretende é: / 1Que o José visite a obra para conhecer o ponto de situação da mesma e se existem condições para deixar o material na obra ou no estaleiro da Casais (responsabilidade de transporte posterior para a obra da responsabilidade da CONSTRU); / 2Que o Raúl o informe da previsão de entrega do material em obra e envie o Packing List para o Eng.º Emanuel; / 3O pagamento da Adjudicação está em fase de ser efetuado e a garantia bancária não se vai renovar. / DATA LIMITE ENTREGA EQUIPAMENTO EM OBRA: 19/01/24
- 153: 08/3/24 / FALTAM PEÇAS PARA COLOCAR PEÇAS NOS PORTÕES / 17/11/23 / JC VAI REUNIR DIA 20/11 / 03/11/23 / JC MARCOU VISITA À OBRA P/15/11/23 / 24//7/23 / FALTA LIQUIDAR PARTE DE MATERIAIS / PORTAS NO FORN, SMECA / 1/7 /23 / EQUIPAMENTO PRONTO PARA ENTREGA
- 154: CARAMULO / VISEU / PINHÃO
- 155: 25/8 / CP TEM DE ENCOMENDAR À SICMALEVA
- 158: 12/1/24 / JC VAI MANDAR FAZER OS SUPORTES DOS MOTORES / ART VAI REPARA NOVO MOTOR / 01/9/23 / OBRAS ATRASADAS / FATURAR CONCLUSÃO INFORMAR INICIO DE GARANTIAS / 15/6/23 / 1 DIA DE TRABALHOS TÉCNICOS / AGUARDAMOS CORRENTE DEFINITIVA
- 160: 15/12/23 / JC VISITOU OBRA, AINDA SSEM JANELAS / ACORDOU C/ENGº EMANUEL A DESCARGA EM OBRA. / 17/11/23 / Boa tarde Raúl e José. / Falei agora com o Eng.º Emanuel Roleira e o que o mesmo pretende é: / 1Que o José visite a obra para conhecer o ponto de situação da mesma e se existem condições para deixar o material na obra ou no estaleiro da Casais (responsabilidade de transporte posterior para a obra da responsabilidade da CONSTRU); / 2Que o Raúl o informe da previsão de entrega do material em obra e envie o Packing List para o Eng.º Emanuel; / 3O pagamento da Adjudicação está em fase de ser efetuado e a garantia bancária não se vai renovar. / DATA LIMITE ENTREGA EQUIPAMENTO EM OBRA: 19/01/24
- 161: 02/2/24 / CLIENTE VEM LEVANTAR MATERIAL DIA 3/2/24 / 10 DEGRAUS / 26/1/24 / CLIENTE VEM LEVANTAR EQUIPAMENTO / 30/6/23 / FALTA CAMARA APROVAR ALTERAÇÕES QUE CLIENTE TEM E REALIZAR / MATERIAL EM ARMAZEM / CLIENTE AINDA N FEZ ALTERAÇÕES À PORTA DE ENTRADA
- 162: 02/2/24 / AGUARAMOS MATERIAIS DA SICMALEVA / NA VENDA OFERECEMOS 5 ANOS DE GARANTIA POR TROCA DE CONTRATO DE MANUTENÇÃO DE 5 ANOS POR 43€
- 164: 30/11/23 / ADALBERTO SOLICITA PRESENÇA DE TÉCNICO PARA EFETUAR ALTERAÇÕES / 24/11/23 / RF VAI FAZER PEDIDO À SICMALEVA / 20/10/23 / ART N REGISTOU CORRETAMENTE A ENTREGA NO AUTO / 01/9/23 / PROGRAMAR CONCLUSÃO / FATURAR CONCLUSÃO / 07/7/23 / JC VAI FALAR C/CLIENTE / 30/6/23 / FALTRA 1 DIA
- 165: 10/11/23 / CLIENTE FICOU DE AVISAR QUANDO TIVESSE CONDIÇÕES / FATURAR OBRA ATE 31/12/23 / 01/9/23 / PERCEBER QUAL O ESTADO DA OBRA / 5 PISOS / 15/6/23 / FALTA 2/3 DIA DE TRABALHO / AGUARDAMOS CONTATO CLIENTE, OBRA ATRASADA
- 166: 04/11/23 / DLINE 31/1/24
- 167: 17/11/23 / JC FEZ VISITA À OBRA, TUDO OK PARA ENTREGARMOS EQUIPAMETO.
- 169: 02/2/24 / EQ DESLIGADO
- 170: 15/12/23 / CLIENTE LIGOU C/JC PARA AGENDAR ENTRADA / SEM CORRENTE DEFINITIVA AINDA EM OBRA / 07/12/23 / SICMALEVA ENVIA INFO PARA CARREGAR EM 12/1 / ENTRADA EM OBRA SEGUNDO CONTRATO NA 1ª OU 2ª WK DE JANEIRO / 27/10/23 / CLIENTE PAGOU ADJ
- 172: 26/1/34 / PROBLEMAS TECNICOS PARA RESOLVER / N REDUZ VELOCIDADE NO PISO 1 / 29/9/23 / VTR ENCONTROU A OBRA FECHADA / 15/9 / VITOR VAI VERIFICAR E ENTREGAR EQUIPAMENTO
- 175: 29/9/23 / RB, DIZ Q CAIXA N ESTA APRUMADA E TEM DE COLOCAR DIREITO / RB ESTA A FAZER REGISTO VIA EMAIL / EXISTE 1 COBERTO PARA COLOCAR MATERIAIS
- 176: 17/11/23 / JC FEZ VISITA À OBRA, TUDO OK PARA ENTREGARMOS EQUIPAMETO.
- 177: 04/10/23 / DLINE 27/10 CONTRATO PELO CLIENTE
- 178: 13/10/23 / FORN DA PREVISÃO DE ENTREGA WK 42 / 2P COM ESTRUTURA / 15/9/23 / COM CONTRATO ATE WK 47 / ENVIAR EMAIL P/FORN A PEDIR ENTREGA WK44 / 100% C/CONCLUSÃO

| ID | WBS | Task | Type | Duration | Start | Finish | Resources | CLIENTE | EQPMTO | FT/PGM | LOCALIDADE |
| --- | --- | --- | --- | --- | --- | --- | --- | --- | --- | --- | --- |
| 179 | 5.119 | 034RB23 |  | 1d | 2024-01-10 | 2024-01-10 | ATR; GON | ODRAUDE | METALU PK | 100/100 | CONDEIXA-A-NOVA |
| 180 | 5.120 | 113RB23 |  | 1d | 2024-01-12 | 2024-01-12 | AND; VTR | AGRUPAMENTO ESCOLAS FARIA BAIXO | DOMOFLEX - E | 100/100 | CUCUJAES |
| 181 | 5.121 | 161RB23 |  | 1d | 2024-01-13 | 2024-01-13 | AND; VTR | ALUMINIOS RASTEIRO | HOMEGLIDE OUTDOOR | 100/100 | MEALHADA |
| 182 | 5.122 | 024RB21 |  | 1d | 2024-01-15 | 2024-01-15 | ATR; GON | JRC - RECLAMAÇÃO/GARANTIA | GMV | 100/100 | CASTRO VERDE |
| 183 | 5.123 | 159RB22 | milestone | 0d | 2024-01-16 | 2024-01-16 | SUB | CONSTRUBYCASAIS - DESCARGA | H200 | 40/40 | BRAGA |
| 184 | 5.124 | 223+224RB23 |  | 1d | 2024-01-18 | 2024-01-18 | ATR | MARGARIDA BRAZ BORGES - ENTREGA | SUPRA | 100/100 | VARZEA DE SINTRA |
| 185 | 5.125 | OT |  | 1d | 2024-01-18 | 2024-01-18 | AND | MANUTENÇÃO | GMV |  | SATÃO/CASTELO BRANCO |
| 186 | 5.126 | OT |  | 1d | 2024-01-18 | 2024-01-18 | AND | AZIMUTCAMINHO - GARANTIA | MC |  | CASTELO BRANCO |
| 187 | 5.127 | 237/19 |  | 1d | 2024-01-09 | 2024-01-09 | AND; VTR | SOCERTIMA | MINIPOCKET | 100/90 | VALE DE CAMARA |
| 188 | 5.128 | 222RB23 |  | 1d | 2023-12-27 | 2023-12-27 | AE | MARDARIDA BRAZ BORGES 6063918 - PLTB | SUPRA | 100/100 | AGUALVA - CACÉM |
| 189 | 5.129 | 128DM20 |  | 3d | 2023-12-18 | 2023-12-20 | ATR; GON | MIGUEL FERNANDO MARTINS LOUREIRO | SUPRA OUTDOOR | 100/100 | PINHÃO |
| 190 | 5.130 | OT | milestone | 0d | 2023-12-20 | 2023-12-20 |  | DESMONTAGEM - EDE CURVO | STANNAH |  | VILA REAL |
| 191 | 5.131 | 223RB23 |  | 1d | 2023-12-28 | 2023-12-28 | AE | MARGARIDA BRAZ BORGES 6063980 - PLTA | SUPRA | 100/100 | VARZEA DE SINTRA |
| 192 | 5.132 | 222RB23 |  | 1d | 2023-12-26 | 2023-12-26 | AE | MARGARIDA BRAZ BORGES 6063936 - PLTA | SUPRA | 100/100 | AGUALVA - CACÉM |
| 193 | 5.133 | 088RB21 |  | 1d | 2023-12-07 | 2023-12-07 | AND; VTR | CADIMARTE | INFINITY | 100/100 | MONTEMOR-O-VELHO |
| 194 | 5.134 | 088RB21 | milestone | 0d | 2023-12-07 | 2023-12-07 | AE | CADIMARTE | PLATAFORMA TESOURA 300KG | 100/100 | MONTEMOR-O-VELHO |
| 195 | 5.135 | OT | milestone | 0d | 2023-12-07 | 2023-12-07 | VTR | BOMBEIROS | GMV |  | COIMBRA |
| 196 | 5.136 | 003DM20 | milestone | 0d | 2023-12-05 | 2023-12-05 | ATR; VTR | MJCALDEIRA - ENTREGA | GMV | 100/100 | MOGADOURO |
| 197 | 5.137 | 029DM20 | milestone | 0d | 2023-12-04 | 2023-12-04 | AND; VTR | MJCALDEIRA - ENTREGA | GMV | 100/100 | TORRE DE MONCORVO |
| 198 | 5.138 | 002RB22 | milestone | 0d | 2023-11-30 | 2023-11-30 | VTR | ENTREGA CONJUNTURA | DOMOSTEP | 100/100 | FIGUEIRÓ DOS VINHOS |
| 199 | 5.139 | 059RB22 |  | 2d | 2023-11-29 | 2023-11-30 | AND; GON | LUIS MIGUEL DOS SANTOS VITORIANO | DOMOFLEX | 100/100 | CARTAXO |
| 200 | 5.140 | OT | milestone | 0d | 2023-11-29 | 2023-11-29 | VTR | TIAGO ANTUNES | DOMOFLEX |  | LEIRIA |
| 201 | 5.141 | OT | milestone | 0d | 2023-11-27 | 2023-11-27 | VTR | COSTEIRA | GMV |  | BARCELOS |
| 202 | 5.142 | OT | milestone | 0d | 2023-11-27 | 2023-11-27 |  | JRC | GMV |  | CASTRO VERDE |
| 203 | 5.143 | 091RB22 |  | 1d | 2023-11-24 | 2023-11-24 | VTR; GON | BUILD GROW | SUPRA L | 100/100 | PORTO |
| 204 | 5.144 | 101DM21 |  | 1d | 2023-11-22 | 2023-11-22 | VTR; GON | MANUEL SANTOS | GMV | 100/100 | SRA DA HORA |
| 205 | 5.145 | OT | milestone | 0d | 2023-11-21 | 2023-11-21 | VTR; GON | ADMIN REG. SAUDE CENTRO | GMV |  | VISEU |
| 206 | 5.146 | 099DM21 |  | 1d | 2023-11-17 | 2023-11-17 | AND; VTR; GON | FERNANDO MANUEL S. ALVES - REMAKE | INFINITY | 100/100 | PAÇOS FERREIRA |
| 207 | 5.147 | 024RB21 | milestone | 0d | 2023-11-13 | 2023-11-13 |  | JRC | GMV+E | 100/100 | CASTRO VERDE |
| 208 | 5.148 | CALL TO ACTION | milestone | 0d | 2023-11-13 | 2023-11-13 | AND; VTR | ACCESS | H200 | 3/3 | LISBOA |
| 209 | 5.149 | 052RB23 |  | 2d | 2023-11-14 | 2023-11-15 | AND; VTR | TEIXAEIRA DUARTE | SUPRA | 100/100 | LISBOA |
| 210 | 5.150 | 119RB20 | milestone | 0d | 2023-11-13 | 2023-11-13 | AND; VTR | LINHAS GERAIS | H200 | 100/100 | LISBOA |
| 211 | 5.151 | 119RB20 | milestone | 0d | 2023-11-13 | 2023-11-13 | AND; VTR | LINHAS GERAIS | H200 | 100/100 | LISBOA |
| 212 | 5.152 | 008RB22 | milestone | 0d | 2023-11-13 | 2023-11-13 |  | PAULO GUEDES | PLK8 | 100/100 | SINTRA |
| 213 | 5.153 | OT | milestone | 0d | 2023-11-07 | 2023-11-07 | VTR | MAN |  |  | ZONA CENTRO |
| 214 | 5.154 | OT | milestone | 0d | 2023-11-06 | 2023-11-06 | VTR | CERDOWORK - RECLAMAÇÃO | GMV |  | BRAGA |
| 215 | 5.155 | OT | milestone | 0d | 2023-10-31 | 2023-10-31 | AND; GON | MANUTENÇÃO | VARIOS | 3/3 | LEIRIA |
| 216 | 5.156 | OT | milestone | 0d | 2023-11-03 | 2023-11-03 | ATR; VTR | MED FARMACIA - ENTREGA | GMV |  | POMBAL |
| 217 | 5.157 | 106/19 | milestone | 0d | 2023-10-31 | 2023-10-31 | ATR; VTR | OPUALTE | GMV | 100/100 | GUARDA |
| 218 | 5.158 | 040LG22 | milestone | 0d | 2023-10-27 | 2023-10-27 | AND; GON | FLOPONOR | SUPRA | 100/100 | VISEU |
| 219 | 5.159 | RECLAMACAO | milestone | 0d | 2023-10-30 | 2023-10-30 | N/A | VEIGA LOPES | MC |  | COIMBRA |
| 220 | 5.160 | OT | milestone | 0d | 2023-10-25 | 2023-10-25 | AND; GON | APPACDM | GMV |  | FUNDÃO |
| 221 | 5.161 | OT | milestone | 0d | 2023-10-24 | 2023-10-24 | AND; GON | CERVIMAT | GMV | 100/100 | TORRE DE MONCORVO |
| 222 | 5.162 | 112DM19 | milestone | 0d | 2023-10-24 | 2023-10-24 | AND; GON | MJC | GMV + DOMOFLEX |  | VINHAIS |
| 223 | 5.163 | OTS | milestone | 0d | 2023-10-20 | 2023-10-20 | AND; VTR | ESAD | GMV | 100/100 | SENHORA DA HORA |
| 224 | 5.164 | OTS |  | 1d | 2023-10-18 | 2023-10-18 | VTR | MANUTENÇÃO |  |  | ZONA NORTE |
| 225 | 5.165 | 187/19 | milestone | 0d | 2023-10-17 | 2023-10-17 | VTR | INVERSIL | GMV | 100/100 | AVEIRO |
| 226 | 5.166 | CM0026/22 | milestone | 0d | 2023-10-17 | 2023-10-17 | VTR | ESCOLA SECUNDÁRIA | SUPRA |  | CACIA |
| 227 | 5.167 | 105/19 | milestone | 0d | 2023-10-17 | 2023-10-17 | VTR | ASSOCIAÇÃO DE AMIGOS | HIDRAL | 100/100 | SANGUEDO |
| 228 | 5.168 | 084RB22 | milestone | 0d | 2023-10-16 | 2023-10-16 | AND; VTR | ROSA OLIVEIRA | INFINITY |  | PENAFIEL |
| 229 | 5.169 | OTS | milestone | 0d | 2023-10-16 | 2023-10-16 | AND; VTR | ROSA COELHO | HIDRAL |  | PENAFIEL |
| 230 | 5.170 | OTS | milestone | 0d | 2023-10-16 | 2023-10-16 | AND; VTR | S. VICENTE PADROEIRO | H200 |  | GUIMARAES |
| 231 | 5.171 | OTS |  | 1d | 2023-10-13 | 2023-10-13 | VTR | MANUTENÇÃO |  |  |  |
| 232 | 5.172 | 103RB22 | milestone | 0d | 2023-10-11 | 2023-10-11 | ATR; GON | MARINA FILIPA PINTO RIBEIRO | DOMOFLEX 2 | 100/100 | GONDOMAR |
| 233 | 5.173 | 104DM19 | milestone | 0d | 2023-10-10 | 2023-10-10 | ATR; GON | ARTUR ARAUJO - 14H | GMV | 100/100 | LEÇA DA PALMEIRA |
| 234 | 5.174 | 061RB22 | milestone | 0d | 2023-10-09 | 2023-10-09 | ATR; GON | PRADO CORREIA - 14h | H200 | 100/100 | FEIJÕES |
| 235 | 5.175 | 166/19 | milestone | 0d | 2023-10-10 | 2023-10-10 | ATR | BEFENOR | H200 (8UN) | 100/100 | PORTO |
| 236 | 5.176 | 184RB22 | milestone | 0d | 2023-10-06 | 2023-10-06 | AND | NOBLE SUCESS | GMV | 100/100 | BRAGA |
| 237 | 5.177 | 0149CP23 | milestone | 0d | 2023-10-06 | 2023-10-06 | VTR | CONGREGAÇÃO RELIGIOSAS AMOR DE DEUS | SUPRA LINEA | 100/100 | PORTO |
| 238 | 5.178 | 021RB20 | milestone | 0d | 2023-10-02 | 2023-10-02 | N/A | FERNANDO MOREIRA | GMV |  | VILA NOVA DE GAIA |
| 239 | 5.179 | ON-_190 | milestone | 0d | 2023-09-28 | 2023-09-28 | ATR |  |  |  | BEJA |
| 240 | 5.180 | 115RB20 |  | 2d | 2023-09-27 | 2023-09-28 | ATR | CANAS - GARANTIA | GMV | 100/100 | SARDOAL |
| 241 | 5.181 | 078DM21 |  | 1d | 2023-09-25 | 2023-09-25 | ATR; GON | COSTEIRA | GMV | 100/100 | BARCELOS |
| 242 | 5.182 | CM002723 | milestone | 0d | 2023-09-22 | 2023-09-22 | AND | ASSOCIAÇÃO HUMANITÁRIA | GMV |  | COIMBRA |
| 243 | 5.183 | 087LG22 | milestone | 0d | 2023-09-22 | 2023-09-22 | AND | MEDD - FARMACIA BARROS | H200+E | 100/100 | POMBAL |
| 244 | 5.184 | CM03322 | milestone | 0d | 2023-09-22 | 2023-09-22 | AND | SOLAR CASTANHEIRO | MC |  | LEIRIA |
| 245 | 5.185 | 129RB21 |  | 1d | 2023-09-14 | 2023-09-14 | ATR; GON | AOF - REPARAÇÃO | SUPRA |  | MAFRA |
| 246 | 5.186 | 097RB21 |  | 1d | 2023-09-14 | 2023-09-14 | AND | NIVEL 20 | SUPRA | 100/100 | ANADIA |
| 247 | 5.187 | 223RB22 |  | 2d | 2023-09-12 | 2023-09-13 | ATR; GON | ANTEROS (ESC. EB1 MIRANDA DOURO) | DOMOFLEX 2 | 100/100 | MIRANDA DO DOURO |
| 248 | 5.188 | OS | milestone | 0d | 2023-09-11 | 2023-09-11 | ATR | JOAQUIM JOSÉ FONTES | EDE RETO |  | PAÇOS DE FERREIRA |

Notes:
- 179: 12/1/24 / CLIENTE CONFIRMOU Q IRIA PAGAR NA SEMANA 3
- 180: 13/10/23 / FORN DA PREVISÃO DE ENTREGA WK 42 / 2P COM ESTRUTURA / 15/9/23 / COM CONTRATO ATE WK 47 / ENVIAR EMAIL P/FORN A PEDIR ENTREGA WK44 / 100% C/CONCLUSÃO
- 181: 07/12/23 / rf diz q rb esta ainda a trocar info com forn
- 182: 05/01/24 / PAINEL DESAPERTADO, PQ ARTUR DECIDIU N APERTAR TUDO PQ JULGAVA Q IAMOS SUBSTITUIR OS PAINEIS À GARANTIA / 04/10/23 / CLIENTE PAGOU DESLOCAÇÃO / VERIFICAR PAINEIS DANIFICADOS / 01/9 / FATURAR CONCLUSÃO DE OBRA, INFORMAR INICIO DE GARANTIAS / ESCOLA N ABRE EM 2023
- 183: 15/12/23 / JC VISITOU OBRA, AINDA SSEM JANELAS / ACORDOU C/ENGº EMANUEL A DESCARGA EM OBRA. / 17/11/23 / Boa tarde Raúl e José. / Falei agora com o Eng.º Emanuel Roleira e o que o mesmo pretende é: / 1Que o José visite a obra para conhecer o ponto de situação da mesma e se existem condições para deixar o material na obra ou no estaleiro da Casais (responsabilidade de transporte posterior para a obra da responsabilidade da CONSTRU); / 2Que o Raúl o informe da previsão de entrega do material em obra e envie o Packing List para o Eng.º Emanuel; / 3O pagamento da Adjudicação está em fase de ser efetuado e a garantia bancária não se vai renovar. / DATA LIMITE ENTREGA EQUIPAMENTO EM OBRA: 19/01/24
- 184: 19/1/24 / JC VAI ENVIAR ATAS DE ENTREGA PARA ARQ RENATO ASSINAR E DEVOLVER
- 187: 13/10/23 / PRECISAMOS DE SUBSTITUIR UMAS PEÇAS / 01/9/23 / OBRAS ATRASADAS / FATURAR CONCLUSÃO INFORMAR INICIO DE GARANTIAS / 07/7 / JC VAI PASSAR NA OBRA / 30/6 / 1 DIA DE TRABALHO
- 188: 25/8/23 / RB AINDA COM APROVAÇÃO DAS PLANTAS DE INSTALAÇÃO
- 189: 13/10/23 / APOS VISITA COM JC ART FICOU DECIDIDO MAIS 2 DIAS DE TRABALHO / 22/9/23 / FOI DECIDIDO ENTREGAR O TRANSP AO JORGE DE CINFÃES / 04/8/23 / CLIENTE DE FERIAS, JC VAI LIGAR DIA 03/9
- 193: 15/12/23 / ENTREGA REALIZADA, FICOU COM BATERIAS DESLIGAS / 20/10/23 / IENTREGUE E INSTALADO WK 48 / CONTRATO ASSINADO 17/5 / PAGAMENTO 09/10 / PRAZO DE 7 SEMANAS + 2 DIAS MONTAGEM / ADJUDICAÇÃO AINDA POR LIQUIDAR
- 194: 15/12/23 / EQUIPAMENTO INSTALADO, MAS DESLIGADO POR N TER ENERGIA DEFINITIVA / 20/10/23 / IENTREGUE E INSTALADO WK 48 / CONTRATO ASSINADO 17/5 / PAGAMENTO 09/10 / PRAZO DE 7 SEMANAS + 2 DIAS MONTAGEM / ADJUDICAÇÃO AINDA POR LIQUIDAR
- 197: ENTREGA + FORMAÇÃO
- 198: 04/20/23 / HOUVE 2 SEMANAS DE ATRASO NO TRANSPORTE / 15/9/23 / PEDIR PARA ENTREGAR NO ARMAZEM
- 199: 10/11/23 / CLIENTE JÁ CONFIRMOU CONCLUSÃO E TRABALHOS / 20/10/23 / CLIENTE TEM DE EXECUTAR TRABALHOS DE REMATE / ADR INFORMA FALTAREM 2D+2H / 04/10/23 / PREVISTO 5,7 DIAS / 29/9/23 / RB PASSOU NA OBRA E INFORMOU Q ESTA TUDO OK / FICOU DE ENVIAR FOTOS / 11/9/23 / CLIENTE LIGOU A PEDIR MONTAGEM / 3 STOPS caixa alvenaria / 01/9/23 / AGUARDA MONTAGEM / MATERIAL ENTREGUE / 25/8/23 / SUPERVISOR TEM DE CONFIRMAR TRABALHOS POR PARTE DO CLIENTE / RF ACORDOU C/CLIENTE ENTREGA DOS MATERIAIS / 21/8/23 / ENTREGA DOS MATERIAIS / 04/8/23 / OBRA C/CONDIÇOES PARA MONTAGEM / JC INFORMOU O CLIENTE QUE TEMOS DISPONIBILIDADE PARA FINAL DE SETEMBRO. / DATA MAXIMA CONCLUSÃO: 29/09/2023
- 203: 10/11/23 / JC VAI FAZER VISITA À OBRA 13/11/23 / 01/9/23 / AINDA N PAGARAM MATERIAIS / 30/6/23 / MATERIAL ENTREGUE / RAUL FICOU DE FATURAR / CLIENTE N DÁ CONDIÇOES
- 204: 10/11/23 / CLIENTE AGUARDA AGENDAMENTO / 20/10/23 / RF VAI FATURAR CONCLUSÃO DE OBRA / 01/9/23 / RF LIGAR C/ARQ 3 DIAS ANTES / TENTAR CONCLUIR / 15/6/23 / 1 DIA DE TRABALHO / FALTAM AFINAÇÕES, PROBLEMAS DE CORRENTE EM OBRA
- 206: 04/10/23 / AGUARDAMOS ENVIO DO CARRIL / 18/8 / AGUARDAMOS CUSTO RMK / 04/8 / rb já enviou novo survey p/fábrica / 29/7 / ERRO NO CARRIL
- 207: 20/10/23 / RF VAI FALAR C/CLIENTE PARA ABORDAR CONTRATOS DE MAN / 13/10/23 / VAMOS ANALISAR CUSTOS PAINEIS / OFERECER 1A MAN + GARANTIA 10A / 04/10/23 / CLIENTE PAGOU DESLOCAÇÃO / VERIFICAR PAINEIS DANIFICADOS / 22/9 / SICMALEVA N ACEITRA RECLAMAÇÃO / CONTATAMOS SICMALEVA, ADALBERTO VAI TER DE ANALISAR, FICARAM DE DAR FEEDBACK / 01/9 / FATURAR CONCLUSÃO DE OBRA, INFORMAR INICIO DE GARANTIAS / ESCOLA N ABRE EM 2023 / PROBLEMAS NOS PAINEIS DAS PORTAS / 07/7 / JC VAI FALAR C/SICMALEVA / 30/6 / JC N TEM PREVISÃO DE ENTREGA DOS PAINEIS / FALTA TROCAR PAINEIS / 2 DIAS
- 208: 10/11/23 / RF VAI ENVIAR EMAIL PARA MONTORO / EMAIL DE MAIO / ON-101/RB/21-PLATINUM- 6050626 - JARDIM INFANCIA BENFICA - LISBOA / MANUTENÇÃO NUNCA REALIZADA / ON-022/RB/21 - OPTION A - PLATINUM - 6051278 - CASA DO BARQUEIRO - FUNDÃO
- 210: 20/01/23 / ART PASSOU NA OBRA, ESTÁ EM FASE DE ACABAMENTOS / CLIENTE ENVIOU EMAIL C/RECLAMAÇÃO / 01/9/23 / N SABEMOS SE RECECIONAMOS OS BOTOES / VER C/ATR+VTR / 15/6/23 / FALTA MUDAR BOTOES DE CABINA, / AFINAR E / ENTREGA FINAL
- 211: 01/9 / N SABEMOS SE RECECIONAMOS OS BOTOES / VER C/ATR+VTR / 15/6 / FALTA MUDAR BOTOES DE CABINA / AFINAR / ENTREGA FINAL
- 213: GAVIAO / CASTELO BRANCO
- 217: 04/10/23 / CLIENTE LIGOU A PEDIR CONCLUSÃO / 29/9/23 / FALTAM MATEIRAIS, PUXADORES / 18/8/23 / PRECISAMOS DE AJUDA DA SICMALEVA PARA PROGRAMAR / 29/7/23 / FALTA 1 DIA / PROGRAMAÇÃO - LEVAR CONSOLA / PORTA INSTALADA / 1/7/23 / 2 DIAS / AGUARDAMOS PORTA / 24/2/23 / Boa tarde Eng. Rui Dias . / Espero que se encontre Bem . / Como falado ontem vamos ter mesmo que trocar a porta do piso 0 que as medidas veio por engano . / Veio a porta com 700 x100mais 100 , o que foi encomendado porta de 650 x aro 75x75 falta também dois braços de fechadura aljo mais dois puxadores de porta . / Esta obra infelizmente teve parada derivados a vários motivos a que nos somos alheios ,peço desculpa só agora dar estas noticias nada boas para ambos .
- 218: 22/9 / FALTAM COMANDOS??? / INTERVENÇÃO PARA SUBSTITUIR BORRACHAS E CHAVES
- 219: 27/10/23 / RECEBEMOS REPORT JOÃO SEMECA / NA INTERVENÇÃO ESTEVE A OTIS PRESENTE / 20/10/23 / RF VAI REFORÇAR NOVO EMAILA COM SEMECA / 04/10/23 / CLIENTE VOLTOU A REPORTAR ANOMALIAS / AGUARDAMOS RESPOSTA DA SMECA / 29/9/23 / SMECA VAI TER DE FAZER NOVA INTERVENÇÃO, UMA DAS VALVULAS COM PROBLEMAS / SMECA ENVIOU REPORT DA INTERVENÇÃO / RAUL, VAI COLOCAR COPIA NA REDE / 15/9 / SEMECA VAI FAZER NOVA INTERVENÇÃO / 25/8 / RF VAI PEDIR CONTATO DO FILHO / 18/8 / JC AGUARDA EMAIL C/FEEDBACK DA INTERVENÇÃO
- 220: 20/10/23 / EQUIPAMENTO PARADO / FAZER MANUTENÇÃO
- 221: 04/10/23 / AFINAÇÕES FINAIS E ENTREGA
- 222: LIGAR À CDI / LEVAR BATRERIAS P DOMOFLEX
- 223: 22/9 / FALTAM COMANDOS??? / INTERVENÇÃO PARA SUBSTITUIR BORRACHAS E CHAVES
- 224: 5 MAN
- 225: 13/10/23 / FALTA BOTAP PISO 0 + CONTRATO MAN / 29/9/23 / FAZER ENGTREGA / FALTAM 2 DIAS P/ACABAR / CONCLUIDA EM 31/07/23
- 226: 13/10/23 / AVARIA NO MOTOR / SUBSTITUIR PELA DO ARMAZEM
- 227: 20/10/23 / CLIENTE CANCELOU NO DIA / VAMOS FATURAR NA PRX VEZ DES+MO / 13/10/23 / FALTA BOTAP PISO 0 + CONTRATO MAN / 29/9/23 / FAZER ENGTREGA / FALTAM 2 DIAS P/ACABAR / CONCLUIDA EM 31/07/23
- 228: 13/10/23 / AVARIA NO MOTOR / SUBSTITUIR PELA DO ARMAZEM
- 229: PROBLEMAS NO BOTÃO DO STOP
- 230: AFINAMOS FECHADURAS
- 232: 13/10/23 / ART DETETOU UMA LINHA MAL LIGADA NO GMV / 29/9/23 / ANDRÉ COM DIFICULDADES EM RESOLVER ERRO / AGENDAR COM ITALIA / 15/9 / PASSAR PARA CONFIRMAR TRABALHOS / 11/9 / ANDRE N CONCLUIU / CLIENTE TEM DE REALIZAR PAREDES LATERAIS / 1 DUIA DE TRABALHO / 04/8 / JC VAI REUNIR C/CLIENTE
- 233: 13/10/23 / ART DETETOU PROBLEMA NA PLACA / FAZER RECLAMAÇÃO À SICMALEVA / 04/10/23 / 32H GASTAS / CLIENTE AGUARDA OR P/PINTURA DE PORTAS / EXISTE PROBLEMA TÉCNICO / 29/9/23 / AGUARDAMOS Q CLIENTE TERMINE TRABALHOS / PREVISTO 2 DIAS DE TRABALHO
- 234: 04/10/23 / APOS INTERVENÇÃO DO PLADUR APARECERAM PROBLEMAS TÉCNICOS / 25/9 / CABINA BATE NO PLADUR DE REMETAES DE PORTAS / 15/9 / ANDRE FALHOU COMPROMISSO CM CLIENTE / 01/9 / CLIENTE LIGOU PARA REALIZARMOS LIGAÇÃO / 30/6/23 / FALTA FAZER ENTREGA
- 235: 15/9 / VISITA PARA ANALISAR H200
- 236: 04/10/23 / FALTA LIMPEZA GERAL / FAZER ENTREGA / 15/9/23 / AGENDAR / AGUARDAMOS PAGAMENTO E TRABALHOS FINAIS CLIENTE / 11/9 / FATURAR CONCLUSÃO / FALTA LIMPEZA GERAL / --------------------------------------------- / FICA A FALTAR 1 DIA DE TRABALHO / ENTREGUE EM OBRA / DATA PREVISTA MONTAGEM: / SEMANA 25 (19/06 A 23/06)
- 237: 1ªintervenção 20/9
- 238: 04/10/23 / RF ENVIOU CM AO CLIENTE / TUDO OK / 15/9/23 / RF VAI LIGAR C/CLIENTE / 11/9/23 / N TEMOS REPORT DO ARTUR / ARTUR VAUI FAZER INTERVENÇÃO / APENAS LIGA
- 240: 15/9 / ANDRÉ FOI CONCLUIR / N ENVIOU REPORT / 18/8 / JC VAI ENVIAR EMAIL C/PEDIDO DE RECLAMAÇÃO À SICMALEVA / RODAS OPERADOR CABINA PARTIDAS
- 241: 29/9 / COCLUIDO / 15/6 / FALTA FAZER ENTREGA + AFINAÇÕES / 1 DIA ENTREGA / CLIENTE TEM DE REALIZAR ACABAMENTOS
- 243: 29/9 / RAUL VAI FALAR COM CB PARA DECIDIR PROCESSO DE INJUÇÃO / CLIENTE ALEGA Q N TEM AUTO DE ENTREGA PARA PAGAR / 22/9 / ANDRÉ VAI FAZER INTERVENÇÃO, RF SOLICITOU PAGAMENTO. / 1.Nao foi dada formação ao cliente de forma esclarecedora, nem os procedimentos basicos de segurança, não foram entregues as fichas tecnicas, maunual de instruções ou manual de segurança. / 2.O puxador da porta do piso 0 saiu / 3.As dobradiças estão a fazer muito barulho e pressão (porta piso 0) / 15/6 / FALATAM AFINAÇÕES / AGUARDAMOS INIDICAÇÕES CLIENTE
- 244: ANDRE N ENVIOU O REPORT
- 245: 19/9 / PROBLEMAS NA JUNTA
- 246: 12/9 / LIGAÇÃO FINAL EQUIPAMENTO / RECLAMAÇÃO DE DANOS NO CARRIL
- 247: 15/9 / RF VAI FATURAR CONCLUSÃO / FALTA SUBSTITUIR BOTÃO / 11/9 / ART, CONFIRMOU 2 DIAS / DATA CONCLUSÃO OBRA: 21/09/2023
- 248: substituimos as 2 baterias e fizemos manutenção

| ID | WBS | Task | Type | Duration | Start | Finish | Predecessors | Resources | EQPMTO | LOCALIDADE | CLIENTE | FT/PGM |
| --- | --- | --- | --- | --- | --- | --- | --- | --- | --- | --- | --- | --- |
| 249 | 5.189 | OS | milestone | 0d | 2023-09-11 | 2023-09-11 |  | AND; GON | SUPRA | FELGUEIRAS |  |  |
| 250 | 5.190 | 009RB21 | milestone | 0d | 2023-09-11 | 2023-09-11 |  | ATR | H200 | S FELIX DA MARINHA | CALL TO ACTION |  |
| 251 | 5.191 | 043RB22 |  | 1d | 2023-09-09 | 2023-09-09 |  | AND; GON | SUPRA | LEIRIA | ERGSILVA | 100/100 |
| 252 | 5.192 | 047RB23 |  | 5d | 2023-09-04 | 2023-09-08 |  | AE | MONTA CARGAS PHL1000 | OVAR | DAYLIGHT | 100/100 |
| 253 | 5.193 | 198/19 | milestone | 0d | 2023-07-14 | 2023-07-14 |  |  | INDOMO | AVEIRO | ISABEL CRISTINA | 100/100 |
| 254 | 5.194 | 102RB22 | milestone | 0d | 2023-07-14 | 2023-07-14 |  |  | SUPRA | FELGUEIRAS | JOSE MAIA | 100/100 |
| 255 | 5.195 | 066LG22 |  | 1d | 2023-08-31 | 2023-08-31 |  | VTR | GMV | BATALHA | EDIBATALHA | 100/100 |
| 256 | 5.196 | 036RB22 | milestone | 0d | 2023-08-31 | 2023-08-31 |  | VTR | H200 | COSTA DA CAPARINDA | MARCHAN - RECLAMAÇÃO |  |
| 257 | 5.197 | 063LG22 |  | 2d | 2023-08-28 | 2023-08-29 |  | AE | SUPRA | PORTO | CLUBE FERROVIARIO PORTUGAL | 100/100 |
| 258 | 5.198 | 079DM20 | milestone | 0d | 2023-08-25 | 2023-08-25 |  | AND; VTR | SUPRA | S. MAMEDE INFESTA | COSTEIRA - RECLAMAÇÃO |  |
| 259 | 5.199 | 096DM |  | 1d | 2023-08-23 | 2023-08-23 |  | ATR; VTR | GMV | CELORICO BASTOS | BRITACOSTA - OTSR |  |
| 260 | 5.200 | OTSM |  | 1d | 2023-08-22 | 2023-08-22 |  | ATR | GMV | BEJA | PISCINAS BEJA - OTSM |  |
| 261 | 5.201 | OTSM |  | 1d | 2023-08-22 | 2023-08-22 |  | VTR |  |  | OTSM |  |
| 262 | 5.202 | OTSM / OTSR |  | 1d | 2023-08-21 | 2023-08-21 |  | VTR |  | LEIRIA | OTSM / OTSR |  |
| 263 | 5.203 | 115RB20 |  | 3d | 2023-08-24 | 2023-08-26 |  | AND; GON | GMV | SARDOAL | CANAS | 100/100 |
| 264 | 5.204 | tarefa_146 |  | 3d | 2023-08-27 | 2023-08-29 | 263 | AND; GON |  |  |  |  |
| 265 | 5.205 | 079DM20 |  | 1d | 2023-08-21 | 2023-08-21 |  | AND; GON | SUPRA | PORTO | COSTEIRA (S.º MAMEDE INFESTA) | 100/100 |
| 266 | 5.206 | RECLAMAÇÃO | milestone | 0d | 2023-08-11 | 2023-08-11 |  | ATR | SUPRA | RIBEIRÃO |  |  |
| 267 | 5.207 | 092RB22 |  | 4d | 2023-08-02 | 2023-08-05 |  | ATR; VTR | GMV | BRAGA | CS CONSTRUTORA | 100/100 |
| 268 | 5.208 | 053RB22 |  | 4d | 2023-08-02 | 2023-08-05 |  | AND; GON | H200 | VILA NOVA GAIA | CATEGORY INSPIRATION | 100/100 |
| 269 | 5.209 | 056RB21 |  | 4d | 2023-08-07 | 2023-08-10 |  | ATR; VTR | H200 | CABEÇO DE VIDE | PAULO PATRICIO DA COSTA | 100/100 |
| 270 | 5.210 | 054RB23 | milestone | 0d | 2023-07-14 | 2023-07-14 |  |  | PEV300 | AMARANTE | MANUEL ORLANDO PINTO TEIXEIRA | 100/100 |
| 271 | 5.211 | 067RB23 |  | 2d | 2023-08-03 | 2023-08-04 |  | AND; VTR | H200 | SETUBAL | PEDRO VASCONSELOS | 100/100 |
| 272 | 5.212 | ON-005 | milestone | 0d | 2023-07-26 | 2023-07-26 |  | VTR; GON | MC+GMV | FREIXO ESPADA ACINTA | MJ CALDEIRA | 100/100 |
| 273 | 5.213 | 036RB22 | milestone | 0d | 2023-07-26 | 2023-07-26 |  | ATR; VTR | H200 | COSTA CAPARICA | FILIPE MARCHAND | 100/100 |
| 274 | 5.214 | 043RB22 |  | 1d | 2023-07-18 | 2023-07-18 |  |  | MONTA PRATOS 100KG | LEIRIA | ERGSILVA | 100/100 |
| 275 | 5.215 | 157RB22 |  | 1d | 2023-07-18 | 2023-07-18 |  | JC | SUPRA | VIANA CASTELOS | BALTOR | 100/100 |
| 276 | 5.216 | 058RB21 |  | 1d | 2023-07-18 | 2023-07-18 |  | AND; GON | H200 | LISBOA | BLOCO ZERO | 100/100 |
| 277 | 5.217 | 201RB22 |  | 56d | 2023-05-25 | 2023-07-19 |  | AE | AE | LISBOA | GENIUS ALMEIDA | 100/100 |
| 278 | 5.218 | 141DM21 |  | 1d | 2023-07-10 | 2023-07-10 |  | VTR; GON | SUPRA | GONDOMAR | RAQUEL SUSANA CUNHA M. MOTA | 100/100 |
| 279 | 5.219 | 040LG22 |  | 1d | 2023-07-01 | 2023-07-01 |  |  | INFINITY | VISEU | FLOPONOR | 100/100 |
| 280 | 5.220 | 129CP23 |  | 1d | 2023-07-01 | 2023-07-01 |  |  | HOMEGLIDE | PORTO | LUIS VIEIRA LOMELINO VELOSA | 100/100 |
| 281 | 5.221 | 201RB22 |  | 1d | 2023-04-20 | 2023-04-20 |  |  | EDE-C | LISBOA | GENIUS ALMEIDA | 100/100 |
| 282 | 5.222 | 084DM21 | milestone | 0d | 2023-05-29 | 2023-05-29 |  |  | DOMOFLEX | PORTO | TOMAS CAMOES | 100/100 |
| 283 | 5.223 | 100RB22 |  | 31d | 2023-05-10 | 2023-06-09 |  |  | GMV |  | DINAMICA IMPARCIAL | 100/100 |
| 284 | 5.224 | 022RB21 |  | 3d | 2023-05-27 | 2023-05-29 |  | ATR; GON | H200 |  | SENTIDO ADICIONAL | 100/100 |
| 285 | 5.225 | 188RB22 |  | 6d | 2023-05-29 | 2023-06-03 |  | AND; VTR | GMV | VIEIRA DO MINHO | MANUEL SILVA | 100/100 |
| 286 | 5.226 | 064LG22 |  | 1d | 2023-05-25 | 2023-05-25 |  | ATR; GON | SUPRA L | FEIJÓ | ANTONIO ARSENIO | 100/100 |
| 287 | 5.227 | 145DM21 |  | 1d | 2023-05-24 | 2023-05-24 |  |  | EDE-C |  | ANTONIO MANUEL R. FERREIRA | 100/100 |
| 288 | 5.228 | 135RB21 |  | 1d | 2023-05-24 | 2023-05-24 |  | ATR; GON | SUPRA L |  | AGOSTINHO NOGUEIRA | 100/100 |
| 289 | 5.229 | 040DM20 | milestone | 0d | 2023-04-14 | 2023-04-14 |  |  | SUPRA |  | ROBERTO SOUSA | 100/100 |
| 290 | 5.230 | 101CP23 | milestone | 0d | 2023-04-14 | 2023-04-14 |  |  | CADEIRA PISCINA B2 |  | CUNHA & BARROSO | 100/100 |
| 291 | 5.231 | 048RB23 | milestone | 0d | 2023-04-14 | 2023-04-14 |  |  | MC |  | BATISTA FERNANDES & T. SEQUEIRA | 100/100 |
| 292 | 5.232 | 026RB23 | milestone | 0d | 2023-04-14 | 2023-04-14 |  |  | INFINITY |  | ANA MARGARIDA MORGADO MOREIRA | 100/100 |
| 293 | 5.233 | 052LG22 | milestone | 0d | 2023-04-14 | 2023-04-14 |  |  | HOMEGLIDE |  | INTERLOVERS | 100/100 |
| 294 | 5.234 | 063RB23 | milestone | 0d | 2023-04-19 | 2023-04-19 |  |  | HOMEGLIDE OUTDOOR |  | ANTONIO MARIA SILVA | 100/100 |
| 295 | 5.235 | 053RB23 | milestone | 0d | 2023-04-21 | 2023-04-21 |  |  | FLOW X |  | MARIA IRENE GOMES SILVA ARAUJO | 100/100 |
| 296 | 5.236 | 039LG22 | milestone | 0d | 2023-04-24 | 2023-04-24 |  |  | SUPRA |  | CARLOS MANUEL MARTINS FERREIRA | 100/100 |

Notes:
- 249: COBRAR - SERVIÇO / SUPRA - FELGUEIRAS - JOAO PEDRO FERREIRA, PARAFUSOS EQUIPAMENTOS SOLTOS
- 250: 11/9 / ART VAI FAZER INTERVENÇÃO
- 251: 04/10/23 / 60% FINAIS COM CONFIRMING A 60D / 11/9/23 / INTERVENÇÃO FEITA NO SABADO / FATURAR CONCLUSÃO / 18/8/23 / MONTAGEM E FORMAÇÃO / TIRAR PLASTICOS MONTA PRATOS
- 252: 11/9 / EQUIPAMENTO CONCLUIDO PELA AE. / FICOU DESLIGADO / FATURAR CONCLUSÃO / 18/8 / INFORMAÇÃO DA CARLA ABRANTES QUE CONCLUSAO É NA 1ªWK SET / DATA CONCLUSÃO DA MONTAGEM: 21/07/2023
- 253: 01/9 / CLIENTE LIQUIDOU PROCESSO / 15/6 / 2 DIAS TRABALHO / FALTA LUZ DEFINITIVA
- 254: 30/6 / MATERIAL EM CASA DO CLIENTE / CLIENTE FALECEU / N QUER MONTAGEM
- 255: 25/8 / CLIENTE ESTÁ A PEDIR LIGAÇÃO / RETITAR PLASTICOS E AFINAÇÃO PISOS / 30/7 / FALTAM 2 DIAS DE TRABALHO / PAINEIS DE CABINE ERRADOS / DATA CONCLUSÃO TRABALHOS: 13/06/2023
- 256: 25/8 / JÁ FOMOS 2X AO CLIENTE
- 257: DATA CONCLUSÃO: 04/08/23
- 263: 17/7/23 / JC ALTEROU DATA PARA 31/7 / 07/7/23 / C/ESTRUTURA / JC INFORMOU VIA EMAIL A OBRA C/INFO DE ENTRADA P/17/7
- 266: 04/8 / JC VAI LIGAR C/CLIENTE DIA 10/8
- 267: 07/7 / FALTA PAGAR MATERIAIS / PRAZO CONCLUSÃO MONTAGEM: / 15/06/2023
- 268: MATRIAL EM OBRA
- 270: 07/7 / AE INFORMA DIA 10/7 QUANDO TEM PEÇA PRONTA / 30/6 / FALTA COLOCA CHAPA INXO TRASEIRA / JC VAI FALAR C/VASSALO
- 271: DATA CONCLUSÃO OBRA: / 05/07/2023
- 272: 17/7/23 / PARA QUNADO ESTÁ AGENDADO?
- 273: JC VAI INFORMAR CLIENTE
- 274: 07/7 / AUTOELEVAÇÃO DIA 10/7 ENVIA DATA DE MONTAGEM P/JC / DATA CONCLUSÃO DA MONTAGEM: 07/07/2023
- 277: DATA ADIANTADA PELA AUTO ELEVAÇÃO PARA CONCLUSÃO: / SEMANA 26 (26/06 A 30/06)
- 279: LEVAR BACO E FIXAR PES
- 282: DIA 22/5 CLIENE N ESTAVA EM CASA PARA NOS RECEBER E INICIAR TRABALHOS / DATA CONCLUSÃO DA MONTAGEM: 07/06/23
- 283: 2 DIAS PARA ACABAR OBRA / PAINEIS DE CABINA ERRADOS / DATA CONCLUSÃO OBRA: 09/06/2023
- 284: OBRA CONCLUIDA EM 22/05/2023
- 287: OBRA CONCLUIDA EM 20/05/2023
- 294: MONTAGEM DIA 19/04/23
- 295: MONTAGEM DIA 21/04/23
