# Crèche de VILLERS SEMEUSE

Schedule from GanttProject, 2022-06-14 to 2023-04-19.
Holidays every year on 01-01, 05-01, 05-08, 07-14, 08-15, 11-01, 11-11, 12-25

## Calendars

- Project calendar: Mon-Fri working; Sat-Sun off. Exceptions (off unless hours are given): 2022-08-08 to 2022-08-12, 2022-08-16 to 2022-08-19, 2022-08-22 to 2022-08-26, 2022-08-29 to 2022-08-31, 2022-12-26 to 2022-12-30, 2023-04-10 (Lundi de Pâques).

## Schedule

| ID | Task | Type | Duration | Start | Finish | Predecessors |
| --- | --- | --- | --- | --- | --- | --- |
| 1 | PREPARATION DE CHANTIER |  | 9d | 2022-06-14 | 2022-06-24 |  |
| 2 | CONFORTEMENTS: tirants de charpente, contreventements des fenêtres |  | 5d | 2022-06-27 | 2022-07-01 | 1 |
| 3 | DEMONTAGE PLANCHER 2e ETAGE + MURS |  | 7d | 2022-07-04 | 2022-07-12 | 2 |
| 4 | FONDATIONS EN SOUS SOL |  | 7d | 2022-07-13 | 2022-07-22 | 3 |
| 5 | MACONNERIES RDC |  | 10d | 2022-07-25 | 2022-08-05 | 4 |
| 6 | PLANCHER 1er ETAGE + ESCALIER RDC |  | 12d | 2022-09-01 | 2022-09-16 | 5 |
| 7 | STRUCTURE ETAGE |  | 5d | 2022-09-19 | 2022-09-23 | 6 |
| 8 | PLANCHER 2é ETAGE + ESCALIER 1er |  | 12d | 2022-09-26 | 2022-10-11 | 7 |
| 9 | DESAMIANTAGE |  | 5d | 2022-10-12 | 2022-10-18 | 8 |
| 10 | CHARPENTE |  | 15d | 2022-10-19 | 2022-11-09 | 9 |
| 11 | RAVALEMENT FACADE AVANT |  | 15d | 2022-10-19 | 2022-11-09 | 9 |
| 12 | COUVERTURE |  | 15d | 2022-11-10 | 2022-12-01 | 10 |
| 13 | RAVALEMENT FACADE ARRIERE |  | 15d | 2022-11-10 | 2022-12-01 | 11 |
| 14 | MENUISERIES EXTERIEURES BOIS |  | 20d | 2022-11-25 | 2022-12-22 | 12SS+10d |
| 15 | RAVALEMENT CLOTURES |  | 10d | 2022-12-02 | 2022-12-15 | 13 |
| 16 | HORS D'EAU - HORS D'AIR Grand Bâtiment | milestone | 0d | 2022-12-23 | 2022-12-23 | 14 |
| 17 | TRACAGE DES CLOISONS |  | 3d | 2022-12-21 | 2022-12-23 | 14SS+18d |
| 18 | RESEAUX ELECTRIQUES et COURANTS FAIBLES |  | 10d | 2023-01-02 | 2023-01-13 | 17 |
| 19 | RESEAUX DE CLIMATISATION, VENTILATION et PLOMBERIE |  | 10d | 2023-01-02 | 2023-01-13 | 17 |
| 20 | CLOISON CF ESCALIER 2è étage |  | 3d | 2023-01-16 | 2023-01-18 | 19 |
| 21 | DOUBLAGES + FAUX_PLAFONDS 2è ètage |  | 12d | 2023-01-19 | 2023-02-03 | 20 |
| 22 | CLOISON 2è ètage |  | 5d | 2023-02-06 | 2023-02-10 | 21 |
| 23 | REVETEMENTS DE SOLS 2é étage |  | 7d | 2023-02-13 | 2023-02-21 | 22 |
| 24 | FAIENCE 2é étage |  | 3d | 2023-02-22 | 2023-02-24 | 23 |
| 25 | EQUIPEMENT SANITAIRE |  | 3d | 2023-02-27 | 2023-03-01 | 24 |
| 26 | PEINTURE 2 é étage |  | 15d | 2023-02-22 | 2023-03-14 | 23 |
| 27 | EQUIPEMENT DE MENUISERIE |  | 3d | 2023-03-09 | 2023-03-13 | 26SS+11d |
| 28 | EQUIPEMENT ELECTRIQUE |  | 3d | 2023-03-09 | 2023-03-13 | 26SS+11d |
| 29 | DOUBLAGES 1er étage |  | 10d | 2023-01-30 | 2023-02-10 | 21SS+7d |
| 30 | CLOISONS ET BA13 COLLE 1er étage |  | 3d | 2023-02-13 | 2023-02-15 | 29 |
| 31 | RAILLAGE ET JOUEES 1er étage |  | 5d | 2023-02-16 | 2023-02-22 | 30 |
| 32 | REVETEMENT DE SOLS 1er étage |  | 10d | 2023-02-23 | 2023-03-08 | 31 |
| 33 | FAIENCE 1er étage |  | 5d | 2023-03-09 | 2023-03-15 | 32 |
| 34 | EQUIPEMENT SANITAIRE |  | 5d | 2023-03-16 | 2023-03-22 | 33 |
| 35 | PEINTURE 1er étage |  | 15d | 2023-03-09 | 2023-03-29 | 32 |
| 36 | EQUIPEMENT DE MENUISERIE |  | 3d | 2023-03-24 | 2023-03-28 | 35SS+11d |
| 37 | EQUIPEMENT ELECTRIQUE |  | 3d | 2023-03-24 | 2023-03-28 | 35SS+11d |
| 38 | DOUBLAGES RDC |  | 10d | 2023-02-13 | 2023-02-24 | 29 |
| 39 | CLOISONS RDC |  | 6d | 2023-02-27 | 2023-03-06 | 38 |
| 40 | RAILLAGE + JOUEES RDC |  | 5d | 2023-03-07 | 2023-03-13 | 39 |
| 41 | REVETEMENT DE SOLS RDC |  | 10d | 2023-03-14 | 2023-03-27 | 40 |
| 42 | FAIENCES RDC |  | 3d | 2023-03-28 | 2023-03-30 | 41 |
| 43 | EQUIPEMENT SANITAIRE |  | 3d | 2023-03-31 | 2023-04-04 | 42 |
| 44 | INSTALLATION PLATEFORME PMR |  | 3d | 2023-03-28 | 2023-03-30 | 41 |
| 45 | PEINTURE RDC et NETTOYAGE CHANTIER |  | 15d | 2023-03-28 | 2023-04-18 | 41 |
| 46 | MOBILIER ACCUEIL et REPOS/REPAS |  | 3d | 2023-04-12 | 2023-04-14 | 45SS+10d |
| 47 | EQUIPEMENT DE MENUISERIE |  | 3d | 2023-04-13 | 2023-04-17 | 45SS+11d |
| 48 | EQUIPEMENT ELECTRIQUE |  | 3d | 2023-04-13 | 2023-04-17 | 45SS+11d |
| 49 | RECEPTION DES TRAVAUX | milestone | 0d | 2023-04-19 | 2023-04-19 | 45 |
| 50 | DEMOLITION REFEND EXISTANT RDC |  | 2d | 2022-10-12 | 2022-10-13 | 8 |
| 51 | DALLAGE RDC compris mise à niveau |  | 11d | 2022-10-14 | 2022-10-28 | 50 |
| 52 | FACADE ARRIERE petit bâtiment |  | 10d | 2022-10-31 | 2022-11-15 | 51 |
| 53 | PORTIQUE GAUCHE DE L'ENTREE sur accueil confidentiel |  | 7d | 2022-11-16 | 2022-11-24 | 52 |
| 54 | PLANCHER 1er ETAGE PETIT BATIMENT |  | 10d | 2022-11-25 | 2022-12-08 | 53 |
| 55 | DEOLITION CURTAGE TERRASSEMENT COUR ARRIERE |  | 11d | 2022-12-09 | 2022-12-23 | 54 |
| 56 | ESCALIER CAVE |  | 15d | 2023-01-02 | 2023-01-20 | 55 |
| 57 | AMENAGEMENT COUR ARRIERE |  | 8d | 2023-01-23 | 2023-02-01 | 56 |
| 58 | FONDS DE FORME RDC Petit bâtiment |  | 3d | 2023-02-02 | 2023-02-06 | 57 |
| 59 | FACADES Petit bâtiment |  | 3d | 2023-02-07 | 2023-02-09 | 58 |
| 60 | DALLAGE RDC Petit bâtiment |  | 3d | 2023-02-10 | 2023-02-14 | 59 |
| 61 | MENUISERIES EXTERIEURES "garage" |  | 5d | 2023-02-15 | 2023-02-21 | 60 |
| 62 | DOUBLES 1er étage "garage" |  | 5d | 2023-02-22 | 2023-02-28 | 61 |
| 63 | CLOISONS 1er étage "garage" |  | 5d | 2023-03-01 | 2023-03-07 | 62 |
| 64 | FAUX_PLAFONDS 1er étage "garage" |  | 5d | 2023-03-08 | 2023-03-14 | 63 |
| 65 | DOUBLAGES RDC "garage" |  | 5d | 2023-03-15 | 2023-03-21 | 64 |
| 66 | CLOISONS RDC "garage" |  | 3d | 2023-03-22 | 2023-03-24 | 65 |
| 67 | FAUX_PLAFONDS RDC "garage" |  | 4d | 2023-03-27 | 2023-03-30 | 66 |
