# FT231501-CTT3x2-rev00 proposta BD

Schedule from GanttProject, 2024-02-19 to 2025-03-03.
Gru Comedil

## Calendars

- Project calendar: Mon-Fri working; Sat-Sun off. Exceptions (off unless hours are given): 2024-03-04, 2024-03-15, 2024-03-22, 2024-03-29, 2024-03-31 to 2024-04-01, 2024-04-25, 2024-05-01, 2024-06-02, 2024-08-15, 2024-11-01, 2024-12-08, 2024-12-25 to 2024-12-26.

## Schedule

| ID | Task | Type | Duration | Start | Finish | Predecessors | Complete |
| --- | --- | --- | --- | --- | --- | --- | --- |
| 1 | Gate 2 | milestone | 0d | 2024-07-26 | 2024-07-26 |  |  |
| 2 | Gate 3 | milestone | 0d | 2025-03-03 | 2025-03-03 |  |  |
| 3 | TB08-BOMs,Drawings, Specs for 1st Article production-F2-ENG-C |  | 2d | 2024-02-19 | 2024-02-20 |  | 100% |
| 4 | TB09-BOMs,Drawings, Specs for 1st Article production-F2-ENG-C |  | 2d | 2024-02-21 | 2024-02-22 | 3 | 100% |
| 5 | TB38-BOMs,Drawings, Specs for 1st Article production-F2-ENG-C |  | 5d | 2024-02-23 | 2024-02-29 | 4 | 100% |
| 6 | TB37-BOMs,Drawings, Specs or 1st Article production-F2-ENG-C |  | 3d | 2024-03-01 | 2024-03-06 | 5 | 100% |
| 7 | TB36-BOMs,Drawings, Specs for 1st Article production-F2-ENG-C |  | 6d | 2024-03-07 | 2024-03-14 | 6 | 100% |
| 8 | TB34-BOMs,Drawings, Specs for 1st Article production-F2-ENG-C |  | 5d | 2024-03-26 | 2024-04-03 | 10 |  |
| 9 | TB35-Calculations & Docs for regulatory Technical File-F2-ENG-C |  | 1d | 2024-02-19 | 2024-02-19 |  |  |
| 10 | TB35-BOMs,Drawings, Specs for 1st Article production-F2-ENG-C (Carpenteria) |  | 5d | 2024-03-18 | 2024-03-25 | 7, 9 | 100% |
| 11 | TB35-Evaluation & Choice of Suppliers-F2-MTS |  | 1d | 2024-03-26 | 2024-03-26 | 10 |  |
| 12 | TB35-1st Article Production, Inspection, Review, Acceptance-F3-MTS |  | 1d | 2024-03-27 | 2024-03-27 | 11 |  |

Notes:
- 1: -Dicosola 110324- Nella presentazione G1, il G2 è indicato ad Aprile 2024. Stante il Gantt rev.04 emesso da Engineering la disegnazione degli allestimenti termina al 2 Agosto 2024, da cui si pone oggi G2 al 26/07/2024
- 2: -Dicosola 11032024 In presentazione G1 ci sono 7 mesi per la fase 3 tra Gate 2 e Gate 3. In questo Gantt, la fase 3 dura sempre 7 mesi includendo però oltre alle ferie estive quelle natalizie.
- 3: -In collaborazione con SBR. / -ECN 6130 notifica 23/02/2024
- 4: -In collaborazione con SBR. / -ECN 6130 notifica 23/02/2024
- 5: -In collaborazione con SBR. / -ECN 6130 notifica 06/03/2024
- 6: -In collaborazione con SBR. / -ECN 6130 notifica 06/03/2024
- 7: -In collaborazione con SBR / -Attività completata con emissione ECN6130
- 8: -Incluso disegno costruttivo. In collaborazione con SBR
- 10: -Incluso disegno costruttivo. In collaborazione con SBR / --Attività completata con emissione ECN6130
