# Plan Lansare inchiriere-imprimanta.ro (Iulie-Dec 2025)

Schedule from GanttProject, 2025-07-14 to 2025-07-14.
IntServ Solutions SRL
Sprint de 6 luni pentru construirea fundatiei si generarea primelor venituri.

## Calendars

- Project calendar: Mon-Fri working; Sat-Sun off.

## Resources

| Resource |
| --- |
| Fondator |

## Schedule

| ID | WBS | Task | Duration | Start | Finish | Predecessors | Resources |
| --- | --- | --- | --- | --- | --- | --- | --- |
| 1 | 1 | **LUNA 1: IULIE - FUNDAȚIA ȘI LANSAREA** | 15d |  |  | 17 |  |
| 2 | 1.1 | **Săptămâna 1 (14-20 Iulie): Lansare Tehnică și Legală** | 5d |  |  | 8 |  |
| 3 | 1.1.1 | Luni: Testare Finală Website | 1d | 2025-07-14 | 2025-07-14 | 4 | Fondator |
| 4 | 1.1.2 | Marți: Setup Google Suite | 1d |  |  | 5 | Fondator |
| 5 | 1.1.3 | Miercuri: Finalizare Documentație Legală | 1d |  |  | 6 | Fondator |
| 6 | 1.1.4 | Joi: Setup Canale de Comunicare | 1d |  |  | 7 | Fondator |
| 7 | 1.1.5 | Vineri: Audit SEO On-Page Inițial | 1d |  |  |  | Fondator |
| 8 | 1.2 | **Săptămâna 2 (21-27 Iulie): Prezență Publică și Conținut** | 5d |  |  | 13 |  |
| 9 | 1.2.1 | Luni: Setup Pagina de Facebook | 1d |  |  | 10 | Fondator |
| 10 | 1.2.2 | Marți: Optimizare Profil Personal LinkedIn | 1d |  |  | 11 | Fondator |
| 11 | 1.2.3 | Miercuri-Joi: Scrie și Publică Articolul #1 | 2d |  |  | 12 | Fondator |
| 12 | 1.2.4 | Vineri: Creează Calendar de Conținut Q3 | 1d |  |  |  | Fondator |
| 13 | 1.3 | **Săptămâna 3 (28 Iulie - 3 Aug): Activare Inițială** | 5d |  |  |  |  |
| 14 | 1.3.1 | Luni: Promovare Articol #1 | 1d |  |  | 15 | Fondator |
| 15 | 1.3.2 | Marți: Lansare Campanie Google Ads (Test) | 1d |  |  | 16 | Fondator |
| 16 | 1.3.3 | Miercuri-Vineri: Construire Listă Parteneri | 3d |  |  |  | Fondator |
| 17 | 2 | **LUNA 2: AUGUST - DISCIPLINA** | 20d |  |  | 23 |  |
| 18 | 2.1 | **Acțiuni Săptămânale Recurente (Săpt. 4-7)** | 5d |  |  |  |  |
| 19 | 2.1.1 | Marți: Publică articol de blog nou | 1d |  |  | 20 | Fondator |
| 20 | 2.1.2 | Miercuri: Promovează articolul | 1d |  |  | 21 | Fondator |
| 21 | 2.1.3 | Vineri: Analiză Performanță Săptămânală | 1d |  |  |  | Fondator |
| 22 | 2.1.4 | Zilnic: Gestionează Lead-urile | 5d |  |  |  | Fondator |
| 23 | 3 | **LUNA 3: SEPTEMBRIE - VALIDAREA MODELULUI** | 20d |  |  | 27 |  |
| 24 | 3.1 | Săpt. 8: Închiderea Primului Contract | 5d |  |  | 25 | Fondator |
| 25 | 3.2 | Săpt. 9: Creare Studiu de Caz #1 și Prezentare Parteneri | 5d |  |  | 26 | Fondator |
| 26 | 3.3 | Săpt. 10-11: Contactare Parteneri | 10d |  |  |  | Fondator |

Notes:
- 1: Obiectiv: Asigurarea unei lansări tehnice și legale impecabile. Construirea activelor de marketing de bază și publicarea primului conținut fundamental.
- 2: Pilon Strategic: Operațional
- 3: Verifică fiecare link, pagină și testează calculatorul de costuri cu 10 scenarii diferite pentru a garanta acuratețea. Asigură-te că formula de calcul este corectă.
- 4: Creează și instalează Google Analytics 4 și Google Search Console. Setează evenimente de conversie (ex: click pe butonul 'Trimite' al calculatorului).
- 5: Revizuiește cu un avocat draftul de contract de închiriere. Adaugă pe site paginile obligatorii: Termeni și Condiții, Politica de Confidențialitate (GDPR).
- 6: Creează adresele de email profesionale (ex: contact@inchiriere-imprimanta.ro). Configurează un număr de telefon dedicat.
- 7: Asigură-te că fiecare pagină are un titlu unic, o meta-descriere atractivă și o structură logică de heading-uri (un singur H1 per pagină).
- 8: Pilon Strategic: Marketing
- 9: Completează TOATE secțiunile. Creează imagini de profil și copertă profesionale care comunică propunerea de valoare.
- 10: Actualizează-ți titlul în 'Consultant în Optimizarea Costurilor de Printare / Ajut IMM-urile din București...'. Completează secțiunea 'Despre'.
- 11: Titlu: 'Pachete Standard vs. Soluție Flexibilă...'. Explică matematic, cu exemple clare. Integrează link-uri către calculator.
- 12: Planifică titlurile și ideile principale pentru următoarele 6 articole de blog.
- 13: Pilon Strategic: Marketing & Vânzări
- 14: Distribuie articolul pe Facebook și LinkedIn cu un text care stârnește curiozitatea.
- 15: Buget: 30-50 RON/zi. Targetare: București+Ilfov. Cuvinte Cheie: potrivire de frază. Anunț: atacă durerea: 'Sătul de costuri extra?'.
- 16: Creează un Excel și identifică 50 firme de contabilitate și 50 firme de IT din București. NU contacta încă.
- 17: Obiectiv: Stabilirea unui ritm constant de publicare, generarea primelor lead-uri organice.
- 18: Aceste acțiuni se repetă în fiecare săptămână din August. Pilon: Marketing & Vânzări
- 19: Conform calendarului de conținut. Exemple: 'Cele 5 Greșeli...', 'De ce All-Inclusive Nu Înseamnă Același Lucru...'.
- 20: Distribuie pe rețelele sociale, variază textul, pune întrebări.
- 21: Verifică Google Analytics și Ads. Oprește ce nu funcționează, alocă buget pe ce funcționează.
- 22: Răspunde la orice contact în maxim 2 ore. Fii pregătit să prezinți oferta.
- 23: Obiectiv: Semnarea primilor 1-3 contracte, crearea de dovezi sociale și inițierea programului de parteneriate.
- 24: Prioritatea #1. Fii flexibil, ascultă clientul. Continuă ritmul de marketing.
- 25: Creează un studiu de caz anonimizat (Problemă, Proces, Soluție, Rezultat). Creează un PDF de o pagină pentru programul de parteneriate (Comision 100-150 EUR).
- 26: Începe contactarea telefonică a listei de parteneri cu o abordare directă.

| ID | WBS | Task | Duration | Predecessors | Resources |
| --- | --- | --- | --- | --- | --- |
| 27 | 4 | **LUNA 4: OCTOMBRIE - OPTIMIZARE** | 20d | 32 |  |
| 28 | 4.1 | Săpt. 12: Analiză Aprofundată Q3 | 5d | 29 | Fondator |
| 29 | 4.2 | Săpt. 13: Creare Video Walkthrough | 5d | 30 | Fondator |
| 30 | 4.3 | Săpt. 14: Cere Testimoniale | 5d | 31 | Fondator |
| 31 | 4.4 | Săpt. 15: Rafinează Mesajul de Marketing | 5d |  | Fondator |
| 32 | 5 | **LUNA 5: NOIEMBRIE - ACCELERAREA** | 20d | 37 |  |
| 33 | 5.1 | Săpt. 16: Dublează Bugetul Google Ads | 5d | 34 | Fondator |
| 34 | 5.2 | Săpt. 17: Lansează Campanie Remarketing | 5d | 35 | Fondator |
| 35 | 5.3 | Săpt. 18: Follow-up cu Partenerii | 5d | 36 | Fondator |
| 36 | 5.4 | Săpt. 19: Pregătește Anunț Angajare Tehnician | 5d |  | Fondator |
| 37 | 6 | **LUNA 6: DECEMBRIE - REVIZUIRE ȘI PLANIFICARE** | 20d |  |  |
| 38 | 6.1 | Săpt. 20: Postează anunț angajare | 5d | 39 | Fondator |
| 39 | 6.2 | Săpt. 21: Desfășoară interviuri | 5d | 40 | Fondator |
| 40 | 6.3 | Săpt. 22: Analiză Anuală a Performanței | 5d | 41 | Fondator |
| 41 | 6.4 | Săpt. 23: Planificare Strategică Anul 2 | 5d |  | Fondator |

Notes:
- 27: Obiectiv: Analiza datelor din Q3, optimizarea canalelor și creșterea credibilității.
- 28: Care articole/campanii au avut cel mai bun ROI? Care este costul de achiziție per client (CAC)?
- 29: Înregistrare de ecran de 2-3 minute care explică funcționarea calculatorului de costuri. Postează pe YouTube, Facebook, și pe site.
- 30: Contactează primii clienți și cere-le o recenzie pe Google sau un testimonial scris. Oferă un mic discount.
- 31: Ajustează textele de pe site și din anunțuri pe baza feedback-ului de la clienți.
- 32: Obiectiv: Dublarea eforturilor pe canalele care funcționează. Pregătirea pentru angajarea primului tehnician.
- 33: Concentrează bugetul pe campaniile și cuvintele cheie care au adus cele mai bune rezultate.
- 34: Țintește vizitatorii site-ului care nu au completat formularul cu anunțuri care le reamintesc de beneficii.
- 35: Revino cu un telefon sau email la partenerii care au arătat interes inițial. Prezintă-le studiul de caz.
- 36: Definește clar fișa postului: responsabilități, cerințe, beneficii.
- 37: Obiectiv: Analiza performanței anuale, stabilirea obiectivelor pentru Anul 2.
- 38: Postează anunțul pentru Tehnician pe platformele relevante. Începe selecția CV-urilor.
- 40: Analizează indicatorii cheie: Financiar (Venituri, Profit, CAC), Marketing (Lead-uri, conversie), Operațional.
- 41: Setează obiective clare (ex: 50 de contracte, extindere în Prahova). Definește bugetul și planul de angajări. Oferă și semnează contractul cu tehnicianul selectat.
