Schedule from GanttProject, 2024-03-01 to 2024-12-22.

## Calendars

- Project calendar: Mon-Sun working.

## Schedule

| ID | WBS | Task | Duration | Start | Finish | Predecessors | Complete |
| --- | --- | --- | --- | --- | --- | --- | --- |
| 1 | 1 | **SAL EDGING LINE-1** | 286d | 2024-03-11 | 2024-12-21 |  |  |
| 2 | 1.1 | **RESAW BRUSH-1** | 89d | 2024-03-11 | 2024-06-07 |  |  |
| 3 | 1.1.1 | PACK-&-GO & FILE SETUP | 5d | 2024-03-11 | 2024-03-15 |  | 10% |
| 4 | 1.1.2 | CAD UPDATES & MODEL UPDATES | 7d | 2024-03-16 | 2024-03-22 | 3 |  |
| 5 | 1.1.3 | CREATE BOM & REVIEW w/ GOOSE | 7d | 2024-03-23 | 2024-03-29 | 4 |  |
| 6 | 1.1.4 | CREATE WATERJET & FABRICATED PART DRAWING FILES | 7d | 2024-03-30 | 2024-04-05 | 5 |  |
| 7 | 1.1.5 | BOM ORDERING | 7d | 2024-04-06 | 2024-04-12 | 6 |  |
| 8 | 1.1.6 | PURCHASED PARTS RECEIVING & STAGING | 7d | 2024-04-13 | 2024-04-19 | 7 |  |
| 9 | 1.1.7 | WELDMENTS & MACHINING | 7d | 2024-04-20 | 2024-04-26 | 8 |  |
| 10 | 1.1.8 | GENERAL ASSEMBLY | 7d | 2024-04-27 | 2024-05-03 | 9 |  |
| 11 | 1.1.9 | WIRE ASSEMBLY | 7d | 2024-05-04 | 2024-05-10 | 10 |  |
| 12 | 1.1.10 | POWER UP & TEST & DEBUG | 7d | 2024-05-11 | 2024-05-17 | 11 |  |
| 13 | 1.1.11 | CYCLE TEST | 7d | 2024-05-18 | 2024-05-24 | 12 |  |
| 14 | 1.1.12 | TEARDOWN & PAINT | 7d | 2024-05-25 | 2024-05-31 | 13 |  |
| 15 | 1.1.13 | DRAWING & MODEL & BOM UPDATES | 14d | 2024-05-25 | 2024-06-07 | 13 |  |
| 16 | 1.1.14 | RE-ASSEMBLE & PREP FOR SHIPMENT | 7d | 2024-06-01 | 2024-06-07 | 14 |  |
| 17 | 1.2 | **ROLLOVER-1** | 96d | 2024-03-11 | 2024-06-14 |  |  |
| 18 | 1.2.1 | PACK-&-GO & FILE SETUP | 5d | 2024-03-11 | 2024-03-15 |  |  |
| 19 | 1.2.2 | CAD UPDATES & MODEL UPDATES | 14d | 2024-03-16 | 2024-03-29 | 18 |  |
| 20 | 1.2.3 | CREATE BOM & REVIEW w/ GOOSE | 7d | 2024-03-30 | 2024-04-05 | 19 |  |
| 21 | 1.2.4 | CREATE WATERJET & FABRICATED PART DRAWING FILES | 7d | 2024-04-06 | 2024-04-12 | 20 |  |
| 22 | 1.2.5 | BOM ORDERING | 7d | 2024-04-13 | 2024-04-19 | 21 |  |
| 23 | 1.2.6 | PURCHASED PARTS RECEIVING & STAGING | 7d | 2024-04-20 | 2024-04-26 | 22 |  |
| 24 | 1.2.7 | WELDMENTS & MACHINING | 7d | 2024-04-27 | 2024-05-03 | 23 |  |
| 25 | 1.2.8 | GENERAL ASSEMBLY | 7d | 2024-05-04 | 2024-05-10 | 24 |  |
| 26 | 1.2.9 | WIRE ASSEMBLY | 7d | 2024-05-11 | 2024-05-17 | 25 |  |
| 27 | 1.2.10 | POWER UP & TEST & DEBUG | 7d | 2024-05-18 | 2024-05-24 | 26 |  |
| 28 | 1.2.11 | CYCLE TEST | 7d | 2024-05-25 | 2024-05-31 | 27 |  |
| 29 | 1.2.12 | TEARDOWN & PAINT | 7d | 2024-06-01 | 2024-06-07 | 28 |  |
| 30 | 1.2.13 | DRAWING & MODEL & BOM UPDATES | 14d | 2024-06-01 | 2024-06-14 | 28 |  |
| 31 | 1.2.14 | RE-ASSEMBLE & PREP FOR SHIPMENT | 7d | 2024-06-08 | 2024-06-14 | 29 |  |

| ID | WBS | Task | Duration | Start | Finish | Predecessors |
| --- | --- | --- | --- | --- | --- | --- |
| 32 | 1.3 | **THICKNESS SENSOR-1** | 89d | 2024-05-01 | 2024-07-28 |  |
| 33 | 1.3.1 | PACK-&-GO & FILE SETUP | 5d | 2024-05-01 | 2024-05-05 |  |
| 34 | 1.3.2 | CAD UPDATES & MODEL UPDATES | 7d | 2024-05-06 | 2024-05-12 | 33 |
| 35 | 1.3.3 | CREATE BOM & REVIEW w/ GOOSE | 7d | 2024-05-13 | 2024-05-19 | 34 |
| 36 | 1.3.4 | CREATE WATERJET & FABRICATED PART DRAWING FILES | 7d | 2024-05-20 | 2024-05-26 | 35 |
| 37 | 1.3.5 | BOM ORDERING | 7d | 2024-05-27 | 2024-06-02 | 36 |
| 38 | 1.3.6 | PURCHASED PARTS RECEIVING & STAGING | 7d | 2024-06-03 | 2024-06-09 | 37 |
| 39 | 1.3.7 | WELDMENTS & MACHINING | 7d | 2024-06-10 | 2024-06-16 | 38 |
| 40 | 1.3.8 | GENERAL ASSEMBLY | 7d | 2024-06-17 | 2024-06-23 | 39 |
| 41 | 1.3.9 | WIRE ASSEMBLY | 7d | 2024-06-24 | 2024-06-30 | 40 |
| 42 | 1.3.10 | POWER UP & TEST & DEBUG | 7d | 2024-07-01 | 2024-07-07 | 41 |
| 43 | 1.3.11 | CYCLE TEST | 7d | 2024-07-08 | 2024-07-14 | 42 |
| 44 | 1.3.12 | TEARDOWN & PAINT | 7d | 2024-07-15 | 2024-07-21 | 43 |
| 45 | 1.3.13 | DRAWING & MODEL & BOM UPDATES | 14d | 2024-07-15 | 2024-07-28 | 43 |
| 46 | 1.3.14 | RE-ASSEMBLE & PREP FOR SHIPMENT | 7d | 2024-07-22 | 2024-07-28 | 44 |
| 47 | 1.4 | **ROLLCASE-1** | 98d | 2024-03-11 | 2024-06-16 |  |
| 48 | 1.4.1 | PACK-&-GO & FILE SETUP | 5d | 2024-03-11 | 2024-03-15 |  |
| 49 | 1.4.2 | CAD UPDATES & MODEL UPDATES | 16d | 2024-03-16 | 2024-03-31 | 48 |
| 50 | 1.4.3 | CREATE BOM & REVIEW w/ GOOSE | 7d | 2024-04-01 | 2024-04-07 | 49 |
| 51 | 1.4.4 | CREATE WATERJET & FABRICATED PART DRAWING FILES | 7d | 2024-04-08 | 2024-04-14 | 50 |
| 52 | 1.4.5 | BOM ORDERING | 7d | 2024-04-15 | 2024-04-21 | 51 |
| 53 | 1.4.6 | PURCHASED PARTS RECEIVING & STAGING | 7d | 2024-04-22 | 2024-04-28 | 52 |
| 54 | 1.4.7 | WELDMENTS & MACHINING | 7d | 2024-04-29 | 2024-05-05 | 53 |
| 55 | 1.4.8 | GENERAL ASSEMBLY | 7d | 2024-05-06 | 2024-05-12 | 54 |
| 56 | 1.4.9 | WIRE ASSEMBLY | 7d | 2024-05-13 | 2024-05-19 | 55 |
| 57 | 1.4.10 | POWER UP & TEST & DEBUG | 7d | 2024-05-20 | 2024-05-26 | 56 |
| 58 | 1.4.11 | CYCLE TEST | 7d | 2024-05-27 | 2024-06-02 | 57 |
| 59 | 1.4.12 | TEARDOWN & PAINT | 7d | 2024-06-03 | 2024-06-09 | 58 |
| 60 | 1.4.13 | DRAWING & MODEL & BOM UPDATES | 14d | 2024-06-03 | 2024-06-16 | 58 |
| 61 | 1.4.14 | RE-ASSEMBLE & PREP FOR SHIPMENT | 7d | 2024-06-10 | 2024-06-16 | 59 |

| ID | WBS | Task | Duration | Start | Finish | Predecessors |
| --- | --- | --- | --- | --- | --- | --- |
| 62 | 1.5 | **LASER MOUNT STAND-1** | 89d | 2024-03-25 | 2024-06-21 |  |
| 63 | 1.5.1 | PACK-&-GO & FILE SETUP | 5d | 2024-03-25 | 2024-03-29 |  |
| 64 | 1.5.2 | CAD UPDATES & MODEL UPDATES | 7d | 2024-03-30 | 2024-04-05 | 63 |
| 65 | 1.5.3 | CREATE BOM & REVIEW w/ GOOSE | 7d | 2024-04-06 | 2024-04-12 | 64 |
| 66 | 1.5.4 | CREATE WATERJET & FABRICATED PART DRAWING FILES | 7d | 2024-04-13 | 2024-04-19 | 65 |
| 67 | 1.5.5 | BOM ORDERING | 7d | 2024-04-20 | 2024-04-26 | 66 |
| 68 | 1.5.6 | PURCHASED PARTS RECEIVING & STAGING | 7d | 2024-04-27 | 2024-05-03 | 67 |
| 69 | 1.5.7 | WELDMENTS & MACHINING | 7d | 2024-05-04 | 2024-05-10 | 68 |
| 70 | 1.5.8 | GENERAL ASSEMBLY | 7d | 2024-05-11 | 2024-05-17 | 69 |
| 71 | 1.5.9 | WIRE ASSEMBLY | 7d | 2024-05-18 | 2024-05-24 | 70 |
| 72 | 1.5.10 | POWER UP & TEST & DEBUG | 7d | 2024-05-25 | 2024-05-31 | 71 |
| 73 | 1.5.11 | CYCLE TEST | 7d | 2024-06-01 | 2024-06-07 | 72 |
| 74 | 1.5.12 | TEARDOWN & PAINT | 7d | 2024-06-08 | 2024-06-14 | 73 |
| 75 | 1.5.13 | DRAWING & MODEL & BOM UPDATES | 14d | 2024-06-08 | 2024-06-21 | 73 |
| 76 | 1.5.14 | RE-ASSEMBLE & PREP FOR SHIPMENT | 7d | 2024-06-15 | 2024-06-21 | 74 |
| 77 | 1.6 | **EDGER INFEED CONVEYOR-1** | 89d | 2024-03-18 | 2024-06-14 |  |
| 78 | 1.6.1 | PACK-&-GO & FILE SETUP | 5d | 2024-03-18 | 2024-03-22 |  |
| 79 | 1.6.2 | CAD UPDATES & MODEL UPDATES | 7d | 2024-03-23 | 2024-03-29 | 78 |
| 80 | 1.6.3 | CREATE BOM & REVIEW w/ GOOSE | 7d | 2024-03-30 | 2024-04-05 | 79 |
| 81 | 1.6.4 | CREATE WATERJET & FABRICATED PART DRAWING FILES | 7d | 2024-04-06 | 2024-04-12 | 80 |
| 82 | 1.6.5 | BOM ORDERING | 7d | 2024-04-13 | 2024-04-19 | 81 |
| 83 | 1.6.6 | PURCHASED PARTS RECEIVING & STAGING | 7d | 2024-04-20 | 2024-04-26 | 82 |
| 84 | 1.6.7 | WELDMENTS & MACHINING | 7d | 2024-04-27 | 2024-05-03 | 83 |
| 85 | 1.6.8 | GENERAL ASSEMBLY | 7d | 2024-05-04 | 2024-05-10 | 84 |
| 86 | 1.6.9 | WIRE ASSEMBLY | 7d | 2024-05-11 | 2024-05-17 | 85 |
| 87 | 1.6.10 | POWER UP & TEST & DEBUG | 7d | 2024-05-18 | 2024-05-24 | 86 |
| 88 | 1.6.11 | CYCLE TEST | 7d | 2024-05-25 | 2024-05-31 | 87 |
| 89 | 1.6.12 | TEARDOWN & PAINT | 7d | 2024-06-01 | 2024-06-07 | 88 |
| 90 | 1.6.13 | DRAWING & MODEL & BOM UPDATES | 14d | 2024-06-01 | 2024-06-14 | 88 |
| 91 | 1.6.14 | RE-ASSEMBLE & PREP FOR SHIPMENT | 7d | 2024-06-08 | 2024-06-14 | 89 |

| ID | WBS | Task | Duration | Start | Finish | Predecessors |
| --- | --- | --- | --- | --- | --- | --- |
| 92 | 1.7 | **EDGER BANDSAW-1** | 138d | 2024-03-18 | 2024-08-02 |  |
| 93 | 1.7.1 | PACK-&-GO & FILE SETUP | 5d | 2024-03-18 | 2024-03-22 |  |
| 94 | 1.7.2 | CAD UPDATES & MODEL UPDATES | 21d | 2024-03-23 | 2024-04-12 | 93 |
| 95 | 1.7.3 | CREATE BOM & REVIEW w/ GOOSE | 12d | 2024-04-13 | 2024-04-24 | 94 |
| 96 | 1.7.4 | CREATE WATERJET & FABRICATED PART DRAWING FILES | 7d | 2024-04-25 | 2024-05-01 | 95 |
| 97 | 1.7.5 | BOM ORDERING | 13d | 2024-05-02 | 2024-05-14 | 96 |
| 98 | 1.7.6 | PURCHASED PARTS RECEIVING & STAGING | 13d | 2024-05-15 | 2024-05-27 | 97 |
| 99 | 1.7.7 | WELDMENTS & MACHINING | 8d | 2024-05-28 | 2024-06-04 | 98 |
| 100 | 1.7.8 | GENERAL ASSEMBLY | 10d | 2024-06-05 | 2024-06-14 | 99 |
| 101 | 1.7.9 | WIRE ASSEMBLY | 10d | 2024-06-15 | 2024-06-24 | 100 |
| 102 | 1.7.10 | POWER UP & TEST & DEBUG | 9d | 2024-06-25 | 2024-07-03 | 101 |
| 103 | 1.7.11 | CYCLE TEST | 12d | 2024-07-04 | 2024-07-15 | 102 |
| 104 | 1.7.12 | TEARDOWN & PAINT | 9d | 2024-07-16 | 2024-07-24 | 103 |
| 105 | 1.7.13 | DRAWING & MODEL & BOM UPDATES | 16d | 2024-07-16 | 2024-07-31 | 103 |
| 106 | 1.7.14 | RE-ASSEMBLE & PREP FOR SHIPMENT | 9d | 2024-07-25 | 2024-08-02 | 104 |
| 107 | 1.8 | **EDGER OUTFEED CONVEYOR-1** | 116d | 2024-03-11 | 2024-07-04 |  |
| 108 | 1.8.1 | PACK-&-GO & FILE SETUP | 5d | 2024-03-11 | 2024-03-15 |  |
| 109 | 1.8.2 | CAD UPDATES & MODEL UPDATES | 17d | 2024-03-16 | 2024-04-01 | 108 |
| 110 | 1.8.3 | CREATE BOM & REVIEW w/ GOOSE | 7d | 2024-04-02 | 2024-04-08 | 109 |
| 111 | 1.8.4 | CREATE WATERJET & FABRICATED PART DRAWING FILES | 7d | 2024-04-09 | 2024-04-15 | 110 |
| 112 | 1.8.5 | BOM ORDERING | 7d | 2024-04-16 | 2024-04-22 | 111 |
| 113 | 1.8.6 | PURCHASED PARTS RECEIVING & STAGING | 7d | 2024-04-23 | 2024-04-29 | 112 |
| 114 | 1.8.7 | WELDMENTS & MACHINING | 9d | 2024-04-30 | 2024-05-08 | 113 |
| 115 | 1.8.8 | GENERAL ASSEMBLY | 11d | 2024-05-09 | 2024-05-19 | 114 |
| 116 | 1.8.9 | WIRE ASSEMBLY | 7d | 2024-05-20 | 2024-05-26 | 115 |
| 117 | 1.8.10 | POWER UP & TEST & DEBUG | 9d | 2024-05-27 | 2024-06-04 | 116 |
| 118 | 1.8.11 | CYCLE TEST | 8d | 2024-06-05 | 2024-06-12 | 117 |
| 119 | 1.8.12 | TEARDOWN & PAINT | 12d | 2024-06-13 | 2024-06-24 | 118 |
| 120 | 1.8.13 | DRAWING & MODEL & BOM UPDATES | 18d | 2024-06-13 | 2024-06-30 | 118 |
| 121 | 1.8.14 | RE-ASSEMBLE & PREP FOR SHIPMENT | 10d | 2024-06-25 | 2024-07-04 | 119 |

| ID | WBS | Task | Type | Duration | Start | Finish | Predecessors |
| --- | --- | --- | --- | --- | --- | --- | --- |
| 122 | 1.9 | **INSTALL LINE-1** |  | 21d | 2024-12-01 | 2024-12-21 |  |
| 123 | 1.9.1 | LEAVE FOR INSTALL | milestone | 0d | 2024-12-01 | 2024-12-01 |  |
| 124 | 1.9.2 | ARRIVE & UNLOAD |  | 2d | 2024-12-01 | 2024-12-02 | 123 |
| 125 | 1.9.3 | TEAROUT OLD EQUIPMENT |  | 3d | 2024-12-03 | 2024-12-05 | 124 |
| 126 | 1.9.4 | INSTALL NEW EQUIPMENT |  | 7d | 2024-12-06 | 2024-12-12 | 125 |
| 127 | 1.9.5 | POWER UP NEW EQUIPMENT |  | 3d | 2024-12-13 | 2024-12-15 | 126 |
| 128 | 1.9.6 | TEST & DEBUG |  | 6d | 2024-12-16 | 2024-12-21 | 127 |
| 129 | 1.9.7 | INSTALL APPROVAL AND COMPLETION | milestone | 0d | 2024-12-22 | 2024-12-22 | 128 |
| 130 | 2 | **SAL EDGING LINE-2** |  | 286d | 2024-03-11 | 2024-12-21 |  |
| 131 | 2.1 | **RESAW BRUSH-2** |  | 89d | 2024-03-11 | 2024-06-07 |  |
| 132 | 2.1.1 | PACK-&-GO & FILE SETUP |  | 5d | 2024-03-11 | 2024-03-15 |  |
| 133 | 2.1.2 | CAD UPDATES & MODEL UPDATES |  | 7d | 2024-03-16 | 2024-03-22 | 132 |
| 134 | 2.1.3 | CREATE BOM & REVIEW w/ GOOSE |  | 7d | 2024-03-23 | 2024-03-29 | 133 |
| 135 | 2.1.4 | CREATE WATERJET & FABRICATED PART DRAWING FILES |  | 7d | 2024-03-30 | 2024-04-05 | 134 |
| 136 | 2.1.5 | BOM ORDERING |  | 7d | 2024-04-06 | 2024-04-12 | 135 |
| 137 | 2.1.6 | PURCHASED PARTS RECEIVING & STAGING |  | 7d | 2024-04-13 | 2024-04-19 | 136 |
| 138 | 2.1.7 | WELDMENTS & MACHINING |  | 7d | 2024-04-20 | 2024-04-26 | 137 |
| 139 | 2.1.8 | GENERAL ASSEMBLY |  | 7d | 2024-04-27 | 2024-05-03 | 138 |
| 140 | 2.1.9 | WIRE ASSEMBLY |  | 7d | 2024-05-04 | 2024-05-10 | 139 |
| 141 | 2.1.10 | POWER UP & TEST & DEBUG |  | 7d | 2024-05-11 | 2024-05-17 | 140 |
| 142 | 2.1.11 | CYCLE TEST |  | 7d | 2024-05-18 | 2024-05-24 | 141 |
| 143 | 2.1.12 | TEARDOWN & PAINT |  | 7d | 2024-05-25 | 2024-05-31 | 142 |
| 144 | 2.1.13 | DRAWING & MODEL & BOM UPDATES |  | 14d | 2024-05-25 | 2024-06-07 | 142 |
| 145 | 2.1.14 | RE-ASSEMBLE & PREP FOR SHIPMENT |  | 7d | 2024-06-01 | 2024-06-07 | 143 |

| ID | WBS | Task | Duration | Start | Finish | Predecessors |
| --- | --- | --- | --- | --- | --- | --- |
| 146 | 2.2 | **ROLLOVER-2** | 96d | 2024-03-11 | 2024-06-14 |  |
| 147 | 2.2.1 | PACK-&-GO & FILE SETUP | 5d | 2024-03-11 | 2024-03-15 |  |
| 148 | 2.2.2 | CAD UPDATES & MODEL UPDATES | 14d | 2024-03-16 | 2024-03-29 | 147 |
| 149 | 2.2.3 | CREATE BOM & REVIEW w/ GOOSE | 7d | 2024-03-30 | 2024-04-05 | 148 |
| 150 | 2.2.4 | CREATE WATERJET & FABRICATED PART DRAWING FILES | 7d | 2024-04-06 | 2024-04-12 | 149 |
| 151 | 2.2.5 | BOM ORDERING | 7d | 2024-04-13 | 2024-04-19 | 150 |
| 152 | 2.2.6 | PURCHASED PARTS RECEIVING & STAGING | 7d | 2024-04-20 | 2024-04-26 | 151 |
| 153 | 2.2.7 | WELDMENTS & MACHINING | 7d | 2024-04-27 | 2024-05-03 | 152 |
| 154 | 2.2.8 | GENERAL ASSEMBLY | 7d | 2024-05-04 | 2024-05-10 | 153 |
| 155 | 2.2.9 | WIRE ASSEMBLY | 7d | 2024-05-11 | 2024-05-17 | 154 |
| 156 | 2.2.10 | POWER UP & TEST & DEBUG | 7d | 2024-05-18 | 2024-05-24 | 155 |
| 157 | 2.2.11 | CYCLE TEST | 7d | 2024-05-25 | 2024-05-31 | 156 |
| 158 | 2.2.12 | TEARDOWN & PAINT | 7d | 2024-06-01 | 2024-06-07 | 157 |
| 159 | 2.2.13 | DRAWING & MODEL & BOM UPDATES | 14d | 2024-06-01 | 2024-06-14 | 157 |
| 160 | 2.2.14 | RE-ASSEMBLE & PREP FOR SHIPMENT | 7d | 2024-06-08 | 2024-06-14 | 158 |
| 161 | 2.3 | **THICKNESS SENSOR-2** | 89d | 2024-05-01 | 2024-07-28 |  |
| 162 | 2.3.1 | PACK-&-GO & FILE SETUP | 5d | 2024-05-01 | 2024-05-05 |  |
| 163 | 2.3.2 | CAD UPDATES & MODEL UPDATES | 7d | 2024-05-06 | 2024-05-12 | 162 |
| 164 | 2.3.3 | CREATE BOM & REVIEW w/ GOOSE | 7d | 2024-05-13 | 2024-05-19 | 163 |
| 165 | 2.3.4 | CREATE WATERJET & FABRICATED PART DRAWING FILES | 7d | 2024-05-20 | 2024-05-26 | 164 |
| 166 | 2.3.5 | BOM ORDERING | 7d | 2024-05-27 | 2024-06-02 | 165 |
| 167 | 2.3.6 | PURCHASED PARTS RECEIVING & STAGING | 7d | 2024-06-03 | 2024-06-09 | 166 |
| 168 | 2.3.7 | WELDMENTS & MACHINING | 7d | 2024-06-10 | 2024-06-16 | 167 |
| 169 | 2.3.8 | GENERAL ASSEMBLY | 7d | 2024-06-17 | 2024-06-23 | 168 |
| 170 | 2.3.9 | WIRE ASSEMBLY | 7d | 2024-06-24 | 2024-06-30 | 169 |
| 171 | 2.3.10 | POWER UP & TEST & DEBUG | 7d | 2024-07-01 | 2024-07-07 | 170 |
| 172 | 2.3.11 | CYCLE TEST | 7d | 2024-07-08 | 2024-07-14 | 171 |
| 173 | 2.3.12 | TEARDOWN & PAINT | 7d | 2024-07-15 | 2024-07-21 | 172 |
| 174 | 2.3.13 | DRAWING & MODEL & BOM UPDATES | 14d | 2024-07-15 | 2024-07-28 | 172 |
| 175 | 2.3.14 | RE-ASSEMBLE & PREP FOR SHIPMENT | 7d | 2024-07-22 | 2024-07-28 | 173 |

| ID | WBS | Task | Duration | Start | Finish | Predecessors |
| --- | --- | --- | --- | --- | --- | --- |
| 176 | 2.4 | **ROLLCASE-2** | 98d | 2024-03-11 | 2024-06-16 |  |
| 177 | 2.4.1 | PACK-&-GO & FILE SETUP | 5d | 2024-03-11 | 2024-03-15 |  |
| 178 | 2.4.2 | CAD UPDATES & MODEL UPDATES | 16d | 2024-03-16 | 2024-03-31 | 177 |
| 179 | 2.4.3 | CREATE BOM & REVIEW w/ GOOSE | 7d | 2024-04-01 | 2024-04-07 | 178 |
| 180 | 2.4.4 | CREATE WATERJET & FABRICATED PART DRAWING FILES | 7d | 2024-04-08 | 2024-04-14 | 179 |
| 181 | 2.4.5 | BOM ORDERING | 7d | 2024-04-15 | 2024-04-21 | 180 |
| 182 | 2.4.6 | PURCHASED PARTS RECEIVING & STAGING | 7d | 2024-04-22 | 2024-04-28 | 181 |
| 183 | 2.4.7 | WELDMENTS & MACHINING | 7d | 2024-04-29 | 2024-05-05 | 182 |
| 184 | 2.4.8 | GENERAL ASSEMBLY | 7d | 2024-05-06 | 2024-05-12 | 183 |
| 185 | 2.4.9 | WIRE ASSEMBLY | 7d | 2024-05-13 | 2024-05-19 | 184 |
| 186 | 2.4.10 | POWER UP & TEST & DEBUG | 7d | 2024-05-20 | 2024-05-26 | 185 |
| 187 | 2.4.11 | CYCLE TEST | 7d | 2024-05-27 | 2024-06-02 | 186 |
| 188 | 2.4.12 | TEARDOWN & PAINT | 7d | 2024-06-03 | 2024-06-09 | 187 |
| 189 | 2.4.13 | DRAWING & MODEL & BOM UPDATES | 14d | 2024-06-03 | 2024-06-16 | 187 |
| 190 | 2.4.14 | RE-ASSEMBLE & PREP FOR SHIPMENT | 7d | 2024-06-10 | 2024-06-16 | 188 |
| 191 | 2.5 | **LASER MOUNT STAND-2** | 89d | 2024-03-25 | 2024-06-21 |  |
| 192 | 2.5.1 | PACK-&-GO & FILE SETUP | 5d | 2024-03-25 | 2024-03-29 |  |
| 193 | 2.5.2 | CAD UPDATES & MODEL UPDATES | 7d | 2024-03-30 | 2024-04-05 | 192 |
| 194 | 2.5.3 | CREATE BOM & REVIEW w/ GOOSE | 7d | 2024-04-06 | 2024-04-12 | 193 |
| 195 | 2.5.4 | CREATE WATERJET & FABRICATED PART DRAWING FILES | 7d | 2024-04-13 | 2024-04-19 | 194 |
| 196 | 2.5.5 | BOM ORDERING | 7d | 2024-04-20 | 2024-04-26 | 195 |
| 197 | 2.5.6 | PURCHASED PARTS RECEIVING & STAGING | 7d | 2024-04-27 | 2024-05-03 | 196 |
| 198 | 2.5.7 | WELDMENTS & MACHINING | 7d | 2024-05-04 | 2024-05-10 | 197 |
| 199 | 2.5.8 | GENERAL ASSEMBLY | 7d | 2024-05-11 | 2024-05-17 | 198 |
| 200 | 2.5.9 | WIRE ASSEMBLY | 7d | 2024-05-18 | 2024-05-24 | 199 |
| 201 | 2.5.10 | POWER UP & TEST & DEBUG | 7d | 2024-05-25 | 2024-05-31 | 200 |
| 202 | 2.5.11 | CYCLE TEST | 7d | 2024-06-01 | 2024-06-07 | 201 |
| 203 | 2.5.12 | TEARDOWN & PAINT | 7d | 2024-06-08 | 2024-06-14 | 202 |
| 204 | 2.5.13 | DRAWING & MODEL & BOM UPDATES | 14d | 2024-06-08 | 2024-06-21 | 202 |
| 205 | 2.5.14 | RE-ASSEMBLE & PREP FOR SHIPMENT | 7d | 2024-06-15 | 2024-06-21 | 203 |

| ID | WBS | Task | Duration | Start | Finish | Predecessors |
| --- | --- | --- | --- | --- | --- | --- |
| 206 | 2.6 | **EDGER INFEED CONVEYOR-2** | 89d | 2024-03-18 | 2024-06-14 |  |
| 207 | 2.6.1 | PACK-&-GO & FILE SETUP | 5d | 2024-03-18 | 2024-03-22 |  |
| 208 | 2.6.2 | CAD UPDATES & MODEL UPDATES | 7d | 2024-03-23 | 2024-03-29 | 207 |
| 209 | 2.6.3 | CREATE BOM & REVIEW w/ GOOSE | 7d | 2024-03-30 | 2024-04-05 | 208 |
| 210 | 2.6.4 | CREATE WATERJET & FABRICATED PART DRAWING FILES | 7d | 2024-04-06 | 2024-04-12 | 209 |
| 211 | 2.6.5 | BOM ORDERING | 7d | 2024-04-13 | 2024-04-19 | 210 |
| 212 | 2.6.6 | PURCHASED PARTS RECEIVING & STAGING | 7d | 2024-04-20 | 2024-04-26 | 211 |
| 213 | 2.6.7 | WELDMENTS & MACHINING | 7d | 2024-04-27 | 2024-05-03 | 212 |
| 214 | 2.6.8 | GENERAL ASSEMBLY | 7d | 2024-05-04 | 2024-05-10 | 213 |
| 215 | 2.6.9 | WIRE ASSEMBLY | 7d | 2024-05-11 | 2024-05-17 | 214 |
| 216 | 2.6.10 | POWER UP & TEST & DEBUG | 7d | 2024-05-18 | 2024-05-24 | 215 |
| 217 | 2.6.11 | CYCLE TEST | 7d | 2024-05-25 | 2024-05-31 | 216 |
| 218 | 2.6.12 | TEARDOWN & PAINT | 7d | 2024-06-01 | 2024-06-07 | 217 |
| 219 | 2.6.13 | DRAWING & MODEL & BOM UPDATES | 14d | 2024-06-01 | 2024-06-14 | 217 |
| 220 | 2.6.14 | RE-ASSEMBLE & PREP FOR SHIPMENT | 7d | 2024-06-08 | 2024-06-14 | 218 |
| 221 | 2.7 | **EDGER BANDSAW-2** | 138d | 2024-03-18 | 2024-08-02 |  |
| 222 | 2.7.1 | PACK-&-GO & FILE SETUP | 5d | 2024-03-18 | 2024-03-22 |  |
| 223 | 2.7.2 | CAD UPDATES & MODEL UPDATES | 21d | 2024-03-23 | 2024-04-12 | 222 |
| 224 | 2.7.3 | CREATE BOM & REVIEW w/ GOOSE | 12d | 2024-04-13 | 2024-04-24 | 223 |
| 225 | 2.7.4 | CREATE WATERJET & FABRICATED PART DRAWING FILES | 7d | 2024-04-25 | 2024-05-01 | 224 |
| 226 | 2.7.5 | BOM ORDERING | 13d | 2024-05-02 | 2024-05-14 | 225 |
| 227 | 2.7.6 | PURCHASED PARTS RECEIVING & STAGING | 13d | 2024-05-15 | 2024-05-27 | 226 |
| 228 | 2.7.7 | WELDMENTS & MACHINING | 8d | 2024-05-28 | 2024-06-04 | 227 |
| 229 | 2.7.8 | GENERAL ASSEMBLY | 10d | 2024-06-05 | 2024-06-14 | 228 |
| 230 | 2.7.9 | WIRE ASSEMBLY | 10d | 2024-06-15 | 2024-06-24 | 229 |
| 231 | 2.7.10 | POWER UP & TEST & DEBUG | 9d | 2024-06-25 | 2024-07-03 | 230 |
| 232 | 2.7.11 | CYCLE TEST | 12d | 2024-07-04 | 2024-07-15 | 231 |
| 233 | 2.7.12 | TEARDOWN & PAINT | 9d | 2024-07-16 | 2024-07-24 | 232 |
| 234 | 2.7.13 | DRAWING & MODEL & BOM UPDATES | 16d | 2024-07-16 | 2024-07-31 | 232 |
| 235 | 2.7.14 | RE-ASSEMBLE & PREP FOR SHIPMENT | 9d | 2024-07-25 | 2024-08-02 | 233 |

| ID | WBS | Task | Type | Duration | Start | Finish | Predecessors |
| --- | --- | --- | --- | --- | --- | --- | --- |
| 236 | 2.8 | **EDGER OUTFEED CONVEYOR-2** |  | 116d | 2024-03-11 | 2024-07-04 |  |
| 237 | 2.8.1 | PACK-&-GO & FILE SETUP |  | 5d | 2024-03-11 | 2024-03-15 |  |
| 238 | 2.8.2 | CAD UPDATES & MODEL UPDATES |  | 17d | 2024-03-16 | 2024-04-01 | 237 |
| 239 | 2.8.3 | CREATE BOM & REVIEW w/ GOOSE |  | 7d | 2024-04-02 | 2024-04-08 | 238 |
| 240 | 2.8.4 | CREATE WATERJET & FABRICATED PART DRAWING FILES |  | 7d | 2024-04-09 | 2024-04-15 | 239 |
| 241 | 2.8.5 | BOM ORDERING |  | 7d | 2024-04-16 | 2024-04-22 | 240 |
| 242 | 2.8.6 | PURCHASED PARTS RECEIVING & STAGING |  | 7d | 2024-04-23 | 2024-04-29 | 241 |
| 243 | 2.8.7 | WELDMENTS & MACHINING |  | 9d | 2024-04-30 | 2024-05-08 | 242 |
| 244 | 2.8.8 | GENERAL ASSEMBLY |  | 11d | 2024-05-09 | 2024-05-19 | 243 |
| 245 | 2.8.9 | WIRE ASSEMBLY |  | 7d | 2024-05-20 | 2024-05-26 | 244 |
| 246 | 2.8.10 | POWER UP & TEST & DEBUG |  | 9d | 2024-05-27 | 2024-06-04 | 245 |
| 247 | 2.8.11 | CYCLE TEST |  | 8d | 2024-06-05 | 2024-06-12 | 246 |
| 248 | 2.8.12 | TEARDOWN & PAINT |  | 12d | 2024-06-13 | 2024-06-24 | 247 |
| 249 | 2.8.13 | DRAWING & MODEL & BOM UPDATES |  | 18d | 2024-06-13 | 2024-06-30 | 247 |
| 250 | 2.8.14 | RE-ASSEMBLE & PREP FOR SHIPMENT |  | 10d | 2024-06-25 | 2024-07-04 | 248 |
| 251 | 2.9 | **INSTALL LINE-2** |  | 21d | 2024-12-01 | 2024-12-21 |  |
| 252 | 2.9.1 | LEAVE FOR INSTALL | milestone | 0d | 2024-12-01 | 2024-12-01 |  |
| 253 | 2.9.2 | ARRIVE & UNLOAD |  | 2d | 2024-12-01 | 2024-12-02 | 252 |
| 254 | 2.9.3 | TEAROUT OLD EQUIPMENT |  | 3d | 2024-12-03 | 2024-12-05 | 253 |
| 255 | 2.9.4 | INSTALL NEW EQUIPMENT |  | 7d | 2024-12-06 | 2024-12-12 | 254 |
| 256 | 2.9.5 | POWER UP NEW EQUIPMENT |  | 3d | 2024-12-13 | 2024-12-15 | 255 |
| 257 | 2.9.6 | TEST & DEBUG |  | 6d | 2024-12-16 | 2024-12-21 | 256 |
| 258 | 2.9.7 | INSTALL APPROVAL AND COMPLETION | milestone | 0d | 2024-12-22 | 2024-12-22 | 257 |
| 259 | 3 | STEVENSON BUILDING ADDITION CONSTRUCTION |  | 184d | 2024-04-01 | 2024-10-01 |  |

| ID | WBS | Task | Type | Duration | Start | Finish | Predecessors |
| --- | --- | --- | --- | --- | --- | --- | --- |
| 260 | 4 | **ISC-CB-AUTOSTACKER** |  | 5d | 2024-03-11 | 2024-03-15 |  |
| 261 | 4.1 | AUTO-STACKER - DUAL KEYENCE SENSOR BRACKET FOR TOLOMATIC HEAD |  | 5d | 2024-03-11 | 2024-03-15 |  |
| 262 | 5 | **ISC-CB-ACCUMULATOR** |  | 56d | 2024-03-13 | 2024-05-07 |  |
| 263 | 5.1 | DESIGN REVIEW FOR ACCUMULATOR POP-UP | milestone | 0d | 2024-03-13 | 2024-03-13 |  |
| 264 | 5.2 | FINAL 3D DESIGN |  | 9d | 2024-03-13 | 2024-03-21 | 263 |
| 265 | 5.3 | FINAL DESIGN REVIEW | milestone | 0d | 2024-03-22 | 2024-03-22 | 264 |
| 266 | 5.4 | PROPERTIES & BOM CREATION & REVIEW |  | 4d | 2024-03-22 | 2024-03-25 | 265 |
| 267 | 5.5 | CREATE ASSEMBLY & DETAIL DRAWINGS |  | 5d | 2024-03-26 | 2024-03-30 | 266 |
| 268 | 5.6 | RELEASE BOM | milestone | 0d | 2024-03-26 | 2024-03-26 | 266 |
| 269 | 5.7 | PURCHASED & WATERJET PARTS RECIEVING |  | 14d | 2024-03-26 | 2024-04-08 | 268 |
| 270 | 5.8 | MACHINED PARTS & WELDMENTS |  | 5d | 2024-04-09 | 2024-04-13 | 269 |
| 271 | 5.9 | GENERAL ASSEMBLY |  | 6d | 2024-04-14 | 2024-04-19 | 270 |
| 272 | 5.10 | TEST & DEBUG |  | 8d | 2024-04-20 | 2024-04-27 | 271 |
| 273 | 5.11 | TEARDOWN & PAINT |  | 5d | 2024-04-28 | 2024-05-02 | 272 |
| 274 | 5.12 | MODEL & DRAWING & BOM UPDATES |  | 5d | 2024-04-28 | 2024-05-02 | 272 |
| 275 | 5.13 | FINAL ASSEMBLY & PREP FOR SHIPMENT |  | 5d | 2024-05-03 | 2024-05-07 | 273 |
| 276 | 6 | **ISC-CB-CONCEPT WHEEL SORTER** |  | -11d | 2024-03-13 | 2024-03-13 |  |
| 277 | 6.1 | DESIGN REVIEW FOR WHEEL SORTER | milestone | 0d | 2024-03-13 | 2024-03-13 |  |
| 278 | 7 | **ISC-CB-CONCEPT ROLLOVER** |  | 30d | 2024-03-01 | 2024-03-30 |  |
| 279 | 7.1 | ROUGH 3D DESIGN CONCEPT |  | 30d | 2024-03-01 | 2024-03-30 |  |
| 280 | 8 | **ISC-CB-90° FLAT ROLLER CONVEYOR** |  | -11d | 2024-03-13 | 2024-03-13 |  |
| 281 | 8.1 | DESIGN REVIEW FOR 90° FLAT ROLLER CONVEYOR | milestone | 0d | 2024-03-13 | 2024-03-13 |  |
| 282 | 9 | **ISC-CB-STRAIGHT ROLLER CONVEYOR** |  | -11d | 2024-03-13 | 2024-03-13 |  |
| 283 | 9.1 | DESIGN REVIEW FOR STRAIGHT ROLLER CONVEYOR | milestone | 0d | 2024-03-13 | 2024-03-13 |  |
